# MICE HALL INSTALLATION SCHEDULE

Schedule from MS Project, 2008-09-01 to 2015-04-03, costs in £, A marks actual dates.
Daresbury Laboratory

## Calendars

- Standard: Mon-Fri 08:00-12:00, 13:00-17:00; Sat-Sun off. Exceptions (off unless hours are given): 2011-07-05 to 2011-08-12, 2011-11-15 to 2011-12-22.
- ISIS Run Cycle: Mon-Fri 08:00-12:00, 13:00-17:00; Sat-Sun off.
- Shipping: Mon-Fri 08:00-12:00, 13:00-17:00; Sat-Sun off.

## Resources

| Resource | Group | Unit | Rate |
| --- | --- | --- | --- |
| N.Rimmer |  |  |  |
| A.Moss |  |  |  |
| Vac Lab |  |  |  |
| W Spensley |  |  |  |
| W.Spensley |  |  |  |
| Electrical Engineer |  |  |  |
| Electrical Designer |  |  |  |
| Electrical Technician |  |  |  |
| Elec Technician |  |  |  |
| Elec Engineer |  |  |  |
| Mech Technician |  |  |  |
| RF Engineer |  |  |  |
| Mech Technician(75%) |  |  |  |
| RF Engineer(50%) |  |  |  |
| Tim Hayler | STFC |  | 59.26 |
| Andy Lintern | STFC |  | 47.23 |
| Peter Lau | Oxford |  | 23.57 |
| Geoff Barber | Imperial |  |  |
| Mike Bell | STFC |  | 37.76 |
| Eamonn Capocci | STFC |  | 37.76 |
| Craig McWaters | STFC |  | 47.23 |
| Merit1 | Merit |  | 30 |
| Merit2 | Merit |  | 30 |
| Merit3 | Merit |  | 30 |
| Designer (STFC) | STFC |  | 47.23 |
| Roger Hare | Imperial |  |  |
| Ken Long | Imperial |  |  |
| Paul Kyberd |  |  | 49.38 |
| Malcolm Ellis |  |  |  |
| Henry Nebrensky |  |  |  |
| David Forrest |  |  |  |
| Paul Soler |  |  |  |
| Adam Dobbs |  |  | 11.74 |
| Peter Dornan | Imperial |  |  |
| James Leaver |  |  |  |
| Marco Appollonio |  |  |  |
| Becky Seviour |  |  |  |
| Ray Gamet |  |  |  |
| John Cobb |  |  |  |
| Mark Raynor |  |  |  |
| Chris Booth |  |  |  |
| Paul Hodgson |  |  |  |
| Paul Smith |  |  |  |
| David Adey |  |  | 4.79 |
| Student |  | & | 15000 |
| Research Assistant |  |  | 46.78 |
| John Back | Warwick |  |  |
| Stewart | Warwick |  |  |
| Project Manager |  |  | 47 |
| STFC |  |  | 47.23 |
| Andy Nichols |  |  | 72.14 |
| Willie Spensley |  |  | 37 |
| Steve Griffiths |  |  | 72.14 |
| Jason Tarrant |  |  | 59.26 |
| Pierrick Hanlet |  |  |  |
| PH's Students |  |  |  |
| Jean-Sebastien Graulich |  |  |  |
| Mike Courthold |  |  | 59.26 |
| miceiocpc2 |  |  | 500 |
| miceecserv2 |  |  | 2000 |
| miceopipc2 |  |  | 555 |
| miceopipc3 |  |  | 555 |
| Steve Virostek | LBL |  |  |
| Allan DeMello | LBL |  |  |
| Matt Hills | STFC |  | 47.23 |
| Merit Staff (three people) |  |  | 90 |
| RFCC floor support |  |  | 35000 |
| AFC floor support |  |  | 35000 |
| Survey effort |  |  | 47.23 |
| INFN staff |  |  | 47.23 |
| Bolts & hardware |  |  | 2000 |
| Flanges & valves |  |  | 5000 |
| RF waveguide hardware |  |  | 50000 |
| AFC #3 cost |  |  | 356000 |
| Andy Moss |  |  | 60.98 |
| RF Engineer (DL) |  |  | 47.23 |
| Bellows |  |  | 10000 |
| LH2 system #3 |  |  |  |
| Tom Bradshaw | STFC |  | 88.89 |
| Wing Lau | OU |  |  |
| Mech tech (OU) | OU |  |  |
| Elec tech (OU) | OU |  |  |
| Post Doc (OU) | OU |  | 46.87 |
| John Tacon | OU |  |  |
| Dawson | OU |  |  |
| Electrical Engineer (DL) | DL |  | 47.23 |
| Electrical Designer (DL) | DL |  | 47.23 |
| Electrical Technician (DL) | DL |  | 47.23 |
| Mech Technician (DL) | DL |  | 47.23 |
| RF Engineer (DL) | DL |  | 47.23 |
| STG (obsolete) |  |  | 46 |
| Excel (obsolete) |  |  | 46 |
| MET |  |  | 46 |
| TEC |  |  | 46 |
| SHEFF |  |  | 46 |
| OM (obsolete) |  |  | 46 |
| Harry (obsolete) |  |  | 46 |
| EMcC (obsolete) |  |  | 46 |
| MG |  |  | 46 |
| Richard (obsolete) |  |  | 40.18 |
| Chris |  |  | 64.2 |
| Daresbury |  |  | 47.23 |
| Paul |  |  | 34.82 |
| Sheffield Workshop |  |  | 46.22 |
| Nick Bulmer |  |  | 40 |
| Controls Technician (DL) |  |  | 47.23 |
| Mike Tacon |  |  | 45 |
| Mech Technician (STFC) |  |  | 45 |
| Blackmore |  |  | 45 |
| Phil Warburton |  |  | 47.23 |
| Ian Mullacrane |  |  | 59.26 |
| David Matthewson |  |  | 53.78 |
| Contractor (OPUS) |  |  | 30 |
| Electrical Technician (STFC) |  |  | 47.23 |
| Stephen Watson |  |  | 37.76 |
| Cryo Technician (STFC) |  |  | 47.23 |
| Malcolm Ellis (FY10/11) |  |  | 48.51 |
| Paul Kyberd (FY10/11) |  |  |  |
| Henry Nebrensky (FY10/11) |  |  | 35.46 |
| Paul Soler (FY10/11) |  |  | 22.09 |
| James Leaver (FY10/11) |  |  | 24.92 |
| Ken Long (FY10/11) |  |  | 130.51 |
| Marco Appollonio (FY10/11) |  |  | 124.59 |
| John Cobb (FY10/11) |  |  | 18.52 |
| Chris Booth (FY10/11) |  |  | 22.78 |
| Paul Hodgson (FY10/11) |  |  | 88.72 |
| Paul Smith (FY10/11) |  |  | 52.71 |
| John Back (FY10/11) |  |  | 21.13 |
| Stewart (FY10/11) |  |  | 182.1 |
| Peter Dornan (FY10/11) |  |  | 1.02 |
| Geoff Barber (FY2010/11) |  |  | 17.02 |
| Roger Hare (FY2010/11) |  |  | 2.44 |
| Wing Lau (FY2010/11) |  |  | 14.41 |
| Mtech |  |  | 45 |
| Dawson (FY2010/11) |  |  | 7.53 |
| David Forrest (FY2010/11) |  |  | 8.63 |
| Brian Martlew |  |  | 72.14 |
| Roy Preece |  |  | 59.26 |
| W Spensley / Merrit |  |  | 180550 |
| Mary Shrewry |  |  | 45.59 |
| Alan Grant |  |  | 72.14 |
| Vishal Francis |  |  | 59.26 |
| System Engineer |  |  | 59.26 |
| STEP V - TIARA |  |  |  |
| RF System |  |  |  |
| Alan Muir |  |  |  |
| Gordon Stanford |  |  |  |
| Cryo Technician |  |  |  |
| Hyrogen |  |  |  |
| Hydrogen System |  |  |  |
| Electrical Infrastucture |  |  |  |
| Mechanical Infrastructure |  |  |  |
| Step IV |  |  |  |
| Step V |  |  |  |
| StepVI |  |  |  |
| EMR |  |  |  |
| TOF |  |  |  |
| Mechanical Integration |  |  |  |
| Focus Coils |  |  |  |
| Spectrometer |  |  |  |
| Milestones |  |  |  |
| Step VI |  |  |  |
| ISIS Run Cycle |  |  |  |
| Shipping |  |  |  |
| Pre Installation Work |  |  |  |
| Installation |  |  |  |
| Commissioning |  |  |  |

## Schedule

| ID | WBS | Task | Type | Duration | Start | Finish | Predecessors | Complete | Remaining | Baseline start | Baseline finish | Baseline duration | Total slack | Constraint | Resources | Work | Cost |
| --- | --- | --- | --- | --- | --- | --- | --- | --- | --- | --- | --- | --- | --- | --- | --- | --- | --- |
| 1 | 1 | MICE HALL INSTALLATION SCHEDULE | milestone | 0d | 2008-09-01 A | 2008-09-01 A |  | 100% |  |  |  |  |  |  |  |  |  |
| 3 | 2 | **Milestones - Top Level** |  | 1378d | 2009-10-05 A | 2015-04-03 |  |  | 1378d |  |  |  | 0d |  | Milestones | 30984h | 1,500 |
| 4 | 2.1 | **Mechanical Integration** |  | 335d | 2009-10-05 A | 2011-01-17 |  |  | 335d |  |  |  | 1009d |  | Mechanical Infrastructure | 2680h |  |
| 5 | 2.1.1 | Rolling platforms ready for Step II | milestone | 0d | 2009-10-05 A | 2009-10-05 A | 124 | 100% |  | 2009-05-15 | 2009-05-15 | 0d |  | start no earlier than 2009-10-05 |  |  |  |
| 6 | 2.1.2 | TOF2 at RAL | milestone | 0d | 2009-11-24 A | 2009-11-24 A | 129 | 100% |  | 2009-06-30 | 2009-06-30 | 0d |  | start no earlier than 2009-11-24 |  |  |  |
| 7 | 2.1.3 | Step IV floor preparations begin | milestone | 0d | 2011-01-17 | 2011-01-17 |  |  |  |  |  |  | 1043d | start no earlier than 2011-01-17 |  |  |  |
| 8 | 2.1.4 | Solid Lithium Hydride absorber at Fermilab | milestone | 0d | 2010-02-15 | 2010-02-15 |  |  |  | 2009-08-03 | 2009-08-03 | 0d | 1283d | start no earlier than 2010-02-15 |  |  |  |
| 9 | 2.2 | **Liquid hydrogen System** |  | 839d | 2010-12-16 A | 2014-05-22 |  |  | 839d |  |  |  | 192d |  | Hydrogen System | 6712h |  |
| 10 | 2.2.1 | **System A/R&D System** |  | 409d | 2010-12-16 A | 2012-09-28 |  |  | 409d |  |  |  | 622d |  |  |  |  |
| 11 | 2.2.1.1 | LH2 R&D Delivery system at RAL (from AS scientific) | milestone | 0d | 2010-12-16 A | 2010-12-16 A | 116 | 100% |  |  |  |  |  | start no earlier than 2010-12-16 |  |  |  |
| 12 | 2.2.1.2 | Installation of System A/R&D Infrastructure complete | milestone | 0d | 2011-06-29 | 2011-06-29 | 520 |  |  |  |  |  | 925d |  |  |  |  |
| 13 | 2.2.1.3 | Installation of System A/R&D components complete | milestone | 0d | 2011-05-18 | 2011-05-18 | 540 |  |  |  |  |  | 955d |  |  |  |  |
| 14 | 2.2.1.4 | R&D Tests of System A/R&D complete | milestone | 0d | 2011-08-22 | 2011-08-22 | 1009 |  |  |  |  |  | 916d |  |  |  |  |
| 15 | 2.2.1.5 | LH2 absorber #1 at RAL (KEK) | milestone | 0d | 2012-01-26 | 2012-01-26 | 117 |  |  | 2010-02-26 | 2010-02-26 | 0d | 832d | start no earlier than 2012-01-26 |  |  |  |
| 16 | 2.2.1.6 | LH2 absorber #2 at RAL (KEK) | milestone | 0d | 2012-09-28 | 2012-09-28 | 118 |  |  | 2010-08-27 | 2010-08-27 | 0d | 656d | start no earlier than 2012-09-28 |  |  |  |
| 17 | 2.2.2 | **System B** |  | 273d | 2012-05-24 | 2013-06-11 |  |  |  |  |  |  | 439d |  |  |  |  |
| 18 | 2.2.2.1 | R&D Tests with KEK absorber | milestone | 0d | 2012-05-24 | 2012-05-24 | 138 |  |  |  |  |  | 746d |  |  |  |  |
| 19 | 2.2.2.2 | Heater/Chiller Unit Delivery to RAL | milestone | 0d | 2012-11-05 | 2012-11-05 | 119 |  |  |  |  |  | 630d |  |  |  |  |
| 20 | 2.2.2.3 | Hydride Bed Delivery to RAL | milestone | 0d | 2013-01-28 | 2013-01-28 | 120 |  |  |  |  |  | 570d |  |  |  |  |
| 21 | 2.2.2.4 | Installation of System B Infrastructure complete | milestone | 0d | 2013-04-10 | 2013-04-10 | 558 |  |  |  |  |  | 517d |  |  |  |  |
| 22 | 2.2.2.5 | Installation of System B components complete | milestone | 0d | 2013-04-17 | 2013-04-17 | 568 |  |  |  |  |  | 512d |  |  |  |  |
| 23 | 2.2.2.6 | Commissioning of System B with AFC complete | milestone | 0d | 2013-06-11 | 2013-06-11 | 1024 |  |  |  |  |  | 473d |  |  |  |  |
| 24 | 2.2.3 | **System C** |  | 154d | 2013-10-21 | 2014-05-22 |  |  |  |  |  |  | 192d |  |  |  |  |
| 25 | 2.2.3.1 | Heater/Chiller Unit Delivery to RAL | milestone | 0d | 2013-10-21 | 2013-10-21 | 121 |  |  |  |  |  | 380d |  |  |  |  |
| 26 | 2.2.3.2 | Hydride Bed Delivery to RAL | milestone | 0d | 2014-01-06 | 2014-01-06 | 122 |  |  |  |  |  | 325d |  |  |  |  |
| 27 | 2.2.3.3 | Installation of System C Infrastructure complete | milestone | 0d | 2014-03-26 | 2014-03-26 | 578 |  |  |  |  |  | 267d |  |  |  |  |
| 28 | 2.2.3.4 | Installation of System C components complete | milestone | 0d | 2014-03-17 | 2014-03-17 | 588 |  |  |  |  |  | 274d |  |  |  |  |
| 29 | 2.2.3.5 | Commissioning of System C with AFC complete | milestone | 0d | 2014-05-22 | 2014-05-22 | 1039 |  |  |  |  |  | 226d |  |  |  |  |

| ID | WBS | Task | Type | Duration | Start | Finish | Predecessors | Complete | Baseline start | Baseline finish | Baseline duration | Total slack | Free slack | Constraint | Resources | Work | Cost |
| --- | --- | --- | --- | --- | --- | --- | --- | --- | --- | --- | --- | --- | --- | --- | --- | --- | --- |
| 30 | 2.3 | **RF system** |  | 404d | 2011-04-27 | 2013-02-01 |  |  |  |  |  | 532d |  |  | RF System | 3232h | 1,500 |
| 31 | 2.3.1 | Amplifier system #1 Delivered | milestone | 0d | 2011-04-27 | 2011-04-27 | 86 |  |  |  |  | 970d |  |  |  |  |  |
| 32 | 2.3.2 | Amplfier#1 installation complete | milestone | 0d | 2011-06-14 | 2011-06-14 | 785 |  |  |  |  | 936d |  |  |  |  |  |
| 33 | 2.3.3 | Waveguides & dummy loads system #1 delivered | milestone | 0d | 2011-12-01 | 2011-12-01 | 99 |  |  |  |  | 856d |  |  |  |  |  |
| 34 | 2.3.4 | Waveguides & dummy loads system #2 delivered | milestone | 0d | 2011-12-01 | 2011-12-01 | 102 |  |  |  |  | 856d |  |  |  |  |  |
| 35 | 2.3.5 | Amplifier system #2 Delivered | milestone | 0d | 2012-01-17 | 2012-01-17 | 89 |  |  |  |  | 838d |  |  |  |  | 500 |
| 36 | 2.3.6 | Amplifier system #3 Delivered | milestone | 0d | 2012-06-29 | 2012-06-29 | 92 |  |  |  |  | 720d |  |  |  |  | 500 |
| 37 | 2.3.7 | Amplifier system #4 Delivered | milestone | 0d | 2012-11-02 | 2012-11-02 | 95 |  |  |  |  | 630d |  |  |  |  | 500 |
| 38 | 2.3.8 | Amplfier#2 installation complete | milestone | 0d | 2012-01-31 | 2012-01-31 | 788 |  |  |  |  | 828d |  |  |  |  |  |
| 39 | 2.3.9 | Amplfier#3 installation complete | milestone | 0d | 2012-07-13 | 2012-07-13 | 791 |  |  |  |  | 710d |  |  |  |  |  |
| 40 | 2.3.10 | Amplfier#4 installation complete | milestone | 0d | 2012-11-16 | 2012-11-16 | 794 |  |  |  |  | 620d |  |  |  |  |  |
| 41 | 2.3.11 | Cavity & RFCC module #1 delivered to RAL | milestone | 0d | 2013-01-14 | 2013-01-14 | 131 |  |  |  |  | 580d |  |  |  |  |  |
| 42 | 2.3.12 | Cavity & RFCC module #2 delivered to RAL | milestone | 0d | 2013-02-01 | 2013-02-01 | 132 |  |  |  |  | 566d |  |  |  |  |  |
| 43 | 2.4 | **Spectrometer Solenoids (Tracker)** |  | 71d | 2012-03-26 | 2012-07-03 |  |  |  |  |  | 718d |  |  | Spectrometer | 568h |  |
| 44 | 2.4.1 | Solenoid 2 arrives at RAL | milestone | 0d | 2012-03-26 | 2012-03-26 | 107 |  |  |  |  | 762.42d | 0d |  |  |  |  |
| 45 | 2.4.2 | Solenoid 1 arrives at RAL | milestone | 0d | 2012-07-03 | 2012-07-03 | 111 |  |  |  |  | 718d |  |  |  |  |  |
| 46 | 2.5 | **AFC - Focus coils** |  | 59d | 2011-09-06 | 2012-01-05 |  |  |  |  |  | 813d |  |  | Focus Coils | 472h |  |
| 47 | 2.5.1 | FC module #1 at RAL | milestone | 0d | 2011-09-06 | 2011-09-06 | 113 |  | 2010-02-26 | 2010-02-26 | 0d | 906d |  |  |  |  |  |
| 48 | 2.5.2 | FC module #2 at RAL | milestone | 0d | 2012-01-05 | 2012-01-05 | 114 |  | 2010-08-27 | 2010-08-27 | 0d | 847d |  |  |  |  |  |
| 49 | 2.6 | **TOF** |  | 0d | 2009-11-24 A | 2009-11-24 A |  | 100% |  |  |  |  |  |  | TOF |  |  |
| 50 | 2.6.1 | TOF2 at RAL | milestone | 0d | 2009-11-24 A | 2009-11-24 A |  | 100% | 2009-06-30 | 2009-06-30 | 0d |  |  | start no earlier than 2009-11-24 |  |  |  |
| 51 | 2.7 | **MICE Step IV Installation** |  | 298d | 2011-09-01 | 2012-11-30 |  |  |  |  |  | 610d |  |  | Step IV | 2384h |  |
| 52 | 2.7.1 | Step IV base plate installation complete | milestone | 0d | 2011-09-01 | 2011-09-01 | 817 |  |  |  |  | 908d |  |  |  |  |  |
| 53 | 2.7.2 | Step IV Spectrometer Solenoid # 1 Installation Complete | milestone | 0d | 2012-04-30 | 2012-04-30 | 818 |  |  |  |  | 764d |  |  |  |  |  |
| 54 | 2.7.3 | Tracker #1 Installation complete | milestone | 0d | 2012-07-06 | 2012-07-06 | 844 |  |  |  |  | 715d |  |  |  |  |  |
| 55 | 2.7.4 | AFC #1 Installation complete | milestone | 0d | 2012-06-19 | 2012-06-19 | 845 |  |  |  |  | 728d |  |  |  |  |  |
| 56 | 2.7.5 | Step IV Spectrometer Solenoid # 2 Installation Complete | milestone | 0d | 2012-07-24 | 2012-07-24 | 860 |  |  |  |  | 703d |  |  |  |  |  |
| 57 | 2.7.6 | Tracker #2 Installation complete | milestone | 0d | 2012-06-22 | 2012-06-22 | 859 |  |  |  |  | 725d |  |  |  |  |  |
| 58 | 2.7.7 | MICE step IV installation complete | milestone | 0d | 2012-10-05 | 2012-10-05 | 887 |  |  |  |  | 650d |  |  |  |  |  |
| 59 | 2.7.8 | MICE step IV commissioning complete | milestone | 0d | 2012-11-30 | 2012-11-30 | 1060 |  |  |  |  | 610d |  |  |  |  |  |

| ID | WBS | Task | Type | Duration | Start | Finish | Predecessors | Remaining | Total slack | Free slack | Constraint | Calendar | Resources | Work | Cost |
| --- | --- | --- | --- | --- | --- | --- | --- | --- | --- | --- | --- | --- | --- | --- | --- |
| 60 | 2.8 | **MICE Step V Installation** |  | 243d | 2013-02-26 | 2014-01-31 |  |  | 305d |  |  |  | Step V | 1944h |  |
| 61 | 2.8.1 | Step V base plate installation complete | milestone | 0d | 2013-02-26 | 2013-02-26 | 912 |  | 548d |  |  |  |  |  |  |
| 62 | 2.8.2 | AFC #2 Installation complete | milestone | 0d | 2013-07-03 | 2013-07-03 | 913 |  | 457d |  |  |  |  |  |  |
| 63 | 2.8.3 | RFCC #1 Installation complete | milestone | 0d | 2013-11-08 | 2013-11-08 | 934 |  | 365d |  |  |  |  |  |  |
| 64 | 2.8.4 | Step V Spectrometer Solenoid # 2 Installation Complete | milestone | 0d | 2013-11-29 | 2013-11-29 | 943 |  | 350d |  |  |  |  |  |  |
| 65 | 2.8.5 | MICE step V installation complete | milestone | 0d | 2013-12-06 | 2013-12-06 | 945 |  | 345d |  |  |  |  |  |  |
| 66 | 2.8.6 | MICE step V commissioning complete | milestone | 0d | 2014-01-31 | 2014-01-31 | 1063 |  | 305d |  |  |  |  |  |  |
| 67 | 2.9 | **MICE Step VI Installation** |  | 246d | 2014-04-24 | 2015-04-03 |  |  | 0d |  |  |  | Step VI | 1968h |  |
| 68 | 2.9.1 | Step VI base plate installation complete | milestone | 0d | 2014-04-24 | 2014-04-24 | 953 |  | 246d |  |  |  |  |  |  |
| 69 | 2.9.2 | RFCC #2 Installation complete | milestone | 0d | 2014-09-01 | 2014-09-01 | 973 |  | 154d |  |  |  |  |  |  |
| 70 | 2.9.3 | AFC #3 Installation complete | milestone | 0d | 2015-01-09 | 2015-01-09 | 982 |  | 60d |  |  |  |  |  |  |
| 71 | 2.9.4 | Step VI Spectrometer Solenoid # 2 Installation Complete | milestone | 0d | 2015-01-30 | 2015-01-30 | 1003 |  | 45d |  |  |  |  |  |  |
| 72 | 2.9.5 | MICE step VI installation complete | milestone | 0d | 2015-02-06 | 2015-02-06 | 1005 |  | 40d |  |  |  |  |  |  |
| 73 | 2.9.6 | MICE step VI commissioning complete | milestone | 0d | 2015-04-03 | 2015-04-03 | 1066 |  | 0d |  |  |  |  |  |  |
| 75 | 3 | **ISIS Run Cycle** |  | 193d | 2011-07-05 | 2012-03-29 |  |  | 752d |  |  | ISIS Run Cycle | ISIS Run Cycle | 984h |  |
| 76 | 3.1 | Cycle 2011/02 |  | 29d | 2011-07-05 | 2011-08-12 |  |  | 950d |  | finish no earlier than 2011-08-12 | ISIS Run Cycle |  |  |  |
| 77 | 3.2 | Cycle 2011/03 |  | 28d | 2011-09-20 | 2011-10-27 |  |  | 896d |  | finish no earlier than 2011-10-27 | ISIS Run Cycle |  |  |  |
| 78 | 3.3 | Cycle 2011/04 |  | 28d | 2011-11-15 | 2011-12-22 |  |  | 856d |  | finish no earlier than 2011-12-22 | ISIS Run Cycle |  |  |  |
| 79 | 3.4 | Cycle 2011/05 |  | 38d | 2012-02-07 | 2012-03-29 |  |  | 786d |  | finish no earlier than 2012-03-29 | ISIS Run Cycle |  |  |  |
| 81 | 4 | **Shipping** |  | 1110d | 2009-10-05 A | 2014-01-06 |  | 1110d | 325d |  |  | Shipping | Shipping | 24240h | 31,500 |
| 82 | 4.1 | **RF system** |  | 399d | 2011-04-26 | 2012-11-02 |  |  | 616d |  |  | Shipping | RF System | 2768h | 1,500 |
| 83 | 4.1.1 | **Amplifiers** |  | 399d | 2011-04-26 | 2012-11-02 |  |  | 579d |  |  | Shipping |  | 32h | 1,500 |
| 84 | 4.1.1.1 | **System #1** |  | 2d | 2011-04-26 | 2011-04-27 |  |  | 976d |  |  | Shipping | STEP V - TIARA | 16h |  |
| 85 | 4.1.1.1.1 | Ship Amplifier system #1 to RAL from DL |  | 2d | 2011-04-26 | 2011-04-27 |  |  | 980d | 0d | start no earlier than 2011-04-26 | Shipping |  |  |  |
| 86 | 4.1.1.1.2 | Amplifier system #1 Delivered | milestone | 0d | 2011-04-27 | 2011-04-27 | 85 |  | 980d | 0d |  | Shipping |  |  |  |

| ID | WBS | Task | Type | Duration | Start | Finish | Predecessors | Total slack | Free slack | Constraint | Calendar | Resources | Work | Cost |
| --- | --- | --- | --- | --- | --- | --- | --- | --- | --- | --- | --- | --- | --- | --- |
| 87 | 4.1.1.2 | **System #2** |  | 2d | 2012-01-16 | 2012-01-17 |  | 787d |  |  | Shipping | STEP V - TIARA | 16h | 500 |
| 88 | 4.1.1.2.1 | Ship Amplifier system #2 to RAL from DL |  | 2d | 2012-01-16 | 2012-01-17 |  | 791d | 0d | start no earlier than 2012-01-16 | Shipping |  |  |  |
| 89 | 4.1.1.2.2 | Amplifier system #2 Delivered | milestone | 0d | 2012-01-17 | 2012-01-17 | 88 | 791d | 0d |  | Shipping |  |  | 500 |
| 90 | 4.1.1.3 | **System #3** |  | 10d | 2012-06-18 | 2012-06-29 |  | 669d |  |  | Shipping |  |  | 500 |
| 91 | 4.1.1.3.1 | Ship Amplifier system #3 to RAL from DL |  | 10d | 2012-06-18 | 2012-06-29 |  | 673d | 0d | start no earlier than 2012-06-18 | Shipping |  |  |  |
| 92 | 4.1.1.3.2 | Amplifier system #3 Delivered | milestone | 0d | 2012-06-29 | 2012-06-29 | 91 | 673d | 0d |  | Shipping |  |  | 500 |
| 93 | 4.1.1.4 | **System #4** |  | 10d | 2012-10-22 | 2012-11-02 |  | 579d |  |  | Shipping |  |  | 500 |
| 94 | 4.1.1.4.1 | Ship Amplifier system #4 to RAL from DL |  | 10d | 2012-10-22 | 2012-11-02 |  | 583d | 0d | start no earlier than 2012-10-22 | Shipping |  |  |  |
| 95 | 4.1.1.4.2 | Amplifier system #4 Delivered | milestone | 0d | 2012-11-02 | 2012-11-02 | 94 | 583d | 0d |  | Shipping |  |  | 500 |
| 96 | 4.1.2 | **Waveguides** |  | 5d | 2011-11-25 | 2011-12-01 |  | 857d |  |  | Shipping |  |  |  |
| 97 | 4.1.2.1 | **System#1** |  | 5d | 2011-11-25 | 2011-12-01 |  | 857d |  |  | Shipping | STEP V - TIARA |  |  |
| 98 | 4.1.2.1.1 | Delivery of waveguides & dummy loads system #1 |  | 5d | 2011-11-25 | 2011-12-01 |  | 861d | 0d | start no earlier than 2011-11-25 | Shipping |  |  |  |
| 99 | 4.1.2.1.2 | Waveguides & dummy loads system #1 delivered | milestone | 0d | 2011-12-01 | 2011-12-01 | 98 | 861d | 0d |  | Shipping |  |  |  |
| 100 | 4.1.2.2 | **System#2** |  | 5d | 2011-11-25 | 2011-12-01 |  | 857d |  |  | Shipping |  |  |  |
| 101 | 4.1.2.2.1 | Delivery of waveguides & dummy loads system #2 |  | 5d | 2011-11-25 | 2011-12-01 |  | 861d | 0d | start no earlier than 2011-11-25 | Shipping |  |  |  |
| 102 | 4.1.2.2.2 | Waveguides & dummy loads system #2 delivered | milestone | 0d | 2011-12-01 | 2011-12-01 | 101 | 861d | 0d |  | Shipping |  |  |  |
| 103 | 4.2 | **Spectrometer Solenoids (Tracker)** |  | 137d | 2011-12-26 | 2012-07-03 |  | 49d |  |  | Shipping | Spectrometer | 1624h |  |
| 104 | 4.2.1 | **Spectrometer Solenoid #2** |  | 66d | 2011-12-26 | 2012-03-26 |  | 49d |  |  | Shipping | STEP V - TIARA | 528h |  |
| 105 | 4.2.1.1 | Package solenoid 2 |  | 4w | 2011-12-26 | 2012-01-20 |  | 835d |  | finish no earlier than 2012-01-20 | Shipping |  |  |  |
| 106 | 4.2.1.2 | Ship Solenoid 2 to UK |  | 24d | 2012-02-22 | 2012-03-26 |  | 7d | 0d | start no earlier than 2012-02-22 | Shipping |  |  |  |
| 107 | 4.2.1.3 | Solenoid 2 arrives at RAL | milestone | 0d | 2012-03-26 | 2012-03-26 | 106 | 7d | 0d |  | Shipping |  |  |  |
| 108 | 4.2.2 | **Spectrometer Solenoid #1** |  | 48d | 2012-04-27 | 2012-07-03 |  | 20d |  |  | Shipping |  |  |  |
| 109 | 4.2.2.1 | Package Solenoid 1 |  | 4w | 2012-04-27 | 2012-05-24 |  | 746d |  | start no earlier than 2012-04-27 | Shipping |  |  |  |
| 110 | 4.2.2.2 | Ship Solenoid 1 to UK |  | 28d | 2012-05-25 | 2012-07-03 |  | 0d |  | start no earlier than 2012-05-25 | Shipping |  |  |  |
| 111 | 4.2.2.3 | Solenoid 1 arrives at RAL | milestone | 0d | 2012-07-03 | 2012-07-03 | 110 | 0d |  |  | Shipping |  |  |  |

| ID | WBS | Task | Type | Duration | Start | Finish | Complete | Remaining | Baseline start | Baseline finish | Baseline duration | Total slack | Free slack | Constraint | Calendar | Resources | Work | Cost |
| --- | --- | --- | --- | --- | --- | --- | --- | --- | --- | --- | --- | --- | --- | --- | --- | --- | --- | --- |
| 112 | 4.3 | **AFC - Focus coils - Tesla** |  | 87d | 2011-09-06 | 2012-01-05 |  |  |  |  |  | 34d |  |  | Shipping | Focus Coils | 472h |  |
| 113 | 4.3.1 | FC module #1 at RAL | milestone | 0d | 2011-09-06 | 2011-09-06 |  |  | 2010-02-26 | 2010-02-26 | 0d | 34d | 0d | start no earlier than 2011-09-06 | Shipping |  |  |  |
| 114 | 4.3.2 | FC module #2 at RAL | milestone | 0d | 2012-01-05 | 2012-01-05 |  |  | 2010-08-27 | 2010-08-27 | 0d | 847d | 0d | start no earlier than 2012-01-05 | Shipping |  |  |  |
| 115 | 4.4 | **Liquid Hydrogen System** |  | 836d | 2010-10-22 A | 2014-01-06 |  | 836d |  |  |  | 291d |  |  | Shipping | Hydrogen System | 6232h |  |
| 116 | 4.4.1 | LH2 R&D Delivery system at RAL (from AS scientific) | milestone | 0d | 2010-10-22 A | 2010-10-22 A | 100% |  |  |  |  |  |  | start no earlier than 2010-10-22 | Shipping |  |  |  |
| 117 | 4.4.2 | LH2 absorber #1 at RAL (KEK) | milestone | 0d | 2011-11-15 | 2011-11-15 |  |  | 2010-02-26 | 2010-02-26 | 0d | 774d | 0d | start no earlier than 2011-11-15 | Shipping |  |  |  |
| 118 | 4.4.3 | LH2 absorber #2 at RAL (KEK) | milestone | 0d | 2012-09-28 | 2012-09-28 |  |  | 2010-08-27 | 2010-08-27 | 0d | 656d | 0d | start no earlier than 2012-09-28 | Shipping |  |  |  |
| 119 | 4.4.4 | Heater/Chiller Unit Delivery to RAL (sys B) | milestone | 0d | 2012-11-05 | 2012-11-05 |  |  |  |  |  | 630d | 0d | start no earlier than 2012-11-05 | Shipping |  |  |  |
| 120 | 4.4.5 | Hydride Bed Delivery to RAL (sys B) | milestone | 0d | 2013-01-28 | 2013-01-28 |  |  |  |  |  | 570d | 0d | start no earlier than 2013-01-28 | Shipping |  |  |  |
| 121 | 4.4.6 | Heater/Chiller Unit Delivery to RAL (sys C) | milestone | 0d | 2013-10-21 | 2013-10-21 |  |  |  |  |  | 380d | 0d | start no earlier than 2013-10-21 | Shipping |  |  |  |
| 122 | 4.4.7 | Hydride Bed Delivery to RAL (sys C) | milestone | 0d | 2014-01-06 | 2014-01-06 |  |  |  |  |  | 325d | 0d | start no earlier than 2014-01-06 | Shipping |  |  |  |
| 123 | 4.5 | **Mechanical integration Components** |  | 525d | 2009-10-05 A | 2011-10-10 |  | 525d | 2008-07-21 | 2011-05-02 | 727d? | 876d |  |  | Shipping | Mechanical Infrastructure | 3968h | 30,000 |
| 124 | 4.5.1 | Rolling platforms ready for Step II | milestone | 0d | 2009-10-05 A | 2009-10-05 A | 100% |  | 2009-05-15 | 2009-05-15 | 0d |  |  | start no earlier than 2009-10-05 | Shipping |  |  |  |
| 125 | 4.5.2 | Deliver rail system for AFC and RFCC (Rolling platform replacement)-Norbert | milestone | 0d | 2011-06-20 | 2011-06-20 |  |  |  |  |  | 965d | 0d | start no earlier than 2011-06-20 | Shipping |  |  | 30,000 |
| 126 | 4.5.3 | Diffuser at RAL | milestone | 0d | 2011-10-10 | 2011-10-10 |  |  | 2009-05-15 | 2009-05-15 | 0d | 910d |  | start no earlier than 2011-10-10 | Shipping |  |  |  |
| 127 | 4.5.4 | Solid Lithium Hydride absorber at Fermilab | milestone | 0d | 2010-02-15 | 2010-02-15 |  |  | 2009-08-03 | 2009-08-03 | 0d | 1340d |  | start no earlier than 2010-02-15 | Shipping |  |  |  |
| 128 | 4.6 | **TOF 01 & 02** |  | 0d | 2009-11-24 A | 2009-11-24 A | 100% |  |  |  |  |  |  |  | Shipping | TOF |  |  |
| 129 | 4.6.1 | TOF2 at RAL | milestone | 0d | 2009-11-24 A | 2009-11-24 A | 100% |  | 2009-06-30 | 2009-06-30 | 0d |  |  | start no earlier than 2009-11-24 | Shipping |  |  |  |
| 130 | 4.7 | **Cavities & RFCC's** |  | 14d | 2013-01-14 | 2013-02-01 |  |  |  |  |  | 562d |  |  | Shipping | RF System | 112h |  |
| 131 | 4.7.1 | Cavity & RFCC module #1 delivered to RAL | milestone | 0d | 2013-01-14 | 2013-01-14 |  |  |  |  |  | 580d | 0d | start no earlier than 2013-01-14 | Shipping |  |  |  |
| 132 | 4.7.2 | Cavity & RFCC module #2 delivered to RAL | milestone | 0d | 2013-02-01 | 2013-02-01 |  |  |  |  |  | 566d | 0d | start no earlier than 2013-02-01 | Shipping |  |  |  |
| 133 | 4.8 | **EMR** |  | 109d | 2011-06-01 | 2011-11-01 |  |  |  |  |  | 822d |  |  | Shipping | EMR | 640h |  |
| 134 | 4.8.1 | EMR at RAL for initial tests | milestone | 0d | 2011-06-01 | 2011-06-01 |  |  |  |  |  | 949d | 0d | start no earlier than 2011-06-01 | Shipping |  |  |  |
| 135 | 4.8.2 | EMR at RAL final delivery | milestone | 0d | 2011-11-01 | 2011-11-01 |  |  |  |  |  | 856d | 0d | start no earlier than 2011-11-01 | Shipping |  |  |  |

Notes:
- 131: Need to confirm this shipping date!!
- 132: Need to confirm this shipping date!!

| ID | WBS | Task | Type | Duration | Start | Finish | Predecessors | Total slack | Free slack | Constraint | Calendar | Resources | Work | Cost |
| --- | --- | --- | --- | --- | --- | --- | --- | --- | --- | --- | --- | --- | --- | --- |
| 137 | 5 | **Pre Installation Work** |  | 209d | 2011-05-19 | 2012-05-24 |  | 746d |  |  |  | Pre Installation Work | 5192h | 45,078.92 |
| 138 | 5.1 | **Hydrogen system tests with KEK absorber** |  | 209d | 2011-05-19 | 2012-05-24 |  | 746d | 0d |  |  | Hydrogen System | 2344h | 45,078.92 |
| 139 | 5.1.1 | **R&D Tests with KEK absorber** |  | 50d | 2011-12-23 | 2012-03-01 |  | 712d | 0d |  |  |  | 672h | 27,453.92 |
| 140 | 5.1.1.1 | Install absorber in test cryostat |  | 20d | 2011-12-23 | 2012-01-19 | 117, 1009 | 746d | 0d | start no earlier than 2011-01-20 |  | Cryo Technician; Mike Courthold [20%] | 192h | 1,896.32 |
| 141 | 5.1.1.2 | **Helium Tests** |  | 21d | 2012-01-20 | 2012-02-17 | 140 | 712d | 0d |  |  |  | 336h | 17,890.32 |
| 142 | 5.1.1.2.1 | Check instrumentation |  | 3d | 2012-01-20 | 2012-01-24 |  | 746d | 0d | start no earlier than 2011-01-05 |  | Mike Courthold; Matt Hills | 48h | 2,555.76 |
| 143 | 5.1.1.2.2 | Pump and purge |  | 2d | 2012-01-25 | 2012-01-26 | 142 | 746d | 0d | start no earlier than 2011-01-10 |  | Mike Courthold; Matt Hills | 32h | 1,703.84 |
| 144 | 5.1.1.2.3 | Check relief valve settings |  | 1d | 2012-01-27 | 2012-01-27 | 143 | 746d | 0d | start no earlier than 2011-01-12 |  | Matt Hills; Mike Courthold | 16h | 851.92 |
| 145 | 5.1.1.2.4 | Liquify helium in the absorber |  | 4d | 2012-01-30 | 2012-02-02 | 144 | 746d | 0d | start no earlier than 2011-01-19 |  | Mike Courthold; Matt Hills | 64h | 3,407.68 |
| 146 | 5.1.1.2.5 | Test emptying sequence |  | 1d | 2012-02-03 | 2012-02-03 | 145 | 746d | 0d | start no earlier than 2011-01-21 |  | Mike Courthold; Matt Hills | 16h | 851.92 |
| 147 | 5.1.1.2.6 | Thermal cycling to check for leaks from thermal stresses |  | 10d | 2012-02-06 | 2012-02-17 | 146 | 746d |  | start no earlier than 2011-01-24 |  | Mike Courthold; Matt Hills | 160h | 8,519.2 |
| 148 | 5.1.1.3 | **Hydrogen Tests** |  | 9d | 2012-02-20 | 2012-03-01 | 141 | 712d |  |  |  |  | 144h | 7,667.28 |
| 149 | 5.1.1.3.1 | Liquify hydrogen in the cryostat |  | 3d | 2012-02-20 | 2012-02-22 | 141 | 746d | 0d | start no earlier than 2011-02-07 |  | Mike Courthold; Matt Hills | 48h | 2,555.76 |
| 150 | 5.1.1.3.2 | Check empty and purge sequence |  | 2d | 2012-02-23 | 2012-02-24 | 149 | 746d | 0d | start no earlier than 2011-02-10 |  | Mike Courthold; Matt Hills | 32h | 1,703.84 |
| 151 | 5.1.1.3.3 | Check alarms and interlocks |  | 2d | 2012-02-27 | 2012-02-28 | 150 | 746d | 0d | start no earlier than 2011-02-21 |  | Mike Courthold; Matt Hills | 32h | 1,703.84 |
| 152 | 5.1.1.3.4 | Test relief systems |  | 2d | 2012-02-29 | 2012-03-01 | 151 | 746d |  |  |  | Mike Courthold; Matt Hills | 32h | 1,703.84 |
| 153 | 5.1.2 | Manufacture of new transfer line to fit AFC module |  | 50d | 2011-05-19 | 2011-09-06 | 540 | 845d | 99d |  |  |  |  | 17,625 |
| 154 | 5.1.3 | AFC Off-Line Commissioning |  | 60d | 2012-03-02 | 2012-05-24 | 153, 139 | 746d |  |  |  |  |  |  |
| 155 | 5.2 | **EMR** |  | 90d | 2011-06-01 | 2011-12-22 |  | 856d |  |  |  | EMR | 1176h |  |
| 156 | 5.2.1 | Install EMR (3 modules in Box) behind KL |  | 4w | 2011-06-01 | 2011-06-28 | 134 | 892d | 4d |  |  |  |  |  |
| 157 | 5.2.2 | EMR pre testing |  | 29d | 2011-07-05 | 2011-08-12 | 156 | 945d | 0d |  | ISIS Run Cycle | ISIS Run Cycle | 232h |  |
| 158 | 5.2.3 | EMR pre testing complete | milestone | 0d | 2011-08-12 | 2011-08-12 | 157 | 917d | 0d |  |  |  |  |  |
| 159 | 5.2.4 | Ship EMR back to CERN |  | 5d | 2011-08-15 | 2011-08-19 | 158 | 917d |  |  |  |  |  |  |
| 160 | 5.2.5 | Install EMR in step IV position |  | 2w | 2011-11-01 | 2011-11-14 | 135 | 828d | 0d |  |  |  |  |  |
| 161 | 5.2.6 | EMR final test |  | 28d | 2011-11-15 | 2011-12-22 | 160 | 856d | 0d |  | ISIS Run Cycle | ISIS Run Cycle | 224h |  |
| 162 | 5.2.7 | EMR final tests complete | milestone | 0d | 2011-12-22 | 2011-12-22 | 161 | 856d |  |  |  |  |  |  |

Notes:
- 153: Ideally, would start after installation of system in the hall to identify any integration issues. Also, completion of some testing will give additional confidence in the design.

| ID | WBS | Task | Type | Duration | Start | Finish | Predecessors | Complete | Remaining | Total slack | Free slack | Constraint | Resources | Work | Actual work | Cost | Actual cost |
| --- | --- | --- | --- | --- | --- | --- | --- | --- | --- | --- | --- | --- | --- | --- | --- | --- | --- |
| 164 | 6 | **Installation** |  | 1637.5d | 2008-09-01 A | 2015-02-27 |  | 35% | 1071.1d | 25.5d |  |  | Installation | 74930h | 5399.99h | 945,221.64 | 292,469.08 |
| 165 | 6.1 | **Infrastructure** |  | 1637.5d | 2008-09-01 A | 2015-02-27 |  | 51% | 797.17d | 25.5d |  |  |  | 25148.1h | 3929.28h | 648,000 | 261,480 |
| 166 | 6.1.1 | **Mechanical** |  | 419d | 2010-04-01 A | 2012-01-26 |  | 54% | 194.43d | 831d |  |  | Mechanical Infrastructure | 3352h |  | 451,000 | 105,850 |
| 167 | 6.1.1.1 | Radiation shield design, manufacture and integration (Norbert) |  | 176d | 2011-02-01 | 2011-11-14 |  |  |  | 856d |  | start no earlier than 2011-02-01 |  |  |  | 20,000 |  |
| 168 | 6.1.1.2 | Managing compressor stands & high pressure hoses |  | 261d | 2010-04-01 A | 2011-03-31 A |  | 100% |  |  |  | start no earlier than 2010-04-01 |  |  |  | 5,000 | 5,000 |
| 169 | 6.1.1.3 | Patch panel interfaces and stand (tracker, Geoff Barber) | milestone | 0d | 2010-04-01 | 2010-04-01 |  |  |  | 1250d |  | start no earlier than 2010-04-01 |  |  |  | 1,000 |  |
| 170 | 6.1.1.4 | Trellises for fibre optices (tracker, Geoff Barber) | milestone | 0d | 2010-04-01 | 2010-04-01 |  |  |  | 1250d |  | start no earlier than 2010-04-01 |  |  |  | 2,000 |  |
| 171 | 6.1.1.5 | He window (tracker, Geoff Barber) | milestone | 0d | 2010-04-01 | 2010-04-01 |  |  |  | 1250d |  | start no earlier than 2010-04-01 |  |  |  | 5,000 |  |
| 172 | 6.1.1.6 | Drill jigs for drilling solenoid interfaces (tracker, Geoff Barber) | milestone | 0d | 2010-04-01 | 2010-04-01 |  |  |  | 1250d |  | start no earlier than 2010-04-01 |  |  |  | 1,000 |  |
| 173 | 6.1.1.7 | Steel structure for supporting fume stacks for Hydrogen system |  | 230d | 2010-04-01 A | 2011-03-01 |  | 50% | 115d | 1011d |  | finish no earlier than 2011-03-01 |  |  |  |  |  |
| 174 | 6.1.1.8 | Vacuum pump enclosure |  | 230d | 2010-04-01 A | 2011-03-01 |  | 50% | 115d | 1011d |  | finish no earlier than 2011-03-01 |  |  |  | 31,000 | 15,500 |
| 175 | 6.1.1.9 | Retaining wall for LH2 vents |  | 127d | 2010-04-01 A | 2010-09-24 A |  | 100% |  |  |  | finish no earlier than 2010-09-24 |  |  |  | 10,000 | 10,000 |
| 176 | 6.1.1.10 | Mezzanine for Electronics racks (Next to Q7,Q8,Q9) |  | 115d | 2010-08-16 A | 2011-01-21 |  | 80% | 23d | 1038d |  | finish no earlier than 2011-01-21 |  |  |  | 40,000 | 32,000 |
| 177 | 6.1.1.11 | Security fence around the MICE roof |  | 56d | 2010-08-16 A | 2010-11-01 A |  | 100% |  |  |  | finish no earlier than 2010-11-01 |  |  |  | 20,000 | 20,000 |
| 178 | 6.1.1.12 | Hand rail around the MICE roof |  | 36d | 2011-01-07 | 2011-02-25 |  |  |  | 1013d |  | finish no earlier than 2011-02-25 |  |  |  | 5,000 |  |
| 179 | 6.1.1.13 | Walkway from the concrete steps to the MICE roof |  | 53d | 2010-09-15 A | 2010-11-26 A |  | 100% |  |  |  | finish no earlier than 2010-11-26 |  |  |  | 6,000 | 6,000 |
| 180 | 6.1.1.14 | PPS fences and gates for RF enclosure |  | 48d | 2010-08-16 A | 2010-10-20 A |  | 100% |  |  |  | finish no earlier than 2010-10-20 |  |  |  | 5,000 | 5,000 |
| 181 | 6.1.1.15 | Checker plate the false floor |  | 50d | 2011-04-04 | 2011-06-10 |  |  |  | 938d |  | start no earlier than 2011-04-04 |  |  |  | 20,000 |  |
| 182 | 6.1.1.16 | Walkway behind the south shield wall at mezzanine level |  | 105d | 2010-09-08 A | 2011-02-01 |  | 10% | 94.5d | 1031d |  | start no earlier than 2010-09-08 |  |  |  | 6,000 | 600 |
| 183 | 6.1.1.17 | Gas bottle rack outside the MICE hall |  | 60d | 2010-10-01 A | 2010-12-23 |  | 25% | 45d | 1059d |  | finish no earlier than 2010-12-23 |  |  |  | 3,000 | 750 |
| 184 | 6.1.1.18 | Mono rail hoist |  | 48d | 2010-08-16 A | 2010-10-20 A |  | 100% |  |  |  | finish no earlier than 2010-10-20 |  |  |  | 5,000 | 5,000 |
| 185 | 6.1.1.19 | MICE main door refurbishment |  | 95d | 2010-08-16 A | 2010-12-24 A |  | 100% |  |  |  | start no earlier than 2010-08-16 |  |  |  | 6,000 | 6,000 |
| 186 | 6.1.1.20 | **Magnetic shield walls** |  | 242d | 2010-12-06 | 2012-01-26 |  |  |  | 831d |  |  |  |  |  | 260,000 |  |
| 187 | 6.1.1.20.1 | Vector fields Analysis |  | 42d | 2010-12-06 | 2011-02-01 |  |  |  | 831d | 0d | finish no earlier than 2011-02-01 |  |  |  | 10,000 |  |
| 188 | 6.1.1.20.2 | Build new steel walls |  | 200d | 2011-02-02 | 2012-01-26 | 187 |  |  | 831d |  |  |  |  |  | 250,000 |  |

| ID | WBS | Task | Type | Duration | Start | Finish | Predecessors | Complete | Remaining | Baseline start | Baseline finish | Baseline duration | Total slack | Free slack | Constraint | Resources | Work | Actual work | Cost | Baseline cost | Actual cost |
| --- | --- | --- | --- | --- | --- | --- | --- | --- | --- | --- | --- | --- | --- | --- | --- | --- | --- | --- | --- | --- | --- |
| 189 | 6.1.2 | **Electrical** |  | 1637.5d | 2008-09-01 A | 2015-02-27 |  | 48% | 850.94d |  |  |  | 25.5d |  |  | Electrical Infrastucture | 21796.1h | 3929.28h | 197,000 |  | 155,630 |
| 190 | 6.1.2.1 | **Personnel Safety** |  | 1190d | 2008-09-01 A | 2013-06-11 |  | 71% | 344.27d | 2009-06-15 | 2012-12-18 | 917d? | 473d |  |  |  | 2004.5h | 1372.5h | 23,500 | 93,086 | 17,500 |
| 191 | 6.1.2.1.1 | DSA Modifications and additions |  | 5d | 2009-12-01 A | 2009-12-08 A |  | 100% |  | 2009-10-26 | 2009-10-30 | 5d |  |  | start no earlier than 2009-10-05 | Electrical Designer | 40h | 40h | 7,500 | 9,380 | 7,500 |
| 192 | 6.1.2.1.2 | DSA installation |  | 4d | 2009-12-08 A | 2009-12-14 A | 191 | 100% |  | 2009-11-02 | 2009-11-05 | 4d |  |  |  | Electrical Technician | 32h | 32h |  | 1,504 |  |
| 193 | 6.1.2.1.3 | Electrical Commission DAS PPS |  | 3d | 2009-12-14 A | 2009-12-17 A | 192 | 100% |  | 2009-11-06 | 2009-11-10 | 3d |  |  | start no earlier than 2009-10-12 | Electrical Designer | 24h | 24h |  | 1,128 |  |
| 194 | 6.1.2.1.4 | DSA PPS Electrical Ready | milestone | 0d | 2009-12-17 A | 2009-12-17 A | 193 | 100% |  | 2009-11-10 | 2009-11-10 | 0d |  |  | start no earlier than 2008-12-29 |  |  |  |  |  |  |
| 195 | 6.1.2.1.5 | PPS Safety Office commissions DSA |  | 3d | 2010-11-30 A | 2010-12-03 A | 205 | 100% |  |  |  |  |  |  |  |  |  |  |  |  |  |
| 196 | 6.1.2.1.6 | **Hall electrical design** |  | 1190d | 2008-09-01 A | 2013-06-11 |  | 69% | 366.35d | 2009-06-15 | 2012-12-18 | 917d? | 439d |  |  |  | 1908.5h | 1276.5h | 16,000 | 81,074 | 10,000 |
| 197 | 6.1.2.1.6.1 | **PPS** |  | 340.15d | 2009-06-15 A | 2010-10-04 A |  | 100% |  | 2009-06-15 | 2009-06-15 | 0d |  |  |  |  | 1202.5h | 1202.5h | 10,000 | 10,000 | 10,000 |
| 198 | 6.1.2.1.6.1.1 | PPS electrical design generated |  | 37d | 2009-06-15 A | 2009-08-04 A |  | 100% |  | 2009-06-15 | 2009-07-24 | 30d |  |  |  | Electrical Designer | 296h | 296h |  | 11,280 |  |
| 199 | 6.1.2.1.6.1.2 | PPS Hall Drawings provisionally accepted |  | 4.62d | 2009-08-05 A | 2009-08-11 A | 198 | 100% |  |  |  |  |  |  |  | Electrical Designer | 37h | 37h |  |  |  |
| 200 | 6.1.2.1.6.1.3 | Step II Hall installation |  | 55.5d | 2009-08-11 A | 2010-07-01 A | 199 | 100% |  | 2009-07-27 | 2009-10-06 | 52d |  |  | start no earlier than 2009-06-22 | Electrical Technician; Electrical Designer [25%] | 555h | 555h |  | 20,680 |  |
| 201 | 6.1.2.1.6.1.4 | PPS Rack termination diagrams generated |  | 18.5d | 2010-05-17 A | 2010-06-10 A |  | 100% |  |  |  |  |  |  | start no earlier than 2010-05-17 | Electrical Designer | 148h | 148h |  |  |  |
| 202 | 6.1.2.1.6.1.5 | PPS Rack termination approved |  | 4.62d | 2010-06-10 A | 2010-06-17 A | 201 | 100% |  |  |  |  |  |  |  |  |  |  |  |  |  |
| 203 | 6.1.2.1.6.1.6 | PPS Rack terminations in MLCR |  | 13.88d | 2010-07-01 A | 2010-09-29 A | 200, 202 | 100% |  |  |  |  |  |  |  | Electrical Technician; Electrical Designer [25%] | 138.75h | 138.75h |  |  |  |
| 204 | 6.1.2.1.6.1.7 | Electrical commissioning |  | 2.77d | 2010-09-29 A | 2010-10-04 A | 203 | 100% |  | 2009-10-07 | 2009-10-09 | 3d |  |  | start no earlier than 2008-12-15 | Electrical Designer; Electrical Technician [25%] | 27.75h | 27.75h |  | 1,410 |  |
| 205 | 6.1.2.1.6.2 | Personnel Safety Officer commissioning |  | 18.5d | 2010-10-04 A | 2010-11-30 A | 204 | 100% |  | 2009-10-12 | 2009-10-23 | 10d |  |  | start no earlier than 2009-08-31 | Electrical Technician [25%]; Electrical Designer [25%] | 74h | 74h |  |  |  |
| 206 | 6.1.2.1.6.3 | Personnel Safety Office commissions and approves |  | 1.85d | 2008-09-01 A | 2008-09-02 A |  | 100% |  |  |  |  |  |  |  |  |  |  |  |  |  |
| 207 | 6.1.2.1.6.4 | PPS integrated and tested with ISIS system |  | 4.62d | 2008-09-02 A | 2008-09-09 A | 206 | 100% |  |  |  |  |  |  |  |  |  |  |  |  |  |
| 208 | 6.1.2.1.6.5 | Hall PPS Step II ready | milestone | 0d | 2009-09-21 A | 2009-09-21 A | 207 | 100% |  | 2009-10-23 | 2009-10-23 | 0d |  |  | start no earlier than 2009-09-21 |  |  |  |  |  |  |
| 209 | 6.1.2.1.6.6 | **PPS Step IV** |  | 24d | 2011-09-12 | 2011-10-13 |  |  |  | 2011-04-27 | 2011-05-24 | 20d | 844d |  |  |  | 192h |  | 2,000 | 9,332 |  |
| 210 | 6.1.2.1.6.6.1 | Review mods required to PPS |  | 5d | 2011-09-12 | 2011-09-16 |  |  |  | 2011-04-27 | 2011-05-03 | 5d | 878d | 0d | start no earlier than 2011-09-12 | Electrical Designer | 40h |  | 2,000 | 3,880 |  |
| 211 | 6.1.2.1.6.6.2 | PPS electrical designs generated |  | 5d | 2011-09-19 | 2011-09-23 | 210 |  |  | 2011-05-04 | 2011-05-10 | 5d | 878d | 0d |  | Electrical Designer | 40h |  |  | 1,880 |  |
| 212 | 6.1.2.1.6.6.3 | PPS Hall Drawings provisionally accepted |  | 3d | 2011-09-26 | 2011-09-28 | 211 |  |  |  |  |  | 878d | 0d |  | Electrical Designer | 24h |  |  |  |  |
| 213 | 6.1.2.1.6.6.4 | Step IV Hall installation |  | 5d | 2011-09-29 | 2011-10-05 | 212 |  |  | 2011-05-11 | 2011-05-17 | 5d | 878d | 0d |  | Electrical Technician | 40h |  |  | 1,880 |  |
| 214 | 6.1.2.1.6.6.5 | Electrical commissioning |  | 3d | 2011-10-06 | 2011-10-10 | 213 |  |  | 2011-05-18 | 2011-05-20 | 3d | 878d | 0d |  | Electrical Designer; Electrical Technician [50%] | 36h |  |  | 1,692 |  |
| 215 | 6.1.2.1.6.6.6 | Personnel Safety Officer commissioning |  | 3d | 2011-10-11 | 2011-10-13 | 214 |  |  | 2011-05-23 | 2011-05-24 | 2d | 878d | 0d |  | Electrical Technician [25%]; Electrical Designer [25%] | 12h |  |  |  |  |
| 216 | 6.1.2.1.6.6.7 | Hall PPS Step IV ready | milestone | 0d | 2011-10-13 | 2011-10-13 | 215 |  |  | 2011-05-24 | 2011-05-24 | 0d | 878d |  |  |  |  |  |  |  |  |

| ID | WBS | Task | Type | Duration | Start | Finish | Predecessors | Complete | Remaining | Baseline start | Baseline finish | Baseline duration | Total slack | Free slack | Constraint | Resources | Work | Actual work | Cost | Baseline cost | Actual cost |
| --- | --- | --- | --- | --- | --- | --- | --- | --- | --- | --- | --- | --- | --- | --- | --- | --- | --- | --- | --- | --- | --- |
| 217 | 6.1.2.1.6.7 | **PPS Step V** |  | 24d | 2012-12-06 | 2013-01-08 |  |  |  | 2012-04-18 | 2012-05-15 | 20d | 549d |  |  |  | 220h |  | 2,000 | 9,520 |  |
| 218 | 6.1.2.1.6.7.1 | Review mods required to PPS |  | 5d | 2012-12-06 | 2012-12-12 |  |  |  | 2012-04-18 | 2012-04-24 | 5d | 583d | 0d | start no earlier than 2012-12-06 | Electrical Designer | 40h |  | 2,000 | 3,880 |  |
| 219 | 6.1.2.1.6.7.2 | PPS electrical designs generated |  | 5d | 2012-12-13 | 2012-12-19 | 218 |  |  | 2012-04-25 | 2012-05-01 | 5d | 583d | 0d |  | Electrical Designer | 40h |  |  | 1,880 |  |
| 220 | 6.1.2.1.6.7.3 | PPS Hall Drawings provisionally accepted |  | 3d | 2012-12-20 | 2012-12-24 | 219 |  |  |  |  |  | 583d | 0d |  | Electrical Designer | 24h |  |  |  |  |
| 221 | 6.1.2.1.6.7.4 | Step V Hall installation |  | 5d | 2012-12-25 | 2012-12-31 | 220 |  |  | 2012-05-02 | 2012-05-08 | 5d | 583d | 0d |  | Electrical Technician; Electrical Designer [25%] | 50h |  |  | 2,350 |  |
| 222 | 6.1.2.1.6.7.5 | Electrical commissioning |  | 3d | 2013-01-01 | 2013-01-03 | 221 |  |  | 2012-05-09 | 2012-05-11 | 3d | 583d | 0d |  | Electrical Designer; Electrical Technician [25%] | 30h |  |  | 1,410 |  |
| 223 | 6.1.2.1.6.7.6 | Personnel Safety Officer commissioning |  | 3d | 2013-01-04 | 2013-01-08 | 222 |  |  | 2012-05-14 | 2012-05-15 | 2d | 583d | 0d |  | Electrical Designer; Electrical Technician [50%] | 36h |  |  |  |  |
| 224 | 6.1.2.1.6.7.7 | Hall PPS Step V ready | milestone | 0d | 2013-01-08 | 2013-01-08 | 223 |  |  | 2012-05-15 | 2012-05-15 | 0d | 583d |  |  | Electrical Technician [25%]; Electrical Designer [25%] |  |  |  |  |  |
| 225 | 6.1.2.1.6.8 | **PPS Step VI** |  | 24d | 2013-05-09 | 2013-06-11 |  |  |  | 2012-11-21 | 2012-12-18 | 20d? | 439d |  |  |  | 220h |  | 2,000 | 9,520 |  |
| 226 | 6.1.2.1.6.8.1 | Review mods required to PPS |  | 5d | 2013-05-09 | 2013-05-15 |  |  |  | 2012-11-21 | 2012-11-27 | 5d | 473d | 0d | start no earlier than 2013-05-09 | Electrical Designer | 40h |  | 2,000 | 3,880 |  |
| 227 | 6.1.2.1.6.8.2 | PPS electrical designs generated |  | 5d | 2013-05-16 | 2013-05-22 | 226 |  |  | 2012-11-28 | 2012-12-04 | 5d | 473d | 0d |  | Electrical Designer | 40h |  |  | 1,880 |  |
| 228 | 6.1.2.1.6.8.3 | PPS Hall Drawings provisionally accepted |  | 3d | 2013-05-23 | 2013-05-27 | 227 |  |  |  |  |  | 473d | 0d |  | Electrical Designer | 24h |  |  |  |  |
| 229 | 6.1.2.1.6.8.4 | Step V Hall installation |  | 5d | 2013-05-28 | 2013-06-03 | 228 |  |  | 2012-12-05 | 2012-12-11 | 5d | 473d | 0d |  | Electrical Technician; Electrical Designer [25%] | 50h |  |  | 2,350 |  |
| 230 | 6.1.2.1.6.8.5 | Electrical commissioning |  | 3d | 2013-06-04 | 2013-06-06 | 229 |  |  | 2012-12-12 | 2012-12-14 | 3d | 473d | 0d |  | Electrical Designer; Electrical Technician [25%] | 30h |  |  | 1,410 |  |
| 231 | 6.1.2.1.6.8.6 | Personnel Safety Officer commissioning |  | 3d | 2013-06-07 | 2013-06-11 | 230 |  |  | 2012-12-17 | 2012-12-18 | 2d | 473d | 0d |  | Electrical Designer; Electrical Technician [50%] | 36h |  |  |  |  |
| 232 | 6.1.2.1.6.8.7 | Hall PPS Step V ready | milestone | 0d | 2013-06-11 | 2013-06-11 | 231 |  |  | 2012-12-18 | 2012-12-18 | 0d | 473d |  |  | Electrical Technician [25%]; Electrical Designer [25%] |  |  |  |  |  |
| 233 | 6.1.2.2 | **MICE Hall compressors** |  | 857.62d | 2009-02-11 A | 2012-08-14 |  | 90% | 87.35d | 2009-03-09 | 2010-05-24 | 316d | 688.38d |  |  |  | 652.2h | 587.4h | 21,000 | 44,688 | 20,800 |
| 234 | 6.1.2.2.1 | Compressor Hardware Fixed and Agreed | milestone | 0d | 2009-03-09 A | 2009-03-09 A |  | 100% |  | 2009-03-09 | 2009-03-09 | 0d |  |  | start no earlier than 2009-03-09 |  |  |  | 17,000 | 17,000 | 17,000 |
| 235 | 6.1.2.2.2 | Design AC distribution |  | 10d | 2009-03-09 A | 2009-03-20 A | 234 | 100% |  | 2009-03-09 | 2009-03-20 | 10d |  |  | start no earlier than 2009-01-26 | Electrical Designer | 80h | 80h |  | 3,760 |  |
| 236 | 6.1.2.2.3 | Design/ agree equipment layout |  | 10d | 2009-04-13 A | 2009-04-24 A | 235 | 100% |  | 2009-04-13 | 2009-04-24 | 10d |  |  | start no earlier than 2009-04-13 | Electrical Designer | 80h | 80h |  | 3,760 |  |
| 237 | 6.1.2.2.4 | Install main cable management |  | 15d | 2009-06-08 A | 2009-06-26 A | 236 | 100% |  | 2009-06-08 | 2009-06-26 | 15d |  |  | start no earlier than 2009-06-08 | Electrical Technician | 120h | 120h |  | 5,640 |  |
| 238 | 6.1.2.2.5 | Install main sub distribution boards |  | 9.25d | 2009-11-02 A | 2009-11-13 A | 237 | 100% |  |  |  |  |  |  | start no earlier than 2009-11-02 | Electrical Technician | 74h | 74h |  |  |  |
| 239 | 6.1.2.2.6 | Test and energise main sub-distribution boards |  | 0.93d | 2010-03-04 A | 2010-03-04 A | 238 | 100% |  |  |  |  |  |  | start no earlier than 2010-03-04 | Electrical Technician | 7.4h | 7.4h |  |  |  |
| 240 | 6.1.2.2.7 | Compressor cooling system review requirements |  | 1.85d | 2010-03-18 A | 2010-03-22 A | 239FS+9.25d | 100% |  |  |  |  |  |  |  | Electrical Designer | 14.8h | 14.8h |  |  |  |

| ID | WBS | Task | Type | Duration | Start | Finish | Predecessors | Complete | Remaining | Baseline start | Baseline finish | Baseline duration | Total slack | Free slack | Constraint | Resources | Work | Actual work | Cost | Baseline cost | Actual cost |
| --- | --- | --- | --- | --- | --- | --- | --- | --- | --- | --- | --- | --- | --- | --- | --- | --- | --- | --- | --- | --- | --- |
| 241 | 6.1.2.2.8 | **Tracker # 1 Compressors** |  | 476.98d | 2010-03-22 A | 2012-04-06 | 240 | 99% | 0d | 2009-09-24 | 2009-10-02 | 7d | 747d |  |  |  | 37h | 37h | 1,000 | 3,632 | 1,000 |
| 242 | 6.1.2.2.8.1 | Install local cable management |  | 0.93d | 2010-03-22 A | 2010-03-22 A |  | 100% |  | 2009-09-24 | 2009-09-25 | 2d |  |  | start no earlier than 2009-09-24 | Electrical Technician | 7.4h | 7.4h | 1,000 | 1,752 | 1,000 |
| 243 | 6.1.2.2.8.2 | Install cables to local outlet |  | 1.85d | 2010-03-22 A | 2010-03-24 A | 242 | 100% |  | 2009-09-28 | 2009-09-30 | 3d |  |  |  | Electrical Technician | 14.8h | 14.8h |  | 1,128 |  |
| 244 | 6.1.2.2.8.3 | Compressors available for installation | milestone | 0d | 2012-04-06 | 2012-04-06 | 243 |  |  | 2009-09-30 | 2009-09-30 | 0d | 781d | 0d | start no earlier than 2012-04-06 |  |  |  |  |  |  |
| 245 | 6.1.2.2.8.4 | Terminate and install local ac cables |  | 1.85d | 2010-03-23 A | 2010-03-24 A |  | 100% |  | 2009-10-01 | 2009-10-02 | 2d |  |  | start no earlier than 2010-03-23 | Electrical Technician | 14.8h | 14.8h |  | 752 |  |
| 246 | 6.1.2.2.8.5 | Tracker#1 compressor electrical complete | milestone | 0d | 2012-04-06 | 2012-04-06 | 244 |  |  |  |  |  | 781d |  |  |  |  |  |  |  |  |
| 247 | 6.1.2.2.9 | **Spectrometer Soleniod Compressors # 1** |  | 60.4d | 2012-01-09 A | 2012-04-02 | 245, 44 | 56% | 26.58d | 2009-12-01 | 2009-12-09 | 7d | 784.6d |  |  |  | 80h | 44.8h | 1,000 | 3,632 | 800 |
| 248 | 6.1.2.2.9.1 | Install local cable management |  | 3d | 2012-01-09 A | 2012-03-27 |  | 80% | 0.6d | 2009-12-01 | 2009-12-02 | 2d | 784.6d | 0d | start no earlier than 2009-12-01 | Electrical Technician | 24h | 19.2h | 1,000 | 1,752 | 800 |
| 249 | 6.1.2.2.9.2 | Install cables |  | 4d | 2012-01-12 A | 2012-03-28 | 248 | 80% | 0.8d | 2009-12-03 | 2009-12-07 | 3d | 784.6d | 0d |  | Electrical Technician | 32h | 25.6h |  | 1,128 |  |
| 250 | 6.1.2.2.9.3 | Compressors available for installation | milestone | 0d | 2012-03-28 | 2012-03-28 | 249 |  |  | 2009-12-07 | 2009-12-07 | 0d | 784.6d | 0d | start no earlier than 2009-12-07 |  |  |  |  |  |  |
| 251 | 6.1.2.2.9.4 | Terminate and install local ac cables |  | 3d | 2012-03-28 | 2012-04-02 | 250 |  |  | 2009-12-08 | 2009-12-09 | 2d | 784.6d | 0d |  | Electrical Technician | 24h |  |  | 752 |  |
| 252 | 6.1.2.2.9.5 | Spectrometer Soleniod # 1 compressors complete | milestone | 0d | 2012-04-02 | 2012-04-02 | 251 |  |  |  |  |  | 784.6d |  |  |  |  |  |  |  |  |
| 253 | 6.1.2.2.10 | **Tracker # 2 Compressors** |  | 4.62d | 2012-08-08 A | 2012-08-14 |  | 20% | 3.7d | 2010-01-28 | 2010-02-05 | 7d | 688.38d |  |  |  | 37h | 7.4h | 1,000 | 3,632 | 1,000 |
| 254 | 6.1.2.2.10.1 | Install local cable management |  | 0.93d | 2012-08-08 A | 2012-08-08 A | 884 | 100% |  | 2010-01-28 | 2010-01-29 | 2d |  |  | start no earlier than 2010-01-28 | Electrical Technician | 7.4h | 7.4h | 1,000 | 1,752 | 1,000 |
| 255 | 6.1.2.2.10.2 | Install cables |  | 1.85d | 2012-08-08 | 2012-08-10 | 254 |  |  | 2010-02-01 | 2010-02-03 | 3d | 688.38d | 0d |  | Electrical Technician | 14.8h |  |  | 1,128 |  |
| 256 | 6.1.2.2.10.3 | Compressors available for installation | milestone | 0d | 2012-08-10 | 2012-08-10 | 255 |  |  | 2010-02-03 | 2010-02-03 | 0d | 688.38d | 0d | start no earlier than 2009-09-28 |  |  |  |  |  |  |
| 257 | 6.1.2.2.10.4 | Terminate cables |  | 1.85d | 2012-08-10 | 2012-08-14 | 256 |  |  | 2010-02-04 | 2010-02-05 | 2d | 688.38d | 0d |  | Electrical Technician | 14.8h |  |  | 752 |  |
| 258 | 6.1.2.2.10.5 | Tracker#2 electrical complete | milestone | 0d | 2012-08-14 | 2012-08-14 | 257 |  |  |  |  |  | 688.38d |  |  |  |  |  |  |  |  |
| 259 | 6.1.2.2.11 | **Spectrometer Soleniod Compressors # 2** |  | 4d | 2009-02-11 A | 2009-02-16 A | 257 | 100% |  | 2010-05-14 | 2010-05-24 | 7d |  |  |  |  | 48h | 48h |  | 3,632 |  |
| 260 | 6.1.2.2.11.1 | Produce AC distribution for systems |  | 4d | 2009-02-11 A | 2009-02-16 A |  | 100% |  | 2009-02-11 | 2009-02-16 | 4d |  |  |  | Electrical Designer; Electrical Engineer [50%] | 48h | 48h |  | 2,256 |  |
| 261 | 6.1.2.2.12 | **DSA** |  | 82.78d | 2009-06-08 A | 2009-09-30 A |  | 100% |  | 2009-10-26 | 2009-11-10 | 12d |  |  |  |  | 74h | 74h | 1,000 | 12,012 | 1,000 |
| 262 | 6.1.2.2.12.1 | **PPS Step II** |  | 2.77d | 2009-06-08 A | 2009-06-10 A |  | 100% |  | 2009-06-15 | 2009-10-23 | 95d |  |  |  |  | 22.2h | 22.2h | 1,000 | 43,370 | 1,000 |
| 263 | 6.1.2.2.12.1.1 | Install local cable management |  | 2.77d | 2009-06-08 A | 2009-06-10 A |  | 100% |  | 2010-05-14 | 2010-05-17 | 2d |  |  | start no earlier than 2009-06-08 | Electrical Technician | 22.2h | 22.2h | 1,000 | 1,752 | 1,000 |
| 264 | 6.1.2.2.12.2 | Install cables |  | 3.7d | 2009-06-10 A | 2009-06-16 A | 263 | 100% |  | 2010-05-18 | 2010-05-20 | 3d |  |  |  | Electrical Technician | 29.6h | 29.6h |  | 1,128 |  |
| 265 | 6.1.2.2.12.3 | Compressors available for installation | milestone | 0d | 2009-09-28 A | 2009-09-28 A | 264 | 100% |  | 2010-05-20 | 2010-05-20 | 0d |  |  | start no earlier than 2009-09-28 |  |  |  |  |  |  |
| 266 | 6.1.2.2.12.4 | Terminate cables |  | 2.77d | 2009-09-28 A | 2009-09-30 A | 265 | 100% |  | 2010-05-21 | 2010-05-24 | 2d |  |  |  | Electrical Technician | 22.2h | 22.2h |  | 752 |  |

| ID | WBS | Task | Type | Duration | Start | Finish | Predecessors | Complete | Remaining | Baseline start | Baseline finish | Baseline duration | Total slack | Free slack | Constraint | Resources | Work | Actual work | Cost | Baseline cost | Actual cost |
| --- | --- | --- | --- | --- | --- | --- | --- | --- | --- | --- | --- | --- | --- | --- | --- | --- | --- | --- | --- | --- | --- |
| 267 | 6.1.2.3 | **Vacuum System (Matt Hills& Mike Courtold)** |  | 70d | 2011-05-02 | 2011-09-15 |  |  |  |  |  |  | 898d |  |  |  | 544h |  | 3,000 |  |  |
| 268 | 6.1.2.3.1 | Review Vacuum requirements |  | 5d | 2011-05-02 | 2011-05-06 |  |  |  |  |  |  | 898d | 0d | start no earlier than 2011-05-02 | Electrical Designer | 40h |  |  |  |  |
| 269 | 6.1.2.3.2 | Design Vacuum system and racks |  | 19d | 2011-05-09 | 2011-06-02 | 268 |  |  |  |  |  | 898d | 0d |  | Electrical Designer | 152h |  |  |  |  |
| 270 | 6.1.2.3.3 | Assembe Vacuum racks |  | 24d | 2011-06-03 | 2011-08-16 | 269 |  |  |  |  |  | 898d | 0d |  | Electrical Technician | 192h |  | 3,000 |  |  |
| 271 | 6.1.2.3.4 | Test Vacuum system |  | 5d | 2011-08-17 | 2011-08-23 | 270 |  |  |  |  |  | 898d | 0d |  | Electrical Designer | 40h |  |  |  |  |
| 272 | 6.1.2.3.5 | Transfer Vacuum system to RAL |  | 2d | 2011-08-24 | 2011-08-25 | 271 |  |  |  |  |  | 898d | 0d |  |  |  |  |  |  |  |
| 273 | 6.1.2.3.6 | Install Vacuum system in MICE Hall |  | 10d | 2011-08-26 | 2011-09-08 | 272 |  |  |  |  |  | 898d | 0d |  | Electrical Technician | 80h |  |  |  |  |
| 274 | 6.1.2.3.7 | Commission Vacuum system |  | 5d | 2011-09-09 | 2011-09-15 | 273 |  |  |  |  |  | 898d | 0d |  | Electrical Designer | 40h |  |  |  |  |
| 275 | 6.1.2.3.8 | Vacuum System Ready for operation | milestone | 0d | 2011-09-15 | 2011-09-15 | 274 |  |  |  |  |  | 898d |  |  |  |  |  |  |  |  |
| 276 | 6.1.2.4 | **Hall HV AC Network Upgrade (JW Morris- Build Proj Group)** |  | 717d | 2008-09-01 A | 2011-05-31 |  | 93% | 47.92d |  |  |  | 946d |  |  |  | 297.2h | 253.2h | 80,000 |  | 80,000 |
| 277 | 6.1.2.4.1 | Finance approved | milestone | 0d | 2010-09-20 A | 2010-09-20 A |  | 100% |  |  |  |  |  |  | start no earlier than 2010-09-20 |  |  |  | 80,000 |  | 80,000 |
| 278 | 6.1.2.4.2 | Tender exercise |  | 55.5d | 2008-09-01 A | 2008-11-17 A |  | 100% |  |  |  |  |  |  |  | Electrical Engineer [20%] | 88.8h | 88.8h |  |  |  |
| 279 | 6.1.2.4.3 | Review and award contract |  | 10d | 2008-11-17 A | 2008-12-01 A | 278 | 100% |  |  |  |  |  |  |  | Electrical Engineer | 80h | 80h |  |  |  |
| 280 | 6.1.2.4.4 | Procurement period |  | 111d | 2010-03-04 A | 2010-08-05 A | 279 | 100% |  |  |  |  |  |  | start no earlier than 2010-03-04 | Electrical Engineer [5%] | 44.4h | 44.4h |  |  |  |
| 281 | 6.1.2.4.5 | MICE Hall AC Network installation preparation |  | 5d | 2010-08-06 A | 2010-08-12 A | 280 | 100% |  |  |  |  |  |  |  | Electrical Technician | 40h | 40h |  |  |  |
| 282 | 6.1.2.4.6 | Agreed date for installation to start | milestone | 0d | 2011-05-13 A | 2011-05-13 A |  | 100% |  |  |  |  |  |  | start no earlier than 2011-05-13 |  |  |  |  |  |  |
| 283 | 6.1.2.4.7 | HV Network installation by contractors |  | 5d | 2011-05-13 | 2011-05-19 | 282 |  |  |  |  |  | 946d | 0d |  | Electrical Engineer [50%] | 20h |  |  |  |  |
| 284 | 6.1.2.4.8 | Install Fencing |  | 5d | 2011-05-20 | 2011-05-26 | 283 |  |  |  |  |  | 946d | 0d |  |  |  |  |  |  |  |
| 285 | 6.1.2.4.9 | Commission and Handover of system |  | 3d | 2011-05-27 | 2011-05-31 | 284 |  |  |  |  |  | 946d | 0d |  | Electrical Engineer | 24h |  |  |  |  |
| 286 | 6.1.2.4.10 | HV AC Network Upgrade complete | milestone | 0d | 2011-05-31 | 2011-05-31 | 285 |  |  |  |  |  | 946d |  |  |  |  |  |  |  |  |
| 287 | 6.1.2.5 | **TOF 01 & 02** |  | 1339.47d | 2009-10-05 A | 2015-02-10 |  | 42% | 771.16d | 2009-12-10 | 2012-11-07 | 760d | 38.52d |  |  |  | 331.4h | 144h | 4,500 | 20,796 | 1,500 |
| 288 | 6.1.2.5.1 | **TOF 01** |  | 7d | 2009-10-05 A | 2009-10-13 A |  | 100% |  | 2009-12-10 | 2009-12-18 | 7d |  |  |  |  | 56h | 56h | 500 | 3,132 | 500 |
| 289 | 6.1.2.5.1.1 | Define new cable management routes |  | 2d | 2009-10-05 A | 2009-10-06 A |  | 100% |  | 2009-12-10 | 2009-12-11 | 2d |  |  | start no earlier than 2009-10-05 | Electrical Designer | 16h | 16h | 500 | 1,252 | 500 |
| 290 | 6.1.2.5.1.2 | Install additional cable management |  | 2d | 2009-10-07 A | 2009-10-08 A | 289 | 100% |  | 2009-12-14 | 2009-12-15 | 2d |  |  |  | Electrical Technician | 16h | 16h |  | 752 |  |
| 291 | 6.1.2.5.1.3 | Re-route cables |  | 3d | 2009-10-09 A | 2009-10-13 A | 290 | 100% |  | 2009-12-16 | 2009-12-18 | 3d |  |  |  | Electrical Technician | 24h | 24h |  | 1,128 |  |
| 292 | 6.1.2.5.1.4 | TOF 01 electrical complete | milestone | 0d | 2009-10-13 A | 2009-10-13 A | 291 | 100% |  | 2009-12-18 | 2009-12-18 | 0d |  |  |  |  |  |  |  |  |  |

| ID | WBS | Task | Type | Duration | Start | Finish | Predecessors | Complete | Remaining | Baseline start | Baseline finish | Baseline duration | Total slack | Free slack | Constraint | Resources | Work | Actual work | Cost | Baseline cost | Actual cost |
| --- | --- | --- | --- | --- | --- | --- | --- | --- | --- | --- | --- | --- | --- | --- | --- | --- | --- | --- | --- | --- | --- |
| 293 | 6.1.2.5.2 | **TOF 02** |  | 731d | 2009-11-02 A | 2012-11-07 | 292 | 69% | 228.44d | 2009-12-21 | 2012-11-07 | 753d | 593d |  |  |  | 120h | 88h | 1,000 | 17,664 | 1,000 |
| 294 | 6.1.2.5.2.1 | Produce electrical design |  | 2d | 2009-11-02 A | 2009-11-03 A |  | 100% |  | 2009-12-21 | 2009-12-22 | 2d |  |  | start no earlier than 2009-11-02 | Electrical Designer | 16h | 16h | 1,000 | 1,752 | 1,000 |
| 295 | 6.1.2.5.2.2 | Evaluate cable / system requirements TOF2 |  | 2d | 2009-11-04 A | 2009-11-05 A | 294 | 100% |  | 2009-12-23 | 2009-12-24 | 2d |  |  | start no earlier than 2009-05-18 | Electrical Designer | 16h | 16h |  | 752 |  |
| 296 | 6.1.2.5.2.3 | Cables Supplied / Delivered | milestone | 0d | 2009-11-05 A | 2009-11-05 A | 295 | 100% |  | 2009-12-24 | 2009-12-24 | 0d |  |  |  |  |  |  |  |  |  |
| 297 | 6.1.2.5.2.4 | Install additional cable management |  | 2d | 2009-11-06 A | 2009-11-09 A | 296 | 100% |  | 2009-12-25 | 2009-12-28 | 2d |  |  |  | Electrical Technician | 16h | 16h |  | 752 |  |
| 298 | 6.1.2.5.2.5 | Install cables |  | 5d | 2009-11-10 A | 2009-11-16 A | 297 | 100% |  | 2009-12-29 | 2010-01-04 | 5d |  |  |  | Electrical Technician | 40h | 40h |  | 1,880 |  |
| 299 | 6.1.2.5.2.6 | TOF 02 electrical complete - temporary position | milestone | 0d | 2009-11-16 A | 2009-11-16 A | 298 | 100% |  | 2010-01-04 | 2010-01-04 | 0d |  |  |  |  |  |  |  |  |  |
| 300 | 6.1.2.5.2.7 | TOF02 Ready for repositioning | milestone | 0d | 2012-11-01 | 2012-11-01 | 299 |  |  |  |  |  | 624d | 0d | start no earlier than 2012-11-01 |  |  |  |  |  |  |
| 301 | 6.1.2.5.2.8 | Disconnect TOF02 and install additional cable tray |  | 2d | 2012-11-01 | 2012-11-02 | 300 |  |  |  |  |  | 627d | 0d |  | Electrical Technician | 16h |  |  |  |  |
| 302 | 6.1.2.5.2.9 | Reposition TOF 02 |  | 1d | 2012-11-05 | 2012-11-05 | 301 |  |  |  |  |  | 627d | 0d |  |  |  |  |  |  |  |
| 303 | 6.1.2.5.2.10 | Recable to new position |  | 2d | 2012-11-06 | 2012-11-07 | 302 |  |  |  |  |  | 627d | 0d |  | Electrical Technician | 16h |  |  |  |  |
| 304 | 6.1.2.5.2.11 | TOF02 Step II electrical complete | milestone | 0d | 2012-11-07 | 2012-11-07 | 303 |  |  |  |  |  | 627d |  |  |  |  |  |  |  |  |
| 305 | 6.1.2.5.3 | **TOF 02 - Step IV** |  | 6.47d | 2012-10-01 | 2012-10-09 |  |  |  | 2011-04-05 | 2011-04-13 | 7d | 648.52d |  |  |  | 51.8h |  | 1,000 | 3,132 |  |
| 306 | 6.1.2.5.3.1 | Define new cable management routes |  | 1.85d | 2012-10-01 | 2012-10-02 | 886SS |  |  | 2011-04-05 | 2011-04-06 | 2d | 648.52d | 0d | start no earlier than 2010-04-12 | Electrical Designer | 14.8h |  | 1,000 | 1,252 |  |
| 307 | 6.1.2.5.3.2 | Install additional cable management |  | 1.85d | 2012-10-02 | 2012-10-04 | 306 |  |  | 2011-04-07 | 2011-04-08 | 2d | 648.52d | 0d |  | Electrical Technician | 14.8h |  |  | 752 |  |
| 308 | 6.1.2.5.3.3 | Re-route cables |  | 2.77d | 2012-10-04 | 2012-10-09 | 307 |  |  | 2011-04-11 | 2011-04-13 | 3d | 648.52d | 0d |  | Electrical Technician | 22.2h |  |  | 1,128 |  |
| 309 | 6.1.2.5.3.4 | TOF 02 electrical complete | milestone | 0d | 2012-10-09 | 2012-10-09 | 308 |  |  | 2011-04-13 | 2011-04-13 | 0d | 648.52d |  |  |  |  |  |  |  |  |
| 310 | 6.1.2.5.4 | **TOF 02 - Step V** |  | 6.47d | 2013-12-02 | 2013-12-10 |  |  |  | 2012-03-27 | 2012-04-04 | 7d | 343.52d |  |  |  | 51.8h |  | 1,000 | 3,132 |  |
| 311 | 6.1.2.5.4.1 | Define new cable management routes |  | 1.85d | 2013-12-02 | 2013-12-03 | 944SS |  |  | 2012-03-27 | 2012-03-28 | 2d | 343.52d | 0d | start no earlier than 2010-04-12 | Electrical Designer | 14.8h |  | 1,000 | 1,252 |  |
| 312 | 6.1.2.5.4.2 | Install additional cable management |  | 1.85d | 2013-12-03 | 2013-12-05 | 311 |  |  | 2012-03-29 | 2012-03-30 | 2d | 343.52d | 0d |  | Electrical Technician | 14.8h |  |  | 752 |  |
| 313 | 6.1.2.5.4.3 | Re-route cables |  | 2.77d | 2013-12-05 | 2013-12-10 | 312 |  |  | 2012-04-02 | 2012-04-04 | 3d | 343.52d | 0d |  | Electrical Technician | 22.2h |  |  | 1,128 |  |
| 314 | 6.1.2.5.4.4 | TOF 02 electrical complete | milestone | 0d | 2013-12-10 | 2013-12-10 | 313 |  |  | 2012-04-04 | 2012-04-04 | 0d | 343.52d |  |  |  |  |  |  |  |  |
| 315 | 6.1.2.5.5 | **TOF 02 - Step VI** |  | 6.47d | 2015-02-02 | 2015-02-10 |  |  |  | 2012-10-30 | 2012-11-07 | 7d | 38.52d |  |  |  | 51.8h |  | 1,000 | 3,132 |  |
| 316 | 6.1.2.5.5.1 | Define new cable management routes |  | 1.85d | 2015-02-02 | 2015-02-03 | 1004SS |  |  | 2012-10-30 | 2012-10-31 | 2d | 38.52d | 0d | start no earlier than 2010-04-12 | Electrical Designer | 14.8h |  | 1,000 | 1,252 |  |
| 317 | 6.1.2.5.5.2 | Install additional cable management |  | 1.85d | 2015-02-03 | 2015-02-05 | 316 |  |  | 2012-11-01 | 2012-11-02 | 2d | 38.52d | 0d |  | Electrical Technician | 14.8h |  |  | 752 |  |
| 318 | 6.1.2.5.5.3 | Re-route cables |  | 2.77d | 2015-02-05 | 2015-02-10 | 317 |  |  | 2012-11-05 | 2012-11-07 | 3d | 38.52d | 0d |  | Electrical Technician | 22.2h |  |  | 1,128 |  |
| 319 | 6.1.2.5.5.4 | TOF 02 electrical complete | milestone | 0d | 2015-02-10 | 2015-02-10 | 318 |  |  | 2012-11-07 | 2012-11-07 | 0d | 38.52d |  |  |  |  |  |  |  |  |

| ID | WBS | Task | Type | Duration | Start | Finish | Predecessors | Complete | Remaining | Baseline start | Baseline finish | Baseline duration | Total slack | Free slack | Constraint | Resources | Work | Actual work | Cost | Baseline cost | Actual cost |
| --- | --- | --- | --- | --- | --- | --- | --- | --- | --- | --- | --- | --- | --- | --- | --- | --- | --- | --- | --- | --- | --- |
| 320 | 6.1.2.6 | **Tracker / Spectrometer Soleniod # 1** |  | 788d | 2009-03-02 A | 2012-05-25 |  | 46% | 424.42d | 2009-03-02 | 2010-01-15 | 230d | 745d |  |  |  | 2546.4h | 1384.18h | 41,000 | 107,640 | 32,830 |
| 321 | 6.1.2.6.1 | Prepare Hall and cable ducts for installation |  | 5d | 2009-04-20 A | 2009-04-24 A |  | 100% |  | 2009-04-20 | 2009-04-24 | 5d |  |  | start no earlier than 2009-04-20 | Electrical Technician | 40h | 40h |  | 1,880 |  |
| 322 | 6.1.2.6.2 | **Tracker** |  | 643d | 2009-09-14 A | 2012-05-18 |  | 58% | 272.42d | 2009-09-14 | 2010-01-15 | 90d | 750d |  |  |  | 278h | 222h | 3,500 | 11,400 | 2,000 |
| 323 | 6.1.2.6.2.1 | Produce rack layout drawings |  | 9.25d | 2009-09-14 A | 2010-03-15 A | 321 | 100% |  | 2009-09-14 | 2009-10-28 | 33d |  |  | start no earlier than 2009-09-14 | Electrical Designer | 74h | 74h | 2,000 | 5,760 | 2,000 |
| 324 | 6.1.2.6.2.2 | Tracker system available for modification | milestone | 0d | 2010-07-19 A | 2010-07-19 A |  | 100% |  |  |  |  |  |  | start no earlier than 2010-07-19 |  |  |  |  |  |  |
| 325 | 6.1.2.6.2.3 | Re-house equipment in new rack |  | 4.62d | 2010-07-19 A | 2010-07-23 A | 323, 324 | 100% |  | 2009-10-29 | 2009-11-04 | 5d |  |  | start no earlier than 2010-04-14 | Electrical Technician | 37h | 37h |  | 1,880 |  |
| 326 | 6.1.2.6.2.4 | Agree/ design Control interface |  | 9.25d | 2010-07-23 A | 2010-08-05 A | 325 | 100% |  | 2009-11-05 | 2009-11-09 | 3d |  |  |  | Electrical Designer; Electrical Technician [50%] | 111h | 111h |  | 1,128 |  |
| 327 | 6.1.2.6.2.5 | Tracker rack available for installation | milestone | 0d | 2011-02-14 A | 2011-02-14 A | 326 | 100% |  |  |  |  |  |  | start no earlier than 2011-02-14 |  |  |  |  |  |  |
| 328 | 6.1.2.6.2.6 | Install Tracker rack in MICE Hall |  | 2d | 2011-03-14 | 2011-03-15 | 323, 327 |  |  | 2009-11-10 | 2009-11-11 | 2d | 1001d |  | start no earlier than 2011-03-14 | Electrical Technician | 16h |  |  | 752 |  |
| 329 | 6.1.2.6.2.7 | Tracker Installation |  | 10d | 2012-04-30 | 2012-05-11 | 324, 388, 362SS+14.8d |  |  | 2010-01-11 | 2010-01-11 | 0d | 750d | 0d | start no earlier than 2010-01-11 |  |  |  |  |  |  |
| 330 | 6.1.2.6.2.8 | Install cables and terminate |  | 5d | 2012-05-14 | 2012-05-18 | 326, 329 |  |  | 2010-01-11 | 2010-01-15 | 5d | 750d | 5d |  | Electrical Technician | 40h |  | 1,500 | 1,880 |  |
| 331 | 6.1.2.6.3 | **Diffuser** |  | 387.62d | 2009-05-11 A | 2010-11-03 |  | 61% | 151.45d | 2009-05-11 | 2009-08-10 | 66d | 1061.38d |  |  |  | 126.8h | 62.8h | 1,500 | 7,392 | 1,000 |
| 332 | 6.1.2.6.3.1 | Understand requirements |  | 3d | 2009-05-11 A | 2009-05-13 A |  | 100% |  | 2009-05-11 | 2009-05-13 | 3d |  |  | start no earlier than 2009-05-11 | Electrical Designer | 24h | 24h | 1,000 | 2,128 | 1,000 |
| 333 | 6.1.2.6.3.2 | Design rack layout / cable schedule |  | 3d | 2009-05-14 A | 2009-05-18 A | 332 | 100% |  | 2009-05-14 | 2009-05-18 | 3d |  |  |  | Electrical Designer | 24h | 24h |  | 1,128 |  |
| 334 | 6.1.2.6.3.3 | Clarification of rack space availability | milestone | 0d | 2010-04-12 A | 2010-04-12 A | 333 | 100% |  |  |  |  |  |  | start no earlier than 2010-04-12 |  |  |  |  |  |  |
| 335 | 6.1.2.6.3.4 | Provide assembled rack for equipment population |  | 1.85d | 2010-05-18 A | 2010-05-19 A | 334 | 100% |  | 2009-07-27 | 2009-07-29 | 3d |  |  | start no earlier than 2010-05-18 | Electrical Technician | 14.8h | 14.8h |  | 1,128 |  |
| 336 | 6.1.2.6.3.5 | Modify and populate rack |  | 4.62d | 2010-10-18 A | 2010-10-22 A | 335 | 100% |  |  |  |  |  |  | start no earlier than 2010-10-18 |  |  |  |  |  |  |
| 337 | 6.1.2.6.3.6 | Install diffuser rack |  | 2d | 2010-10-22 | 2010-10-26 | 336 |  |  | 2009-07-30 | 2009-08-03 | 3d | 1095.38d | 0d |  | Electrical Technician | 16h |  |  | 1,128 |  |
| 338 | 6.1.2.6.3.7 | Diffuser installed | milestone | 0d | 2010-10-26 | 2010-10-26 | 337 |  |  |  |  |  | 1095.38d | 0d | start no earlier than 2010-05-10 |  |  |  |  |  |  |
| 339 | 6.1.2.6.3.8 | Install cables and terminate |  | 6d | 2010-10-26 | 2010-11-03 | 338 |  |  | 2009-08-04 | 2009-08-10 | 5d | 1095.38d | 0d |  | Electrical Technician | 48h |  | 500 | 1,880 |  |
| 340 | 6.1.2.6.3.9 | Diffuser electrical complete | milestone | 0d | 2010-11-03 | 2010-11-03 | 339 |  |  | 2009-08-10 | 2009-08-10 | 0d | 1095.38d | 350.38d |  |  |  |  |  |  |  |
| 341 | 6.1.2.6.4 | **AC Distribution - Main circuits to racks** |  | 123d | 2009-08-17 A | 2010-02-03 |  | 88% | 15.15d | 2009-08-17 | 2009-10-21 | 48d | 1256d |  |  |  | 188.4h | 165.2h | 2,000 | 8,016 | 2,000 |
| 342 | 6.1.2.6.4.1 | Understand AC distribution requirements |  | 5.55d | 2009-08-17 A | 2009-08-24 A |  | 100% |  | 2009-08-17 | 2009-08-21 | 5d |  |  | start no earlier than 2009-08-17 | Electrical Designer | 44.4h | 44.4h | 2,000 | 3,880 | 2,000 |
| 343 | 6.1.2.6.4.2 | Design AC infrastructure and layout |  | 8d | 2009-11-18 A | 2009-11-27 | 342 | 95% | 0.4d | 2009-08-24 | 2009-09-01 | 7d | 1335.5d | 0d | start no earlier than 2009-11-18 | Electrical Designer | 64h | 60.8h |  | 2,632 |  |
| 344 | 6.1.2.6.4.3 | Install AC distribution |  | 10d | 2009-11-30 A | 2010-02-03 | 343 | 75% | 2.5d | 2009-10-16 | 2009-10-21 | 4d | 1290d |  | start no earlier than 2009-10-16 | Electrical Technician | 80h | 60h |  | 1,504 |  |

| ID | WBS | Task | Type | Duration | Start | Finish | Predecessors | Complete | Remaining | Baseline start | Baseline finish | Baseline duration | Total slack | Free slack | Constraint | Resources | Work | Actual work | Cost | Baseline cost | Actual cost |
| --- | --- | --- | --- | --- | --- | --- | --- | --- | --- | --- | --- | --- | --- | --- | --- | --- | --- | --- | --- | --- | --- |
| 345 | 6.1.2.6.5 | **AC Distribution - Local outlets/sockets** |  | 25d | 2010-10-11 A | 2010-11-12 |  | 20% | 20d |  |  |  | 1044d |  |  |  | 120h | 40h |  |  |  |
| 346 | 6.1.2.6.5.1 | Design local distribution for cooling channel racks / circuits |  | 5d | 2010-10-11 A | 2010-10-15 A | 344 | 100% |  |  |  |  |  |  | start no earlier than 2010-10-11 | Electrical Designer | 40h | 40h |  |  |  |
| 347 | 6.1.2.6.5.2 | Procure / assemble distribution equipment |  | 5d | 2010-10-18 | 2010-10-22 | 346 |  |  |  |  |  | 1078d | 0d |  | Electrical Designer | 40h |  |  |  |  |
| 348 | 6.1.2.6.5.3 | Assemble distribution rack / cabinet |  | 10d | 2010-10-25 | 2010-11-05 | 347 |  |  |  |  |  | 1078d | 0d |  |  |  |  |  |  |  |
| 349 | 6.1.2.6.5.4 | Install local rack / AC distribution in Hall |  | 3d | 2010-11-08 | 2010-11-10 | 348 |  |  |  |  |  | 1078d | 0d |  | Electrical Technician | 24h |  |  |  |  |
| 350 | 6.1.2.6.5.5 | Test local AC distribution in MICE Hall |  | 2d | 2010-11-11 | 2010-11-12 | 349 |  |  |  |  |  | 1078d | 333d |  | Electrical Designer | 16h |  |  |  |  |
| 351 | 6.1.2.6.6 | **Spectrometer Soleniod** |  | 770d | 2009-03-02 A | 2012-05-01 |  | 34% | 508.71d | 2009-03-02 | 2009-12-09 | 203d | 763d |  |  |  | 752.8h | 324.68h | 7,500 | 19,736 | 2,830 |
| 352 | 6.1.2.6.6.1 | Evaluate cable / system requirements |  | 14.8d | 2009-03-02 A | 2009-05-25 A |  | 100% |  | 2009-03-02 | 2009-05-25 | 61d |  |  |  | Electrical Designer | 118.4h | 118.4h | 1,500 | 7,140 | 1,500 |
| 353 | 6.1.2.6.6.2 | Electrical rack design and assembly |  | 9.25d | 2009-05-26 A | 2009-06-26 A | 352 | 100% |  | 2009-05-26 | 2009-06-26 | 24d |  |  |  | Electrical Designer | 74h | 74h |  | 3,760 |  |
| 354 | 6.1.2.6.6.3 | Racks issued to WANG for population |  | 5.55d | 2009-06-29 A | 2009-07-06 A | 353 | 100% |  | 2009-06-29 | 2009-07-03 | 5d |  |  |  | Electrical Technician | 44.4h | 44.4h |  | 1,880 |  |
| 355 | 6.1.2.6.6.4 | Review cable management |  | 3d | 2010-06-07 A | 2010-06-09 | 354, 382 | 56% | 1.33d | 2009-07-06 | 2009-07-08 | 3d | 1200d |  | start no earlier than 2010-01-25 | Electrical Designer | 24h | 13.32h |  | 1,128 |  |
| 356 | 6.1.2.6.6.5 | **Spectrometer soleniod power interface** |  | 25d | 2010-11-15 A | 2010-12-17 |  | 21% | 19.75d |  |  |  | 1029d |  |  |  | 200h | 42h | 3,000 |  | 1,050 |
| 357 | 6.1.2.6.6.5.1 | **Power electronics control sequence interface** |  | 25d | 2010-11-15 A | 2010-12-17 |  | 21% | 19.75d |  |  |  | 1029d |  |  |  | 200h | 42h | 3,000 |  | 1,050 |
| 358 | 6.1.2.6.6.5.1.1 | Review power electronic interlock signals |  | 5d | 2010-11-15 A | 2010-11-19 |  | 35% | 3.25d |  |  |  | 1066.5d | 0d | start no earlier than 2010-11-15 | Electrical Engineer | 40h | 14h | 3,000 |  | 1,050 |
| 359 | 6.1.2.6.6.5.1.2 | Design controller interface |  | 10d | 2010-11-22 A | 2010-12-03 | 358 | 35% | 6.5d |  |  |  | 1063d | 0d |  | Electrical Designer | 80h | 28h |  |  |  |
| 360 | 6.1.2.6.6.5.1.3 | Assemble controller interface |  | 5d | 2010-12-06 | 2010-12-10 | 359 |  |  |  |  |  | 1063d | 0d |  | Electrical Technician | 40h |  |  |  |  |
| 361 | 6.1.2.6.6.5.1.4 | Test controller interface |  | 5d | 2010-12-13 | 2010-12-17 | 360 |  |  |  |  |  | 1063d |  |  | Electrical Engineer | 40h |  |  |  |  |
| 362 | 6.1.2.6.6.6 | Spectrometer soleniod delivered | milestone | 0d | 2012-03-26 | 2012-03-26 | 107 |  |  | 2009-11-09 | 2009-11-09 | 0d | 745d | 0d | start no earlier than 2010-06-14 |  |  |  |  |  |  |
| 363 | 6.1.2.6.6.7 | Mechanical installation of soleniod |  | 24d | 2012-03-27 | 2012-04-27 | 362 |  |  |  |  |  | 745d | 0d |  |  |  |  |  |  |  |
| 364 | 6.1.2.6.6.8 | **Spectrometer Soleniod Power Supply racks** |  | 24d | 2012-03-27 | 2012-04-27 |  |  |  |  |  |  | 755d |  |  |  | 180h |  | 2,000 |  |  |
| 365 | 6.1.2.6.6.8.1 | Delivery Spectrometer soleniod racks to DL |  | 2d | 2012-03-27 | 2012-03-28 | 362 |  |  |  |  |  | 755d | 0d |  |  |  |  | 2,000 |  |  |
| 366 | 6.1.2.6.6.8.2 | Finalise electrical design |  | 5d | 2012-03-29 | 2012-04-04 | 365 |  |  | 2009-11-09 | 2009-11-13 | 5d | 755d | 0d |  | Electrical Designer; Electrical Engineer [50%] | 60h |  |  | 2,820 |  |
| 367 | 6.1.2.6.6.8.3 | Modify Spectrometer soleniod Power Supply racks |  | 10d | 2012-04-05 | 2012-04-18 | 366 |  |  |  |  |  | 755d | 0d |  | Electrical Technician | 80h |  |  |  |  |
| 368 | 6.1.2.6.6.8.4 | Test Spectrometer soleniod power supply racks |  | 5d | 2012-04-19 | 2012-04-25 | 367 |  |  |  |  |  | 755d | 0d |  | Electrical Engineer | 40h |  |  |  |  |
| 369 | 6.1.2.6.6.8.5 | Deliver Spectrometer soleniod Power Supply rack to RAL |  | 2d | 2012-04-26 | 2012-04-27 | 368 |  |  |  |  |  | 755d | 0d |  |  |  |  |  |  |  |

| ID | WBS | Task | Type | Duration | Start | Finish | Predecessors | Complete | Remaining | Baseline start | Baseline finish | Baseline duration | Total slack | Free slack | Constraint | Resources | Work | Actual work | Cost | Baseline cost | Actual cost |
| --- | --- | --- | --- | --- | --- | --- | --- | --- | --- | --- | --- | --- | --- | --- | --- | --- | --- | --- | --- | --- | --- |
| 370 | 6.1.2.6.6.9 | **MICE Hall Preparation** |  | 292.62d | 2010-12-29 A | 2012-05-01 |  | 29% | 207.55d |  |  |  | 763d |  |  |  | 112h | 32.56h | 1,000 |  | 280 |
| 371 | 6.1.2.6.6.9.1 | Install cable management and DC magnet cables |  | 10d | 2010-12-29 A | 2012-04-18 | 362FS+9.25d | 28% | 7.22d | 2009-11-30 | 2009-12-09 | 8d | 771.82d | 0d |  | Electrical Technician | 80h | 22.2h | 1,000 | 3,008 | 280 |
| 372 | 6.1.2.6.6.9.2 | Install AC distribution |  | 2d | 2011-01-11 A | 2012-04-19 | 371 | 65% | 0.7d |  |  |  | 771.82d |  |  | Electrical Technician | 16h | 10.36h |  |  |  |
| 373 | 6.1.2.6.6.9.3 | Install Spectrometer soleniod Power supply rack |  | 2d | 2012-04-30 | 2012-05-01 | 369 |  |  |  |  |  | 763d |  |  | Electrical Technician | 16h |  |  |  |  |
| 374 | 6.1.2.6.7 | **Cooling Channel Controls System** |  | 618d | 2009-10-26 A | 2012-05-25 |  | 47% | 328.42d | 2009-06-24 | 2009-12-28 | 134d | 745d |  |  |  | 1040.4h | 529.5h | 26,500 | 59,216 | 25,000 |
| 375 | 6.1.2.6.7.1 | Agree control system format | milestone | 0d | 2009-10-26 A | 2009-10-26 A |  | 100% |  | 2009-06-24 | 2009-06-24 | 0d |  |  | start no earlier than 2009-10-26 |  |  |  | 25,000 | 25,000 | 25,000 |
| 376 | 6.1.2.6.7.2 | Agree control system funding | milestone | 0d | 2009-10-26 A | 2009-10-26 A | 375 | 100% |  | 2009-08-03 | 2009-08-03 | 0d |  |  | start no earlier than 2009-08-03 |  |  |  |  |  |  |
| 377 | 6.1.2.6.7.3 | Identify equipment interface requirements |  | 22d | 2009-10-26 A | 2009-11-24 A | 376 | 100% |  | 2009-08-03 | 2009-09-01 | 22d |  |  |  | Electrical Designer | 176h | 176h |  | 8,272 |  |
| 378 | 6.1.2.6.7.4 | Design preliminary control system layout |  | 10d | 2009-11-25 A | 2009-12-08 A | 377 | 100% |  | 2009-09-02 | 2009-09-15 | 10d |  |  |  | Electrical Designer | 80h | 80h |  | 3,760 |  |
| 379 | 6.1.2.6.7.5 | Design control system wiring diagrams |  | 15d | 2009-12-09 A | 2009-12-29 A |  | 100% |  | 2009-09-16 | 2009-10-06 | 15d |  |  |  | Electrical Designer | 120h | 120h |  | 5,640 |  |
| 380 | 6.1.2.6.7.6 | Visit LBNL for discussions |  | 4.62d | 2010-02-22 A | 2010-02-26 A | 379 | 100% |  |  |  |  |  |  | start no earlier than 2010-02-22 | Electrical Designer | 37h | 37h |  |  |  |
| 381 | 6.1.2.6.7.7 | Controls review after LBNL visit |  | 4.62d | 2010-02-26 A | 2010-03-05 A | 380 | 100% |  |  |  |  |  |  |  | Electrical Designer | 37h | 37h |  |  |  |
| 382 | 6.1.2.6.7.8 | Approval of Finances and work package | milestone | 0d | 2010-06-07 A | 2010-06-07 A | 381 | 100% |  |  |  |  |  |  | start no earlier than 2010-06-07 |  |  |  |  |  |  |
| 383 | 6.1.2.6.7.9 | Update control system design |  | 10d | 2010-06-07 A | 2010-06-18 | 382 | 30% | 7d |  |  |  | 1124.94d | 0d |  | Electrical Designer | 80h | 24h |  |  |  |
| 384 | 6.1.2.6.7.10 | Controls design review and modifications |  | 14d | 2010-06-21 | 2010-07-08 | 383 |  |  |  |  |  | 1124.94d | 0d |  | Electrical Designer [20%] | 22.4h |  |  |  |  |
| 385 | 6.1.2.6.7.11 | Controls design approval | milestone | 0d | 2010-07-08 | 2010-07-08 | 384 |  |  |  |  |  | 1124.94d | 0d |  |  |  |  |  |  |  |
| 386 | 6.1.2.6.7.12 | Assemble controls rack |  | 28d | 2010-07-08 A | 2010-08-17 | 385 | 25% | 21.06d | 2009-10-07 | 2009-11-17 | 30d | 1118.88d | 0d |  | Electrical Technician | 224h | 55.5h |  | 11,280 |  |
| 387 | 6.1.2.6.7.13 | Test controls rack |  | 10d | 2010-08-17 | 2010-08-31 | 386 |  |  | 2009-11-18 | 2009-11-24 | 5d | 1118.88d | 0d |  | Electrical Designer | 80h |  |  | 1,880 |  |
| 388 | 6.1.2.6.7.14 | Soleniod Mechanical installation complete | milestone | 0d | 2012-04-27 | 2012-04-27 | 363 |  |  | 2009-12-18 | 2009-12-18 | 0d | 745d | 0d | start no earlier than 2009-12-18 |  |  |  |  |  |  |
| 389 | 6.1.2.6.7.15 | Install controls rack |  | 3d | 2010-08-31 | 2010-09-03 | 387 |  |  | 2009-11-25 | 2009-11-26 | 2d | 1118.88d | 373.88d |  | Electrical Technician | 24h |  |  | 752 |  |
| 390 | 6.1.2.6.7.16 | Install cables and terminate |  | 10d | 2012-04-30 | 2012-05-11 | 388, 389 |  |  | 2009-12-18 | 2009-12-23 | 4d | 745d | 0d |  | Electrical Technician | 80h |  | 1,500 | 1,504 |  |
| 391 | 6.1.2.6.7.17 | Commission system with installed plant |  | 10d | 2012-05-14 | 2012-05-25 | 350, 369, 390 |  |  | 2009-12-24 | 2009-12-28 | 3d | 745d | 0d |  | Electrical Designer | 80h |  |  | 1,128 |  |
| 392 | 6.1.2.6.7.18 | Cooling channel controls complete | milestone | 0d | 2012-05-25 | 2012-05-25 | 371, 391 |  |  |  |  |  | 745d | 0d |  |  |  |  |  |  |  |
| 393 | 6.1.2.6.7.19 | Cooling Channel electrical complete Step II | milestone | 0d | 2012-05-25 | 2012-05-25 | 330, 340, 392 |  |  |  |  |  | 745d |  |  |  |  |  |  |  |  |

| ID | WBS | Task | Type | Duration | Start | Finish | Predecessors | Complete | Remaining | Baseline start | Baseline finish | Baseline duration | Total slack | Free slack | Constraint | Resources | Work | Actual work | Cost | Baseline cost | Actual cost |
| --- | --- | --- | --- | --- | --- | --- | --- | --- | --- | --- | --- | --- | --- | --- | --- | --- | --- | --- | --- | --- | --- |
| 394 | 6.1.2.7 | **Tracker / Spectrometer Soleniod # 2** |  | 630.23d | 2010-05-19 A | 2013-01-04 |  | 4% | 603.29d | 2009-04-20 | 2010-08-09 | 341d | 585d |  |  |  | 672h | 40h | 8,500 | 45,044 | 2,000 |
| 395 | 6.1.2.7.1 | **Tracker** |  | 630.23d | 2010-05-19 A | 2013-01-04 |  | 18% | 517.68d | 2009-10-26 | 2010-01-15 | 60d | 585d |  |  |  | 152h | 40h | 2,500 | 8,204 | 2,000 |
| 396 | 6.1.2.7.1.1 | Prepare Hall and cable ducts for installation |  | 3d | 2012-12-19 | 2012-12-21 |  |  |  | 2009-04-20 | 2009-04-24 | 5d | 585d | 0d | start no earlier than 2012-12-19 | Electrical Technician | 24h |  |  | 1,880 |  |
| 397 | 6.1.2.7.1.2 | Re-house equipment in new rack |  | 5d | 2010-05-19 A | 2010-05-26 A |  | 100% |  | 2009-10-26 | 2009-10-30 | 5d |  |  | start no earlier than 2009-10-26 | Electrical Technician | 40h | 40h | 2,000 | 3,880 | 2,000 |
| 398 | 6.1.2.7.1.3 | Tracker system available for installation | milestone | 0d | 2012-07-24 | 2012-07-24 | 860 |  |  |  |  |  | 703d |  | finish no earlier than 2010-06-21 |  |  |  |  |  |  |
| 399 | 6.1.2.7.1.4 | Agree/ design Control interface |  | 2d | 2012-12-24 | 2012-12-25 | 396 |  |  | 2009-11-02 | 2009-11-04 | 3d | 585d | 0d |  | Electrical Designer; Electrical Engineer [50%] | 24h |  |  | 1,692 |  |
| 400 | 6.1.2.7.1.5 | Install Tracker rack in MICE Hall |  | 2d | 2012-12-26 | 2012-12-27 | 399 |  |  | 2009-11-05 | 2009-11-06 | 2d | 585d | 0d |  | Electrical Technician | 16h |  |  | 752 |  |
| 401 | 6.1.2.7.1.6 | Tracker Installation |  | 10d | 2012-08-15 | 2012-08-28 | 871 |  |  | 2010-01-11 | 2010-01-11 | 0d | 672d | 87d | start no earlier than 2010-01-11 |  |  |  |  |  |  |
| 402 | 6.1.2.7.1.7 | Install cables and terminate |  | 6d | 2012-12-28 | 2013-01-04 | 400, 401 |  |  | 2010-01-11 | 2010-01-15 | 5d | 585d | 0d |  | Electrical Technician | 48h |  | 500 | 1,880 |  |
| 403 | 6.1.2.7.2 | **Spectrometer Soleniod #2** |  | 272d | 2011-05-16 | 2012-08-16 |  |  |  | 2010-02-22 | 2010-07-27 | 112d | 686d |  |  |  | 380h |  | 5,000 | 22,996 |  |
| 404 | 6.1.2.7.2.1 | Fast discharge circuit review |  | 2d | 2011-05-16 | 2011-05-17 |  |  |  |  |  |  | 938d | 0d | start no earlier than 2011-05-16 |  |  |  |  |  |  |
| 405 | 6.1.2.7.2.2 | **Power electronics control sequence interface** |  | 18d | 2011-05-18 | 2011-06-10 |  |  |  |  |  |  | 904d |  |  |  | 144h |  | 2,000 |  |  |
| 406 | 6.1.2.7.2.2.1 | Review power electronic interlock signals |  | 3d | 2011-05-18 | 2011-05-20 | 404 |  |  |  |  |  | 938d | 0d |  | Electrical Engineer | 24h |  |  |  |  |
| 407 | 6.1.2.7.2.2.2 | Design controller interface |  | 5d | 2011-05-23 | 2011-05-27 | 406 |  |  |  |  |  | 938d | 0d |  | Electrical Designer | 40h |  | 2,000 |  |  |
| 408 | 6.1.2.7.2.2.3 | Assemble controller interface |  | 5d | 2011-05-30 | 2011-06-03 | 407 |  |  |  |  |  | 938d | 0d |  | Electrical Technician | 40h |  |  |  |  |
| 409 | 6.1.2.7.2.2.4 | Test controller interface |  | 5d | 2011-06-06 | 2011-06-10 | 408 |  |  |  |  |  | 938d |  |  | Electrical Engineer | 40h |  |  |  |  |
| 410 | 6.1.2.7.2.3 | Spectrometer soleniod delivered | milestone | 0d | 2012-07-03 | 2012-07-03 | 111 |  |  | 2009-11-09 | 2009-11-09 | 0d | 678d | 0d |  |  |  |  |  |  |  |
| 411 | 6.1.2.7.2.4 | Mechanical installation of soleniod |  | 25d | 2012-07-04 | 2012-08-07 | 410 |  |  |  |  |  | 678d | 0d | start no earlier than 2012-06-08 |  |  |  |  |  |  |
| 412 | 6.1.2.7.2.5 | **Spectrometer Soleniod Power Supply racks** |  | 22d | 2012-07-04 | 2012-08-02 |  |  |  |  |  |  | 696d |  |  |  | 180h |  | 2,000 |  |  |
| 413 | 6.1.2.7.2.5.1 | Review design of existing spectrometer racks |  | 2d | 2012-07-04 | 2012-07-05 | 410 |  |  |  |  |  | 696d | 0d |  |  |  |  |  |  |  |
| 414 | 6.1.2.7.2.5.2 | Finalise electrical design |  | 5d | 2012-07-06 | 2012-07-12 | 413 |  |  | 2009-11-09 | 2009-11-13 | 5d | 696d | 0d |  | Electrical Designer; Electrical Engineer [50%] | 60h |  |  | 2,820 |  |
| 415 | 6.1.2.7.2.5.3 | Modify Spectrometer soleniod Power Supply racks |  | 10d | 2012-07-13 | 2012-07-26 | 414 |  |  |  |  |  | 696d | 0d |  | Electrical Technician | 80h |  | 2,000 |  |  |
| 416 | 6.1.2.7.2.5.4 | Commission Spectrometer soleniod power supply racks |  | 5d | 2012-07-27 | 2012-08-02 | 415 |  |  |  |  |  | 696d |  |  | Electrical Engineer | 40h |  |  |  |  |
| 417 | 6.1.2.7.2.6 | **MICE Hall Preparation** |  | 7d | 2012-08-08 | 2012-08-16 |  |  |  |  |  |  | 686d |  |  |  | 56h |  | 1,000 |  |  |
| 418 | 6.1.2.7.2.6.1 | Install cable management and DC magnet cables |  | 5d | 2012-08-08 | 2012-08-14 | 411 |  |  | 2009-11-30 | 2009-12-09 | 8d | 686d | 0d |  | Electrical Technician | 40h |  | 1,000 | 3,008 |  |
| 419 | 6.1.2.7.2.6.2 | Install AC distribution |  | 2d | 2012-08-15 | 2012-08-16 | 418 |  |  |  |  |  | 686d |  |  | Electrical Technician | 16h |  |  |  |  |

| ID | WBS | Task | Type | Duration | Start | Finish | Predecessors | Baseline start | Baseline finish | Baseline duration | Total slack | Free slack | Constraint | Resources | Work | Cost | Baseline cost |
| --- | --- | --- | --- | --- | --- | --- | --- | --- | --- | --- | --- | --- | --- | --- | --- | --- | --- |
| 420 | 6.1.2.7.3 | **Cooling Channel Controls System** |  | 108d | 2012-08-07 | 2013-01-04 |  | 2010-07-28 | 2010-08-09 | 9d | 585d |  |  |  | 140h | 1,000 | 4,948 |
| 421 | 6.1.2.7.3.1 | Soleniod#2 mechanical installation complete | milestone | 0d | 2012-08-07 | 2012-08-07 | 411 |  |  |  | 678d | 0d |  |  |  |  |  |
| 422 | 6.1.2.7.3.2 | Install cables and terminate |  | 10d | 2012-08-08 | 2012-08-21 | 421 | 2010-07-28 | 2010-08-04 | 6d | 678d | 0d |  | Electrical Technician | 80h | 1,000 | 3,256 |
| 423 | 6.1.2.7.3.3 | Commission system with installed plant |  | 5d | 2012-08-22 | 2012-08-28 | 422 | 2010-08-05 | 2010-08-09 | 3d | 678d | 93d |  | Electrical Designer; Electrical Engineer [50%] | 60h |  | 1,692 |
| 424 | 6.1.2.7.3.4 | Cooling Channel electrical complete Step III | milestone | 0d | 2013-01-04 | 2013-01-04 | 402, 423 |  |  |  | 585d |  |  |  |  |  |  |
| 425 | 6.1.2.8 | **AFC - Focus Coils # 1** |  | 46d | 2011-09-06 | 2011-11-08 |  | 2011-03-14 | 2011-04-04 | 16d | 860d |  |  |  | 288h | 2,500 | 8,268 |
| 426 | 6.1.2.8.1 | Understanding system requirements |  | 5d | 2011-09-06 | 2011-09-12 | 113 |  |  |  | 860d | 0d |  |  |  |  |  |
| 427 | 6.1.2.8.2 | Design control interface |  | 10d | 2011-09-13 | 2011-09-26 | 426 |  |  |  | 860d | 0d |  |  |  |  |  |
| 428 | 6.1.2.8.3 | Update cable schedules / drawings |  | 10d | 2011-09-27 | 2011-10-10 | 427 | 2011-03-14 | 2011-03-16 | 3d | 860d | 0d |  | Electrical Designer | 80h |  | 1,128 |
| 429 | 6.1.2.8.4 | Install power supplies into rack |  | 2d | 2011-10-11 | 2011-10-12 | 428 | 2011-03-17 | 2011-03-18 | 2d | 860d | 0d |  | Electrical Technician | 16h | 1,500 | 2,252 |
| 430 | 6.1.2.8.5 | Install additional cable management |  | 2d | 2011-10-13 | 2011-10-14 | 429 | 2011-03-21 | 2011-03-22 | 2d | 860d | 0d |  | Electrical Technician | 16h |  | 752 |
| 431 | 6.1.2.8.6 | Install DC magnet cables |  | 4d | 2011-10-17 | 2011-10-20 | 430 | 2011-03-23 | 2011-03-25 | 3d | 860d | 0d |  | Electrical Technician | 32h |  | 1,128 |
| 432 | 6.1.2.8.7 | Install controls interface / cables |  | 8d | 2011-10-21 | 2011-11-01 | 431 | 2011-03-28 | 2011-03-31 | 4d | 860d | 0d |  | Electrical Technician | 64h | 1,000 | 1,504 |
| 433 | 6.1.2.8.8 | Commission controls |  | 5d | 2011-11-02 | 2011-11-08 | 432 | 2011-04-01 | 2011-04-04 | 2d | 860d |  |  | Electrical Engineer; Electrical Technician | 80h |  | 1,504 |
| 434 | 6.1.2.9 | **AFC - Focus Coils # 2** |  | 27d | 2012-09-26 | 2012-11-01 |  | 2012-03-05 | 2012-03-26 | 16d | 631d |  |  |  | 232h | 2,500 | 8,268 |
| 435 | 6.1.2.9.1 | Update cable schedules / drawings |  | 4d | 2012-09-26 | 2012-10-01 |  | 2012-03-05 | 2012-03-07 | 3d | 631d | 0d | start no earlier than 2012-09-26 | Electrical Designer | 32h |  | 1,128 |
| 436 | 6.1.2.9.2 | Design control interface |  | 3d | 2012-10-02 | 2012-10-04 | 435 |  |  |  | 631d | 0d |  |  |  |  |  |
| 437 | 6.1.2.9.3 | Install power supplies into rack |  | 2d | 2012-10-05 | 2012-10-08 | 436 | 2012-03-08 | 2012-03-09 | 2d | 631d | 0d |  | Electrical Technician | 16h | 1,500 | 2,252 |
| 438 | 6.1.2.9.4 | Install additional cable management |  | 2d | 2012-10-09 | 2012-10-10 | 437 | 2012-03-12 | 2012-03-13 | 2d | 631d | 0d |  | Electrical Technician | 16h |  | 752 |
| 439 | 6.1.2.9.5 | Install DC magnet cables |  | 4d | 2012-10-11 | 2012-10-16 | 438 | 2012-03-14 | 2012-03-16 | 3d | 631d | 0d |  | Electrical Technician | 32h |  | 1,128 |
| 440 | 6.1.2.9.6 | Install controls interface / cables |  | 7d | 2012-10-17 | 2012-10-25 | 439 | 2012-03-19 | 2012-03-22 | 4d | 631d | 0d |  | Electrical Technician | 56h | 1,000 | 1,504 |
| 441 | 6.1.2.9.7 | Commission controls |  | 5d | 2012-10-26 | 2012-11-01 | 440 | 2012-03-23 | 2012-03-26 | 2d | 631d |  |  | Electrical Engineer; Electrical Technician | 80h |  | 1,504 |
| 442 | 6.1.2.10 | **AFC - Focus Coils # 3** |  | 27d | 2013-02-28 | 2013-04-05 |  | 2012-10-08 | 2012-10-29 | 16d | 520d |  |  |  | 232h | 2,500 | 8,268 |
| 443 | 6.1.2.10.1 | Update cable schedules / drawings |  | 4d | 2013-02-28 | 2013-03-05 |  | 2012-10-08 | 2012-10-10 | 3d | 520d | 0d | start no earlier than 2013-02-28 | Electrical Designer | 32h |  | 1,128 |
| 444 | 6.1.2.10.2 | Design controls interface |  | 3d | 2013-03-06 | 2013-03-08 | 443 |  |  |  | 520d | 0d |  |  |  |  |  |
| 445 | 6.1.2.10.3 | Install power supplies into rack |  | 2d | 2013-03-11 | 2013-03-12 | 444 | 2012-10-11 | 2012-10-12 | 2d | 520d | 0d |  | Electrical Technician | 16h | 1,500 | 2,252 |
| 446 | 6.1.2.10.4 | Install additional cable management |  | 2d | 2013-03-13 | 2013-03-14 | 445 | 2012-10-15 | 2012-10-16 | 2d | 520d | 0d |  | Electrical Technician | 16h |  | 752 |
| 447 | 6.1.2.10.5 | Install DC magnet cables |  | 4d | 2013-03-15 | 2013-03-20 | 446 | 2012-10-17 | 2012-10-19 | 3d | 520d | 0d |  | Electrical Technician | 32h |  | 1,128 |
| 448 | 6.1.2.10.6 | Install controls interface / cables |  | 7d | 2013-03-21 | 2013-03-29 | 447 | 2012-10-22 | 2012-10-25 | 4d | 520d | 0d |  | Electrical Technician | 56h | 1,000 | 1,504 |
| 449 | 6.1.2.10.7 | Commission controls |  | 5d | 2013-04-01 | 2013-04-05 | 448 | 2012-10-26 | 2012-10-29 | 2d | 520d |  |  | Electrical Engineer; Electrical Technician | 80h |  | 1,504 |

| ID | WBS | Task | Type | Duration | Start | Finish | Predecessors | Complete | Remaining | Baseline start | Baseline finish | Baseline duration | Total slack | Free slack | Constraint | Resources | Work | Actual work | Cost | Baseline cost | Actual cost |
| --- | --- | --- | --- | --- | --- | --- | --- | --- | --- | --- | --- | --- | --- | --- | --- | --- | --- | --- | --- | --- | --- |
| 450 | 6.1.2.11 | **KL (MUCAL)** |  | 1321.5d | 2009-11-17 A | 2015-02-27 |  | 16% | 1107.14d | 2010-01-05 | 2012-11-20 | 751d? | 25.5d |  |  |  | 896.4h | 148h | 8,000 | 21,920 | 1,000 |
| 451 | 6.1.2.11.1 | **KL Step II** |  | 719.85d | 2009-11-17 A | 2012-11-07 |  | 73% | 195.59d | 2010-01-05 | 2010-01-15 | 9d | 591.15d |  |  |  | 142.8h | 104h | 1,000 | 4,384 | 1,000 |
| 452 | 6.1.2.11.1.1 | Evaluate cable / system requirements |  | 3d | 2009-11-17 A | 2009-11-19 A |  | 100% |  | 2010-01-05 | 2010-01-07 | 3d |  |  | start no earlier than 2009-10-05 | Electrical Designer | 24h | 24h | 1,000 | 2,128 | 1,000 |
| 453 | 6.1.2.11.1.2 | Install additional cable management |  | 3d | 2009-11-19 A | 2009-11-24 A | 452 | 100% |  | 2010-01-08 | 2010-01-11 | 2d |  |  |  | Electrical Technician | 24h | 24h |  | 752 |  |
| 454 | 6.1.2.11.1.3 | Install cables temporary position |  | 5d | 2009-11-24 A | 2009-12-01 A | 453 | 100% |  | 2010-01-12 | 2010-01-14 | 3d |  |  |  | Electrical Technician | 40h | 40h |  | 1,128 |  |
| 455 | 6.1.2.11.1.4 | Terminate cables |  | 2d | 2009-12-01 A | 2009-12-03 A | 454 | 100% |  | 2010-01-15 | 2010-01-15 | 1d |  |  |  | Electrical Technician | 16h | 16h |  | 376 |  |
| 456 | 6.1.2.11.1.5 | KL electrical temporary position complete | milestone | 0d | 2009-12-03 A | 2009-12-03 A | 455 | 100% |  | 2010-01-15 | 2010-01-15 | 0d |  |  |  |  |  |  |  |  |  |
| 457 | 6.1.2.11.1.6 | KL ready for repositioning | milestone | 0d | 2012-11-01 | 2012-11-01 | 300 |  |  |  |  |  | 624d | 0d |  |  |  |  |  |  |  |
| 458 | 6.1.2.11.1.7 | Disconnect cabling |  | 2d | 2012-11-01 | 2012-11-02 | 457 |  |  |  |  |  | 624d | 0d |  | Electrical Technician | 16h |  |  |  |  |
| 459 | 6.1.2.11.1.8 | Install additional cable tray |  | 1d | 2012-11-05 | 2012-11-05 | 458 |  |  |  |  |  | 624d | 0d |  | Electrical Technician | 8h |  |  |  |  |
| 460 | 6.1.2.11.1.9 | KL Reposition | milestone | 0d | 2012-11-05 | 2012-11-05 | 459 |  |  |  |  |  | 624d | 0d |  |  |  |  |  |  |  |
| 461 | 6.1.2.11.1.10 | Re-cable KL In new position |  | 1.85d | 2012-11-06 | 2012-11-07 | 460 |  |  |  |  |  | 625.15d | 0d |  | Electrical Technician | 14.8h |  |  |  |  |
| 462 | 6.1.2.11.1.11 | KL electrical Step II complete | milestone | 0d | 2012-11-07 | 2012-11-07 | 461 |  |  |  |  |  | 625.15d | 1.15d |  |  |  |  |  |  |  |
| 463 | 6.1.2.11.2 | **KL Step IV** |  | 10.18d | 2012-10-01 | 2012-10-15 |  |  |  | 2011-04-14 | 2011-04-26 | 9d | 634.65d |  |  |  | 81.4h |  | 1,000 | 4,384 |  |
| 464 | 6.1.2.11.2.1 | Evaluate cable / system requirements |  | 2.77d | 2012-10-01 | 2012-10-03 | 886SS |  |  | 2011-04-14 | 2011-04-18 | 3d | 634.65d | 0d | start no earlier than 2009-11-25 | Electrical Designer | 22.2h |  | 1,000 | 2,128 |  |
| 465 | 6.1.2.11.2.2 | Install additional cable management |  | 1.85d | 2012-10-03 | 2012-10-05 | 464 |  |  | 2011-04-19 | 2011-04-20 | 2d | 634.65d | 0d |  | Electrical Technician | 14.8h |  |  | 752 |  |
| 466 | 6.1.2.11.2.3 | Install cables |  | 3.7d | 2012-10-05 | 2012-10-11 | 465 |  |  | 2011-04-21 | 2011-04-25 | 3d | 634.65d | 0d |  | Electrical Technician | 29.6h |  |  | 1,128 |  |
| 467 | 6.1.2.11.2.4 | Terminate cables |  | 1.85d | 2012-10-11 | 2012-10-15 | 466 |  |  | 2011-04-26 | 2011-04-26 | 1d | 634.65d | 0d |  | Electrical Technician | 14.8h |  |  | 376 |  |
| 468 | 6.1.2.11.2.5 | KL Step IV electrical complete | milestone | 0d | 2012-10-15 | 2012-10-15 | 467 |  |  | 2011-04-26 | 2011-04-26 | 0d | 634.65d | 0d |  |  |  |  |  |  |  |
| 469 | 6.1.2.11.3 | **KL Step V** |  | 10.18d | 2013-12-02 | 2013-12-16 |  |  |  | 2012-04-05 | 2012-04-17 | 9d | 329.65d |  |  |  | 81.4h |  | 1,000 | 4,384 |  |
| 470 | 6.1.2.11.3.1 | Evaluate cable / system requirements |  | 2.77d | 2013-12-02 | 2013-12-04 | 944SS |  |  | 2012-04-05 | 2012-04-09 | 3d | 329.65d | 0d | start no earlier than 2010-02-01 | Electrical Designer | 22.2h |  | 1,000 | 2,128 |  |
| 471 | 6.1.2.11.3.2 | Install additional cable management |  | 1.85d | 2013-12-04 | 2013-12-06 | 470 |  |  | 2012-04-10 | 2012-04-11 | 2d | 329.65d | 0d |  | Electrical Technician | 14.8h |  |  | 752 |  |
| 472 | 6.1.2.11.3.3 | Install cables |  | 3.7d | 2013-12-06 | 2013-12-12 | 471 |  |  | 2012-04-12 | 2012-04-16 | 3d | 329.65d | 0d |  | Electrical Technician | 29.6h |  |  | 1,128 |  |
| 473 | 6.1.2.11.3.4 | Terminate cables |  | 1.85d | 2013-12-12 | 2013-12-16 | 472 |  |  | 2012-04-17 | 2012-04-17 | 1d | 329.65d | 0d |  | Electrical Technician | 14.8h |  |  | 376 |  |
| 474 | 6.1.2.11.3.5 | KL Step V electrical complete | milestone | 0d | 2013-12-16 | 2013-12-16 | 473 |  |  | 2012-04-17 | 2012-04-17 | 0d | 329.65d | 0d |  |  |  |  |  |  |  |

| ID | WBS | Task | Type | Duration | Start | Finish | Predecessors | Complete | Remaining | Baseline start | Baseline finish | Baseline duration | Total slack | Free slack | Constraint | Resources | Work | Actual work | Cost | Baseline cost |
| --- | --- | --- | --- | --- | --- | --- | --- | --- | --- | --- | --- | --- | --- | --- | --- | --- | --- | --- | --- | --- |
| 475 | 6.1.2.11.4 | **KL Step VI** |  | 9.32d | 2015-02-02 | 2015-02-13 |  |  |  | 2012-11-08 | 2012-11-20 | 9d? | 25.5d |  |  |  | 74.6h |  | 1,000 | 4,384 |
| 476 | 6.1.2.11.4.1 | Evaluate cable / system requirements |  | 2.77d | 2015-02-02 | 2015-02-04 | 1004SS |  |  | 2012-11-08 | 2012-11-12 | 3d | 25.5d | 0d | start no earlier than 2010-02-01 | Electrical Designer | 22.2h |  | 1,000 | 2,128 |
| 477 | 6.1.2.11.4.2 | Install additional cable management |  | 1.85d | 2015-02-04 | 2015-02-06 | 476 |  |  | 2012-11-13 | 2012-11-14 | 2d | 25.5d | 0d |  | Electrical Technician | 14.8h |  |  | 752 |
| 478 | 6.1.2.11.4.3 | Install cables |  | 3.7d | 2015-02-06 | 2015-02-12 | 477 |  |  | 2012-11-15 | 2012-11-19 | 3d | 25.5d | 0d |  | Electrical Technician | 29.6h |  |  | 1,128 |
| 479 | 6.1.2.11.4.4 | Terminate cables |  | 1d | 2015-02-12 | 2015-02-13 | 478 |  |  | 2012-11-20 | 2012-11-20 | 1d | 25.5d | 0d |  | Electrical Technician | 8h |  |  | 376 |
| 480 | 6.1.2.11.4.5 | KL Step VI electrical complete | milestone | 0d | 2015-02-13 | 2015-02-13 | 479 |  |  | 2012-11-20 | 2012-11-20 | 0d | 25.5d | 0d |  |  |  |  |  |  |
| 481 | 6.1.2.11.5 | **EMR Step II** |  | 334d | 2011-05-16 A | 2012-11-12 |  | 15% | 282.97d | 2010-01-05 | 2010-01-15 | 9d | 590d |  |  |  | 272h | 44h | 1,000 | 4,384 |
| 482 | 6.1.2.11.5.1 | Design additional HV rack - mezzanine |  | 3d | 2011-05-16 | 2011-05-18 |  |  |  |  |  |  | 937d | 0d | start no earlier than 2011-05-16 | Electrical Designer | 24h |  |  |  |
| 483 | 6.1.2.11.5.2 | Assemble additional HV rack |  | 5d | 2011-05-19 | 2011-05-25 | 482 |  |  |  |  |  | 937d | 0d |  | Electrical Technician | 40h |  |  |  |
| 484 | 6.1.2.11.5.3 | Transport to RAL |  | 2d | 2011-05-26 | 2011-05-27 | 483 |  |  |  |  |  | 937d | 0d |  |  |  |  |  |  |
| 485 | 6.1.2.11.5.4 | Evaluate cable / system requirements |  | 3d | 2011-05-30 | 2011-06-01 | 484 |  |  | 2010-01-05 | 2010-01-07 | 3d | 937d | 0d | start no earlier than 2010-07-05 | Electrical Designer | 24h |  | 1,000 | 2,128 |
| 486 | 6.1.2.11.5.5 | Install additional HV rack |  | 2d | 2011-06-02 | 2011-06-03 | 485 |  |  |  |  |  | 937d | 0d |  | Electrical Technician | 16h |  |  |  |
| 487 | 6.1.2.11.5.6 | Install additional cable management |  | 3d | 2011-06-06 | 2011-06-08 | 486 |  |  |  |  |  | 937d | 0d |  | Electrical Technician | 24h |  |  |  |
| 488 | 6.1.2.11.5.7 | Reroute HV cables to new HV rack |  | 3d | 2011-06-09 | 2011-06-13 | 487 |  |  |  |  |  | 937d | 0d |  | Electrical Technician | 24h |  |  |  |
| 489 | 6.1.2.11.5.8 | EMR Delivered to RAL | milestone | 0d | 2011-06-13 | 2011-06-13 | 488 |  |  |  |  |  | 937d |  | start no earlier than 2011-02-14 |  |  |  |  |  |
| 490 | 6.1.2.11.5.9 | Install additional cable management |  | 3d | 2011-06-14 A | 2011-06-16 A | 489 | 100% |  | 2010-01-08 | 2010-01-11 | 2d |  |  |  | Electrical Technician | 24h | 24h |  | 752 |
| 491 | 6.1.2.11.5.10 | Install cables temporary position |  | 5d | 2011-06-17 A | 2011-06-23 | 490 | 50% | 2.5d | 2010-01-12 | 2010-01-14 | 3d | 927d | 0d |  | Electrical Technician | 40h | 20h |  | 1,128 |
| 492 | 6.1.2.11.5.11 | Terminate cables |  | 2d | 2011-06-24 | 2011-06-27 | 491 |  |  | 2010-01-15 | 2010-01-15 | 1d | 927d | 0d |  | Electrical Technician | 16h |  |  | 376 |
| 493 | 6.1.2.11.5.12 | EMR electrical temporary position complete | milestone | 0d | 2011-06-27 | 2011-06-27 | 492 |  |  | 2010-01-15 | 2010-01-15 | 0d | 927d |  |  |  |  |  |  |  |
| 494 | 6.1.2.11.5.13 | EMR ready for repositioning | milestone | 0d | 2012-11-01 | 2012-11-01 | 300 |  |  |  |  |  | 627d | 3d | finish no earlier than 2010-08-02 |  |  |  |  |  |
| 495 | 6.1.2.11.5.14 | Disconnect cabling |  | 2d | 2012-11-06 | 2012-11-07 | 460, 494 |  |  |  |  |  | 624d | 0d |  | Electrical Technician | 16h |  |  |  |
| 496 | 6.1.2.11.5.15 | Install additional cable tray |  | 1d | 2012-11-08 | 2012-11-08 | 495 |  |  |  |  |  | 624d | 0d |  | Electrical Technician | 8h |  |  |  |
| 497 | 6.1.2.11.5.16 | EMR Reposition | milestone | 0d | 2012-11-08 | 2012-11-08 | 462, 496 |  |  |  |  |  | 624d | 0d |  |  |  |  |  |  |
| 498 | 6.1.2.11.5.17 | Re-cable EMR In new position |  | 2d | 2012-11-09 | 2012-11-12 | 497 |  |  |  |  |  | 624d | 0d |  | Electrical Technician | 16h |  |  |  |
| 499 | 6.1.2.11.5.18 | EMR electrical Step II complete | milestone | 0d | 2012-11-12 | 2012-11-12 | 498 |  |  |  |  |  | 624d |  |  |  |  |  |  |  |

| ID | WBS | Task | Type | Duration | Start | Finish | Predecessors | Complete | Remaining | Baseline start | Baseline finish | Baseline duration | Total slack | Free slack | Constraint | Resources | Work | Actual work | Cost | Baseline cost | Actual cost |
| --- | --- | --- | --- | --- | --- | --- | --- | --- | --- | --- | --- | --- | --- | --- | --- | --- | --- | --- | --- | --- | --- |
| 500 | 6.1.2.11.6 | **EMR Step IV** |  | 10.18d | 2012-10-15 | 2012-10-29 |  |  |  | 2011-04-14 | 2011-04-26 | 9d | 634.65d |  |  |  | 81.4h |  | 1,000 | 4,384 |  |
| 501 | 6.1.2.11.6.1 | Evaluate cable / system requirements |  | 2.77d | 2012-10-15 | 2012-10-17 | 468 |  |  | 2011-04-14 | 2011-04-18 | 3d | 634.65d | 0d | start no earlier than 2009-11-25 | Electrical Designer | 22.2h |  | 1,000 | 2,128 |  |
| 502 | 6.1.2.11.6.2 | Install additional cable management |  | 1.85d | 2012-10-17 | 2012-10-19 | 501 |  |  | 2011-04-19 | 2011-04-20 | 2d | 634.65d | 0d |  | Electrical Technician | 14.8h |  |  | 752 |  |
| 503 | 6.1.2.11.6.3 | Install cables |  | 3.7d | 2012-10-19 | 2012-10-25 | 502 |  |  | 2011-04-21 | 2011-04-25 | 3d | 634.65d | 0d |  | Electrical Technician | 29.6h |  |  | 1,128 |  |
| 504 | 6.1.2.11.6.4 | Terminate cables |  | 1.85d | 2012-10-25 | 2012-10-29 | 503 |  |  | 2011-04-26 | 2011-04-26 | 1d | 634.65d | 0d |  | Electrical Technician | 14.8h |  |  | 376 |  |
| 505 | 6.1.2.11.6.5 | EMR Step IV electrical complete | milestone | 0d | 2012-10-29 | 2012-10-29 | 504 |  |  | 2011-04-26 | 2011-04-26 | 0d | 634.65d |  |  |  |  |  |  |  |  |
| 506 | 6.1.2.11.7 | **EMR Step V** |  | 10.18d | 2013-12-16 | 2013-12-30 |  |  |  | 2012-04-05 | 2012-04-17 | 9d | 329.65d |  |  |  | 81.4h |  | 1,000 | 4,384 |  |
| 507 | 6.1.2.11.7.1 | Evaluate cable / system requirements |  | 2.77d | 2013-12-16 | 2013-12-18 | 474 |  |  | 2012-04-05 | 2012-04-09 | 3d | 329.65d | 0d | start no earlier than 2010-02-01 | Electrical Designer | 22.2h |  | 1,000 | 2,128 |  |
| 508 | 6.1.2.11.7.2 | Install additional cable management |  | 1.85d | 2013-12-18 | 2013-12-20 | 507 |  |  | 2012-04-10 | 2012-04-11 | 2d | 329.65d | 0d |  | Electrical Technician | 14.8h |  |  | 752 |  |
| 509 | 6.1.2.11.7.3 | Install cables |  | 3.7d | 2013-12-20 | 2013-12-26 | 508 |  |  | 2012-04-12 | 2012-04-16 | 3d | 329.65d | 0d |  | Electrical Technician | 29.6h |  |  | 1,128 |  |
| 510 | 6.1.2.11.7.4 | Terminate cables |  | 1.85d | 2013-12-26 | 2013-12-30 | 509 |  |  | 2012-04-17 | 2012-04-17 | 1d | 329.65d | 0d |  | Electrical Technician | 14.8h |  |  | 376 |  |
| 511 | 6.1.2.11.7.5 | EMR Step V electrical complete | milestone | 0d | 2013-12-30 | 2013-12-30 | 510 |  |  | 2012-04-17 | 2012-04-17 | 0d | 329.65d |  |  |  |  |  |  |  |  |
| 512 | 6.1.2.11.8 | **EMR Step VI** |  | 10.18d | 2015-02-13 | 2015-02-27 |  |  |  | 2012-11-08 | 2012-11-20 | 9d? | 25.5d |  |  |  | 81.4h |  | 1,000 | 4,384 |  |
| 513 | 6.1.2.11.8.1 | Evaluate cable / system requirements |  | 2.77d | 2015-02-13 | 2015-02-18 | 480 |  |  | 2012-11-08 | 2012-11-12 | 3d | 25.5d | 0d | start no earlier than 2010-02-01 | Electrical Designer | 22.2h |  | 1,000 | 2,128 |  |
| 514 | 6.1.2.11.8.2 | Install additional cable management |  | 1.85d | 2015-02-18 | 2015-02-19 | 513 |  |  | 2012-11-13 | 2012-11-14 | 2d | 25.5d | 0d |  | Electrical Technician | 14.8h |  |  | 752 |  |
| 515 | 6.1.2.11.8.3 | Install cables |  | 3.7d | 2015-02-19 | 2015-02-25 | 514 |  |  | 2012-11-15 | 2012-11-19 | 3d | 25.5d | 0d |  | Electrical Technician | 29.6h |  |  | 1,128 |  |
| 516 | 6.1.2.11.8.4 | Terminate cables |  | 1.85d | 2015-02-25 | 2015-02-27 | 515 |  |  | 2012-11-20 | 2012-11-20 | 1d | 25.5d | 0d |  | Electrical Technician | 14.8h |  |  | 376 |  |
| 517 | 6.1.2.11.8.5 | EMR Step VI electrical complete | milestone | 0d | 2015-02-27 | 2015-02-27 | 516 |  |  | 2012-11-20 | 2012-11-20 | 0d | 25.5d |  |  |  |  |  |  |  |  |
| 518 | 6.2 | **Hydrogen system** |  | 981d | 2010-04-05 A | 2014-03-26 |  | 26% | 728.56d |  |  |  | 267d |  |  | Hydrogen System | 10540h | 736h | 185,221.64 |  | 24,989.08 |
| 519 | 6.2.1 | **Hydrogen system A/R&D** |  | 323d | 2010-04-05 A | 2011-06-29 |  | 49% | 164.66d |  |  |  | 925d |  |  |  | 1452h | 736h | 56,544.76 |  | 24,989.08 |
| 520 | 6.2.1.1 | **Hydrogen System A/R&D Infrastructure** |  | 303d | 2010-05-03 A | 2011-06-29 |  | 42% | 175.81d |  |  |  | 925d | 0d |  |  | 1008h | 508h | 29,874.08 |  | 10,074.08 |
| 521 | 6.2.1.1.1 | **Ventilation / Extraction System** |  | 96d | 2010-12-13 A | 2011-04-25 |  | 4% | 92d |  |  |  | 938d |  |  |  | 248h | 28h | 5,274.08 |  | 474.08 |
| 522 | 6.2.1.1.1.1 | Install Extraction system controls |  | 10d | 2011-01-21 A | 2011-02-03 |  | 25% | 7.5d |  |  |  | 1029d |  | start no earlier than 2011-01-21 | Electrical Technician | 80h | 20h |  |  |  |
| 523 | 6.2.1.1.1.2 | Install UPS |  | 2d | 2011-03-24 A | 2011-03-25 A |  | 100% |  |  |  |  |  |  | start no earlier than 2011-03-24 | Ian Mullacrane [50%]; Electrical Technician | 8h | 8h | 474.08 |  | 474.08 |
| 524 | 6.2.1.1.1.3 | Install high level vents and extraction fans |  | 80d | 2010-12-13 | 2011-04-01 |  |  |  |  |  |  | 988d |  | start no earlier than 2010-12-13 | Merit1 [25%] | 160h |  | 4,800 |  |  |
| 525 | 6.2.1.1.1.4 | Install hydrogen detection system in Hall |  | 5d | 2011-04-04 | 2011-04-08 |  |  |  |  |  |  | 983d |  | start no earlier than 2011-04-04 |  |  |  |  |  |  |
| 526 | 6.2.1.1.1.5 | Test operation of hydrogen detection |  | 11d | 2011-04-11 | 2011-04-25 |  |  |  |  |  |  | 972d |  | start no earlier than 2011-04-11 |  |  |  |  |  |  |

| ID | WBS | Task | Duration | Start | Finish | Predecessors | Complete | Remaining | Total slack | Free slack | Constraint | Resources | Work | Actual work | Cost | Actual cost |
| --- | --- | --- | --- | --- | --- | --- | --- | --- | --- | --- | --- | --- | --- | --- | --- | --- |
| 527 | 6.2.1.1.2 | **Vacuum System** | 30d | 2011-05-19 | 2011-06-29 |  |  |  | 891d |  |  |  | 240h |  |  |  |
| 528 | 6.2.1.1.2.1 | Install / Terminate power feeds associated with pumping system | 10d | 2011-05-19 | 2011-06-01 | 539 |  |  | 925d | 0d | start no earlier than 2011-05-19 | Electrical Technician | 80h |  |  |  |
| 529 | 6.2.1.1.2.2 | Install AC cabling main feeds etc | 20d | 2011-06-02 | 2011-06-29 | 528 |  |  | 925d |  |  | Electrical Technician | 160h |  |  |  |
| 530 | 6.2.1.1.3 | **Pump Enclosure** | 20d | 2011-03-21 | 2011-04-15 |  |  |  | 101d | 0d |  |  | 40h |  | 15,000 |  |
| 531 | 6.2.1.1.3.1 | Install electrical services | 20d | 2011-03-21 | 2011-04-15 |  |  |  | 135d |  | start no earlier than 2011-03-21 | Gordon Stanford [25%] | 40h |  | 15,000 |  |
| 532 | 6.2.1.1.4 | **Supply pipework** | 40d | 2010-10-04 A | 2010-11-26 A |  | 100% |  |  |  |  |  | 320h | 320h | 9,600 | 9,600 |
| 533 | 6.2.1.1.4.1 | Install piping to bottle store (He and N2) | 20d | 2010-10-04 A | 2010-10-29 A |  | 100% |  |  |  |  | Merit1 | 160h | 160h | 4,800 | 4,800 |
| 534 | 6.2.1.1.4.2 | Install piping for charging Hydride Bed | 20d | 2010-11-01 A | 2010-11-26 A | 533 | 100% |  |  |  |  | Merit1 | 160h | 160h | 4,800 | 4,800 |
| 535 | 6.2.1.1.5 | **Prepare H2 Control Room** | 129d | 2010-05-03 A | 2010-10-28 |  | 97% | 3.69d | 1065d |  |  |  | 160h | 160h |  |  |
| 536 | 6.2.1.1.5.1 | Install power, lighting and network | 30d | 2010-05-03 A | 2010-06-11 A |  | 100% |  |  |  |  |  |  |  |  |  |
| 537 | 6.2.1.1.5.2 | Install Air-Conditioning | 20d | 2010-06-14 A | 2010-07-09 | 536 | 90% | 2d | 1178d |  |  |  |  |  |  |  |
| 538 | 6.2.1.1.5.3 | Install electrical feed to HLCR | 5d | 2010-10-01 A | 2010-10-07 A |  | 100% |  |  |  | start no earlier than 2010-10-01 | Electrical Technician | 40h | 40h |  |  |
| 539 | 6.2.1.1.5.4 | Install power distribution boards | 15d | 2010-10-08 A | 2010-10-28 A | 538 | 100% |  |  |  |  | Electrical Technician | 120h | 120h |  |  |
| 540 | 6.2.1.2 | **Installation of main system components sys A/R&D** | 293d | 2010-04-05 A | 2011-05-18 |  | 70% | 87.9d | 135d | 0d |  |  | 444h | 228h | 26,670.68 | 14,915 |
| 541 | 6.2.1.2.1 | Install Gas Panel Enclosure on South Mezzanine | 3d | 2010-10-25 A | 2010-10-27 A |  | 100% |  |  |  | start no earlier than 2010-10-25 | Merit1 | 24h | 24h | 720 | 720 |
| 542 | 6.2.1.2.2 | **Install Heater/Chiler on South Mezzanine** | 5d | 2010-10-28 A | 2010-11-03 |  | 20% | 4d | 241d |  |  |  | 36h | 4h | 1,355.68 | 120 |
| 543 | 6.2.1.2.2.1 | Position on Mezzanine | 1d | 2010-10-28 A | 2010-10-28 A | 541 | 100% |  |  |  |  | Merit1 [50%] | 4h | 4h | 120 | 120 |
| 544 | 6.2.1.2.2.2 | Connect to Hydride Bed and install instrumentation | 4d | 2010-10-29 | 2010-11-03 | 541, 543 |  |  | 275d |  |  | Matt Hills [50%]; Merit1 [50%] | 32h |  | 1,235.68 |  |
| 545 | 6.2.1.2.3 | **Install Test Cryostat in Hall** | 13d | 2010-10-22 A | 2010-11-09 A |  | 100% |  |  |  |  |  | 16h | 16h | 480 | 480 |
| 546 | 6.2.1.2.3.1 | Deliver cryostat to Hall | 1d | 2010-10-22 A | 2010-10-22 A | 116 | 100% |  |  |  | start no earlier than 2008-07-07 |  |  |  |  |  |
| 547 | 6.2.1.2.3.2 | Install cryocooler compressor and lines | 2d | 2010-11-04 A | 2010-11-05 A | 542, 546 | 100% |  |  |  |  | Merit1 [50%] | 8h | 8h | 240 | 240 |
| 548 | 6.2.1.2.3.3 | Install cryostat vacuum pump | 2d | 2010-11-08 A | 2010-11-09 A | 546, 547 | 100% |  |  |  |  | Merit1 [50%] | 8h | 8h | 240 | 240 |
| 549 | 6.2.1.2.4 | Design Transfer Line supports | 20d | 2010-04-05 A | 2010-04-30 A |  | 100% |  |  |  | start no earlier than 2010-04-05 | Alan Muir | 160h | 160h | 7,000 | 7,000 |
| 550 | 6.2.1.2.5 | Manufacture Transfer Line supports | 30d | 2010-05-03 A | 2010-06-11 A | 549 | 100% |  |  |  |  |  |  |  | 5,875 | 5,875 |
| 551 | 6.2.1.2.6 | Install Transfer Line supports | 2d | 2011-01-24 A | 2011-01-25 A | 541, 545 | 100% |  |  |  | start no earlier than 2011-01-24 | Merit1 | 16h | 16h | 480 | 480 |
| 552 | 6.2.1.2.7 | Install Transfer Line | 2d | 2011-01-26 A | 2011-01-27 A | 551 | 100% |  |  |  |  | Merit1 [50%] | 8h | 8h | 240 | 240 |

Notes:
- 534: Will this be done within the hall, or to a dedicated hydrogen storage area?
- 541: Hydride Bed, Gas Panel and Buffer Volume may be installed with enclosure or will be installed on base and enclosure assembled around them.
- 546: Will not be brought into hall until construction work on mezzanine floors are complete.
- 549: Dependent on design of South Mezzanine.

| ID | WBS | Task | Type | Duration | Start | Finish | Predecessors | Total slack | Free slack | Constraint | Resources | Work | Cost |
| --- | --- | --- | --- | --- | --- | --- | --- | --- | --- | --- | --- | --- | --- |
| 553 | 6.2.1.2.8 | **Install Vacuum System** |  | 23d | 2011-04-18 | 2011-05-18 |  | 101d |  |  |  | 184h | 10,520 |
| 554 | 6.2.1.2.8.1 | Install backing pumps in enclosure |  | 3d | 2011-04-18 | 2011-04-20 | 530 | 135d | 0d |  | Merit1 | 24h | 720 |
| 555 | 6.2.1.2.8.2 | Install turbo pumps in hall |  | 10d | 2011-04-21 | 2011-05-04 | 554 | 135d | 0d |  | Merit1 | 80h | 7,400 |
| 556 | 6.2.1.2.8.3 | Install vacuum piping |  | 10d | 2011-05-05 | 2011-05-18 | 555 | 135d |  |  | Merit1 | 80h | 2,400 |
| 557 | 6.2.2 | **Hydrogen system B** |  | 167d | 2012-08-28 | 2013-04-17 |  | 473d |  |  |  | 620h | 64,925.94 |
| 558 | 6.2.2.1 | **Hydrogen System B Infrastructure** |  | 162d | 2012-08-28 | 2013-04-10 |  | 478d | 0d |  |  | 436h | 46,205.26 |
| 559 | 6.2.2.1.1 | **Ventilation System** |  | 20d | 2013-03-14 | 2013-04-10 |  | 444d |  |  |  | 160h | 4,800 |
| 560 | 6.2.2.1.1.1 | Install ductwork and piping |  | 20d | 2013-03-14 | 2013-04-10 |  | 478d |  | start no earlier than 2013-03-14 | Merit1 | 160h | 4,800 |
| 561 | 6.2.2.1.2 | **Vacuum System** |  | 40d | 2012-08-28 | 2012-10-22 |  | 566d |  |  |  | 16h | 33,260.66 |
| 562 | 6.2.2.1.2.1 | Procure pipework, valves and gauges |  | 40d | 2012-08-28 | 2012-10-22 |  | 600d |  | start no earlier than 2012-08-28 | Mike Courthold [5%] | 16h | 18,573.16 |
| 563 | 6.2.2.1.2.2 | Procure pump for AFC |  | 40d | 2012-08-28 | 2012-10-22 |  | 600d |  | start no earlier than 2012-08-28 |  |  | 14,687.5 |
| 564 | 6.2.2.1.3 | **Supply pipework** |  | 20d | 2012-08-28 | 2012-09-24 |  | 586d |  |  |  | 260h | 8,144.6 |
| 565 | 6.2.2.1.3.1 | Identify storage areas and layout pipe routing |  | 5d | 2012-08-28 | 2012-09-03 |  | 620d | 0d | start no earlier than 2012-08-28 | Matt Hills [50%] | 20h | 944.6 |
| 566 | 6.2.2.1.3.2 | Install piping to gas panel (He and N2) |  | 15d | 2012-09-04 | 2012-09-24 | 565 | 620d |  |  | Merit1 | 120h | 3,600 |
| 567 | 6.2.2.1.3.3 | Install piping for charging Hydride Bed |  | 15d | 2012-09-04 | 2012-09-24 | 565 | 620d |  |  | Merit1 | 120h | 3,600 |
| 568 | 6.2.2.2 | **Installation of main system components sys B** |  | 36d | 2013-02-27 | 2013-04-17 |  | 473d | 0d |  |  | 184h | 18,720.68 |
| 569 | 6.2.2.2.1 | Install Gas Panel Enclosure on South Mezzanine |  | 1d | 2013-02-27 | 2013-02-27 |  | 473d | 0d | start no earlier than 2013-02-27 | Merit1 [50%] | 4h | 120 |
| 570 | 6.2.2.2.2 | Install pipework from gas panel to pump enclosure |  | 15d | 2013-02-28 | 2013-04-17 | 569 | 473d |  |  | Merit1 | 120h | 3,600 |
| 571 | 6.2.2.2.3 | **Install Heater/Chiler on South Mezzanine** |  | 7d | 2013-02-28 | 2013-03-08 |  | 467d |  |  |  | 60h | 15,000.68 |
| 572 | 6.2.2.2.3.1 | Position on Mezzanine |  | 1d | 2013-02-28 | 2013-02-28 | 569 | 501d | 0d |  | Merit1 [50%] | 4h | 120 |
| 573 | 6.2.2.2.3.2 | Connect to Hydride Bed and install instrumentation |  | 6d | 2013-03-01 | 2013-03-08 | 569, 572 | 501d | 0d |  | Matt Hills [50%]; Merit1 [50%] | 32h | 12,985.68 |
| 574 | 6.2.2.2.3.3 | Working Margin on instrumentation | milestone | 0d | 2013-03-08 | 2013-03-08 | 573 | 501d |  |  |  |  | 1,175 |
| 575 | 6.2.2.2.3.4 | Install Transfer Line supports |  | 2d | 2013-02-28 | 2013-03-01 | 569 | 504d | 0d |  | Merit1 | 16h | 480 |
| 576 | 6.2.2.2.3.5 | Install Transfer Line |  | 2d | 2013-03-04 | 2013-03-05 | 575 | 504d |  |  | Merit1 [50%] | 8h | 240 |

Notes:
- 567: Will this be done within the hall, or to a dedicated hydrogen storage area?
- 569: Hydride Bed, Gas Panel and Buffer Volume may be installed with enclosure or will be installed on base and enclosure assembled around them.

| ID | WBS | Task | Duration | Start | Finish | Predecessors | Total slack | Free slack | Constraint | Resources | Work | Cost |
| --- | --- | --- | --- | --- | --- | --- | --- | --- | --- | --- | --- | --- |
| 577 | 6.2.3 | **Hydrogen system C** | 162d | 2013-08-13 | 2014-03-26 |  | 226d |  |  |  | 620h | 63,750.94 |
| 578 | 6.2.3.1 | **Hydrogen system C Infrastructure** | 162d | 2013-08-13 | 2014-03-26 |  | 226d | 0d |  |  | 436h | 46,205.26 |
| 579 | 6.2.3.1.1 | **Ventilation System** | 20d | 2014-02-27 | 2014-03-26 |  | 192d |  |  |  | 160h | 4,800 |
| 580 | 6.2.3.1.1.1 | Install ductwork and piping | 20d | 2014-02-27 | 2014-03-26 |  | 226d |  | start no earlier than 2014-02-27 | Merit1 | 160h | 4,800 |
| 581 | 6.2.3.1.2 | **Vacuum System** | 40d | 2013-08-13 | 2013-10-07 |  | 314d |  |  |  | 16h | 33,260.66 |
| 582 | 6.2.3.1.2.1 | Procure pipework, valves and gauges | 40d | 2013-08-13 | 2013-10-07 |  | 348d |  | start no earlier than 2013-08-13 | Mike Courthold [5%] | 16h | 18,573.16 |
| 583 | 6.2.3.1.2.2 | Procure pump for AFC | 40d | 2013-08-13 | 2013-10-07 |  | 348d |  | start no earlier than 2013-08-13 |  |  | 14,687.5 |
| 584 | 6.2.3.1.3 | **Supply pipework** | 35d | 2013-08-20 | 2013-10-07 |  | 314d |  |  |  | 260h | 8,144.6 |
| 585 | 6.2.3.1.3.1 | Identify storage areas and layout pipe routing | 5d | 2013-08-20 | 2013-08-26 |  | 348d | 0d | start no earlier than 2013-08-20 | Matt Hills [50%] | 20h | 944.6 |
| 586 | 6.2.3.1.3.2 | Install piping to gas panel (He and N2) | 15d | 2013-08-27 | 2013-09-16 | 585 | 348d | 0d |  | Merit1 | 120h | 3,600 |
| 587 | 6.2.3.1.3.3 | Install piping for charging Hydride Bed | 15d | 2013-09-17 | 2013-10-07 | 586 | 348d |  |  | Merit1 | 120h | 3,600 |
| 588 | 6.2.3.2 | **Installation of main system components sys C** | 24d | 2014-02-12 | 2014-03-17 |  | 233d | 0d |  |  | 184h | 17,545.68 |
| 589 | 6.2.3.2.1 | Install Gas Panel Enclosure on South Mezzanine | 1d | 2014-02-12 | 2014-02-12 |  | 233d | 0d | start no earlier than 2014-02-12 | Merit1 [50%] | 4h | 120 |
| 590 | 6.2.3.2.2 | Install pipework from gas panel to pump enclosure | 15d | 2014-02-13 | 2014-03-17 | 589 | 233d |  |  | Merit1 | 120h | 3,600 |
| 591 | 6.2.3.2.3 | **Install Heater/Chiler on South Mezzanine** | 7d | 2014-02-13 | 2014-02-21 |  | 215d |  |  |  | 60h | 13,825.68 |
| 592 | 6.2.3.2.3.1 | Position on Mezzanine | 1d | 2014-02-13 | 2014-02-13 | 589 | 249d | 0d |  | Merit1 [50%] | 4h | 120 |
| 593 | 6.2.3.2.3.2 | Connect to Hydride Bed and install instrumentation | 6d | 2014-02-14 | 2014-02-21 | 589, 592 | 249d |  |  | Matt Hills [50%]; Merit1 [50%] | 32h | 12,985.68 |
| 594 | 6.2.3.2.3.3 | Install Transfer Line supports | 2d | 2014-02-13 | 2014-02-14 | 589 | 252d | 0d |  | Merit1 | 16h | 480 |
| 595 | 6.2.3.2.3.4 | Install Transfer Line | 2d | 2014-02-17 | 2014-02-18 | 594 | 252d |  |  | Merit1 [50%] | 8h | 240 |
| 596 | 6.3 | **AFC - Focus coils (Pre test Work in situ for step IV)** | 114d | 2011-09-06 | 2012-03-21 |  | 34d |  |  | Focus Coils | 912h |  |
| 597 | 6.3.1 | **Tesla on-site commissioning and acceptance test** | 27d | 2011-09-06 | 2011-10-12 |  | 34d |  |  |  |  |  |
| 598 | 6.3.1.1 | Installation | 10d | 2011-09-06 | 2011-09-19 | 113 | 34d | 0d | start no earlier than 2011-07-01 |  |  |  |
| 599 | 6.3.1.2 | Connection of services | 10d | 2011-09-20 | 2011-10-03 | 598 | 34d | 0d |  |  |  |  |
| 600 | 6.3.1.3 | Cool down | 5d | 2011-10-04 | 2011-10-10 | 599 | 34d | 0d |  |  |  |  |
| 601 | 6.3.1.4 | Ramp up current | 2d | 2011-10-11 | 2011-10-12 | 600 | 34d | 0d |  |  |  |  |

Notes:
- 587: Will this be done within the hall, or to a dedicated hydrogen storage area?
- 589: Hydride Bed, Gas Panel and Buffer Volume may be installed with enclosure or will be installed on base and enclosure assembled around them.
- 596: esting now proposed in R9 and then finaltesting in MICE hall

| ID | WBS | Task | Duration | Start | Finish | Predecessors | Total slack | Free slack |
| --- | --- | --- | --- | --- | --- | --- | --- | --- |
| 602 | 6.3.2 | **Field Mapping at full field** | 18d | 2011-10-13 | 2011-11-07 | 601 | 34d |  |
| 603 | 6.3.2.1 | Set-up | 10d | 2011-10-13 | 2011-10-26 |  | 34d | 0d |
| 604 | 6.3.2.2 | Mapping | 8d | 2011-10-27 | 2011-11-07 | 603 | 34d | 0d |
| 605 | 6.3.3 | **Absorber integration** | 18d | 2011-11-08 | 2012-01-10 | 604 | 34d |  |
| 606 | 6.3.3.1 | Fit absorber | 5d | 2011-11-08 | 2011-11-14 | 604 | 856d |  |
| 607 | 6.3.3.2 | Integrate with Transfer line | 10d | 2011-11-08 | 2011-12-29 | 604 | 34d | 0d |
| 608 | 6.3.3.3 | Leak check and pump | 5d | 2011-12-30 | 2012-01-05 | 607 | 34d | 0d |
| 609 | 6.3.3.4 | Instrumentation check | 3d | 2012-01-06 | 2012-01-10 | 608 | 34d | 0d |
| 610 | 6.3.4 | **Safety windows** | 5d | 2012-01-11 | 2012-01-17 | 609 | 34d |  |
| 611 | 6.3.4.1 | Installation | 2d | 2012-01-11 | 2012-01-12 |  | 34d | 0d |
| 612 | 6.3.4.2 | Leak check | 3d | 2012-01-13 | 2012-01-17 | 611 | 34d | 0d |
| 613 | 6.3.5 | **Cover plate installation** | 4d | 2012-01-18 | 2012-01-23 | 612 | 34d | 0d |
| 614 | 6.3.5.1 | Install | 1d | 2012-01-18 | 2012-01-18 |  | 34d | 0d |
| 615 | 6.3.5.2 | Pump down and leak check | 3d | 2012-01-19 | 2012-01-23 | 614 | 34d |  |
| 616 | 6.3.6 | **Preliminary cool-down** | 19d | 2012-01-24 | 2012-02-17 | 613 | 34d | 0d |
| 617 | 6.3.6.1 | Base temperature test | 10d | 2012-01-24 | 2012-02-06 |  | 34d | 0d |
| 618 | 6.3.6.2 | Helium condensation | 3d | 2012-02-07 | 2012-02-09 | 617 | 34d | 0d |
| 619 | 6.3.6.3 | Cooling power at 20K | 2d | 2012-02-10 | 2012-02-13 | 618 | 34d | 0d |
| 620 | 6.3.6.4 | Warm-up H2 system | 4d | 2012-02-14 | 2012-02-17 | 619 | 34d |  |
| 621 | 6.3.7 | **Hydrogen System test** | 23d | 2012-02-20 | 2012-03-21 | 616, 1009 | 34d |  |
| 622 | 6.3.7.1 | Cool down | 3d | 2012-02-20 | 2012-02-22 |  | 34d | 0d |
| 623 | 6.3.7.2 | Part fill with hydrogen | 3d | 2012-02-23 | 2012-02-27 | 622 | 34d | 0d |
| 624 | 6.3.7.3 | Warm-up H2 system | 2d | 2012-02-28 | 2012-02-29 | 623 | 34d | 0d |
| 625 | 6.3.7.4 | Purge | 1d | 2012-03-01 | 2012-03-01 | 624 | 34d | 0d |
| 626 | 6.3.7.5 | Cool & Fill with hydrogen | 8d | 2012-03-02 | 2012-03-13 | 625 | 34d | 0d |
| 627 | 6.3.7.6 | Hold for two days | 2d | 2012-03-14 | 2012-03-15 | 626 | 34d | 0d |
| 628 | 6.3.7.7 | Ramp up field and hold | 1d | 2012-03-16 | 2012-03-16 | 627 | 34d | 0d |
| 629 | 6.3.7.8 | Warm-up H2 system | 2d | 2012-03-19 | 2012-03-20 | 628 | 34d | 0d |
| 630 | 6.3.7.9 | purge | 1d | 2012-03-21 | 2012-03-21 | 629 | 34d | 12d |

| ID | WBS | Task | Type | Duration | Start | Finish | Predecessors | Complete | Remaining | Total slack | Free slack | Constraint | Resources | Work | Actual work | Cost |
| --- | --- | --- | --- | --- | --- | --- | --- | --- | --- | --- | --- | --- | --- | --- | --- | --- |
| 631 | 6.4 | **RF system** |  | 640d | 2011-02-07 A | 2013-10-08 |  |  | 639.05d | 388d |  |  | RF System | 17845.9h | 34.67h | 32,000 |
| 632 | 6.4.1 | **Infrastructure** |  | 615.9d | 2011-02-07 A | 2013-09-04 |  |  | 614.89d | 378.1d |  |  |  | 8821.9h | 27.05h | 32,000 |
| 633 | 6.4.1.1 | **RF Hall Electrical Infrastructure** |  | 615.9d | 2011-02-07 A | 2013-09-04 |  |  | 614.86d | 378.1d |  |  |  | 8821.9h | 27.05h | 32,000 |
| 634 | 6.4.1.1.1 | **RF Controls Rack #1** |  | 12d | 2011-04-25 | 2011-05-10 |  |  |  | 927d |  |  | STEP V - TIARA | 192h |  |  |
| 635 | 6.4.1.1.1.1 | Install rack in MICE Hall |  | 2d | 2011-04-25 | 2011-04-26 |  |  |  | 961d | 0d | start no earlier than 2011-04-25 | Electrical Technician | 16h |  |  |
| 636 | 6.4.1.1.1.2 | Install interface cable management / cable |  | 5d | 2011-04-27 | 2011-05-03 | 635 |  |  | 961d | 0d |  | Electrical Technician | 40h |  |  |
| 637 | 6.4.1.1.1.3 | Commission system in MICE Hall |  | 5d | 2011-05-04 | 2011-05-10 | 636 |  |  | 961d |  |  | Electrical Engineer | 40h |  |  |
| 638 | 6.4.1.1.2 | **RF Controls Rack #2** |  | 12d | 2012-08-16 | 2012-08-31 |  |  |  | 641d |  |  | STEP V - TIARA | 192h |  |  |
| 639 | 6.4.1.1.2.1 | Install rack in MICE Hall |  | 2d | 2012-08-16 | 2012-08-17 |  |  |  | 675d | 0d | start no earlier than 2012-08-16 | Electrical Technician | 16h |  |  |
| 640 | 6.4.1.1.2.2 | Install interface cable management / cable |  | 5d | 2012-08-20 | 2012-08-24 | 639 |  |  | 675d | 0d |  | Electrical Technician | 40h |  |  |
| 641 | 6.4.1.1.2.3 | Commission system in MICE Hall |  | 5d | 2012-08-27 | 2012-08-31 | 640 |  |  | 675d |  |  | Electrical Engineer | 40h |  |  |
| 642 | 6.4.1.1.3 | **RF System #1 - Installation** |  | 174d | 2011-02-07 A | 2011-12-26 |  | 1% | 172.62d | 387.1d |  |  | STEP V - TIARA | 2862h | 27.05h | 8,000 |
| 643 | 6.4.1.1.3.1 | **4616 Amplifier system #1** |  | 131d | 2011-02-07 A | 2011-09-16 |  | 1% | 129.42d | 387.1d |  |  |  | 870h | 16h | 4,000 |
| 644 | 6.4.1.1.3.1.1 | RF System #1 integration starts | milestone | 0d | 2011-02-07 A | 2011-02-07 A |  | 100% |  |  |  | start no earlier than 2011-02-07 |  |  |  |  |
| 645 | 6.4.1.1.3.1.2 | Design cable management |  | 2d | 2011-02-07 A | 2011-02-08 | 644 | 50% | 1d | 469.1d | 0d |  | Electrical Engineer; Electrical Designer | 32h | 16h |  |
| 646 | 6.4.1.1.3.1.3 | Install cable management |  | 3d | 2011-02-09 | 2011-02-11 | 645 |  |  | 469.1d | 0d |  | Electrical Designer; Electrical Technician | 48h |  | 1,000 |
| 647 | 6.4.1.1.3.1.4 | Design AC distribution |  | 2d | 2011-02-14 | 2011-02-15 | 646 |  |  | 469.1d | 48d |  | Electrical Designer; Electrical Engineer | 32h |  |  |
| 648 | 6.4.1.1.3.1.5 | Install AC distribution |  | 10d | 2011-04-25 | 2011-05-06 | 647 |  |  | 421.1d | 0d | start no earlier than 2011-04-25 | Electrical Technician; Electrical Designer | 160h |  | 1,000 |
| 649 | 6.4.1.1.3.1.6 | Produce cable schedules - controls interface |  | 10d | 2011-05-09 | 2011-05-20 | 648 |  |  | 421.1d | 0d |  | Electrical Designer; Electrical Engineer | 160h |  |  |
| 650 | 6.4.1.1.3.1.7 | Install controls cables |  | 10d | 2011-05-23 | 2011-06-03 | 649 |  |  | 421.1d | 0d |  | Electrical Designer; Electrical Technician | 160h |  | 1,500 |
| 651 | 6.4.1.1.3.1.8 | System #1 4616 Racks ready | milestone | 0d | 2011-06-03 | 2011-06-03 | 650 |  |  | 421.1d | 0d | start no earlier than 2011-01-24 |  |  |  |  |
| 652 | 6.4.1.1.3.1.9 | Install HV Rack |  | 2d | 2011-06-06 | 2011-06-07 | 651 |  |  | 421.1d | 0d |  | Electrical Technician | 16h |  |  |
| 653 | 6.4.1.1.3.1.10 | Terminate HV Rack cables |  | 3d | 2011-06-08 | 2011-06-10 | 652 |  |  | 421.1d | 0d |  | Electrical Technician | 24h |  |  |
| 654 | 6.4.1.1.3.1.11 | Install Auxiliary Rack |  | 2d | 2011-06-13 | 2011-06-14 | 653 |  |  | 421.1d | 0d |  | Electrical Technician | 16h |  |  |
| 655 | 6.4.1.1.3.1.12 | Terminate Auxiliary Rack cables |  | 4d | 2011-06-15 | 2011-06-20 | 654 |  |  | 421.1d | 0d |  | Electrical Technician | 32h |  | 500 |
| 656 | 6.4.1.1.3.1.13 | Prepare 4616 Dummy Load |  | 10d | 2011-06-21 | 2011-07-04 | 655 |  |  | 421.1d | 0d |  | Electrical Technician; Electrical Engineer [25%] | 100h |  |  |
| 657 | 6.4.1.1.3.1.14 | Commission Electrical system |  | 5d | 2011-08-15 | 2011-08-19 | 656 |  |  | 421.1d | 0d |  | Electrical Engineer; Electrical Technician [25%] | 50h |  |  |
| 658 | 6.4.1.1.3.1.15 | Commission RF with Dummy Load |  | 20d | 2011-08-22 | 2011-09-16 | 657 |  |  | 421.1d | 0d |  | Electrical Engineer [25%] | 40h |  |  |

| ID | WBS | Task | Type | Duration | Start | Finish | Predecessors | Total slack | Free slack | Constraint | Resources | Work | Cost |
| --- | --- | --- | --- | --- | --- | --- | --- | --- | --- | --- | --- | --- | --- |
| 659 | 6.4.1.1.3.2 | **TH116 Amplifier system #1** |  | 43d | 2011-09-19 | 2011-12-26 |  | 387.1d |  |  |  | 600h | 4,000 |
| 660 | 6.4.1.1.3.2.1 | Design cable management |  | 2d | 2011-09-19 | 2011-09-20 | 658 | 421.1d | 0d |  | Electrical Engineer; Electrical Designer | 32h |  |
| 661 | 6.4.1.1.3.2.2 | Install cable management |  | 3d | 2011-09-21 | 2011-09-23 | 660 | 421.1d | 0d |  | Electrical Designer; Electrical Technician | 48h | 1,000 |
| 662 | 6.4.1.1.3.2.3 | Design AC distribution |  | 2d | 2011-09-26 | 2011-09-27 | 661 | 421.1d | 0d |  | Electrical Designer; Electrical Engineer | 32h |  |
| 663 | 6.4.1.1.3.2.4 | Install AC distribution |  | 5d | 2011-09-28 | 2011-10-04 | 662 | 421.1d | 0d |  | Electrical Technician; Electrical Designer | 80h | 1,000 |
| 664 | 6.4.1.1.3.2.5 | Produce cable schedules - controls interface |  | 10d | 2011-10-05 | 2011-10-18 | 663 | 421.1d | 0d |  | Electrical Designer; Electrical Engineer | 160h |  |
| 665 | 6.4.1.1.3.2.6 | Install controls cables |  | 10d | 2011-10-19 | 2011-11-01 | 664 | 421.1d | 0d |  | Electrical Designer; Electrical Technician | 160h | 1,500 |
| 666 | 6.4.1.1.3.2.7 | System #1 TH116 Racks ready | milestone | 0d | 2011-11-01 | 2011-11-01 | 665 | 421.1d | 0d | start no earlier than 2011-04-11 |  |  |  |
| 667 | 6.4.1.1.3.2.8 | Install HV Rack |  | 2d | 2011-11-02 | 2011-11-03 | 666 | 421.1d | 0d |  | Electrical Technician | 16h |  |
| 668 | 6.4.1.1.3.2.9 | Terminate HV Rack cables |  | 3d | 2011-11-04 | 2011-11-08 | 667 | 421.1d | 0d |  | Electrical Technician | 24h |  |
| 669 | 6.4.1.1.3.2.10 | Install Auxiliary Rack |  | 2d | 2011-11-09 | 2011-11-10 | 668 | 421.1d | 0d |  | Electrical Technician | 16h |  |
| 670 | 6.4.1.1.3.2.11 | Terminate Auxiliary Rack cables |  | 4d | 2011-11-11 | 2011-12-26 | 669 | 421.1d | 0d |  | Electrical Technician | 32h | 500 |
| 671 | 6.4.1.1.4 | **RF System #2 - Installation** |  | 116.55d | 2012-01-09 | 2012-06-19 |  | 378.1d |  | start no earlier than 2012-01-09 | STEP V - TIARA | 2338.4h | 8,000 |
| 672 | 6.4.1.1.4.1 | **4616 Amplifier system #2** |  | 58.27d | 2012-01-09 | 2012-03-29 | 670 | 378.1d |  |  |  | 703h | 4,000 |
| 673 | 6.4.1.1.4.1.1 | RF System #2 integration starts | milestone | 0d | 2012-01-09 | 2012-01-09 |  | 412.1d | 0d | start no earlier than 2011-04-04 |  |  |  |
| 674 | 6.4.1.1.4.1.2 | Design cable management |  | 1.85d | 2012-01-09 | 2012-01-10 | 673 | 412.1d | 0d |  | Electrical Engineer; Electrical Designer | 29.6h |  |
| 675 | 6.4.1.1.4.1.3 | Install cable management |  | 2.77d | 2012-01-10 | 2012-01-13 | 674 | 412.1d | 0d |  | Electrical Designer; Electrical Technician | 44.4h | 1,000 |
| 676 | 6.4.1.1.4.1.4 | Design AC distribution |  | 1.85d | 2012-01-13 | 2012-01-17 | 675 | 412.1d | 0d |  | Electrical Designer; Electrical Engineer | 29.6h |  |
| 677 | 6.4.1.1.4.1.5 | Install AC distribution |  | 4.62d | 2012-01-17 | 2012-01-24 | 676 | 412.1d | 0d |  | Electrical Technician; Electrical Designer | 74h | 1,000 |
| 678 | 6.4.1.1.4.1.6 | Produce cable schedules - controls interface |  | 9.25d | 2012-01-24 | 2012-02-06 | 677 | 412.1d | 0d |  | Electrical Designer; Electrical Engineer | 148h |  |
| 679 | 6.4.1.1.4.1.7 | Install controls cables |  | 9.25d | 2012-02-06 | 2012-02-17 | 678 | 412.1d | 0d |  | Electrical Designer; Electrical Technician | 148h | 1,500 |
| 680 | 6.4.1.1.4.1.8 | System #2 4616 Racks ready | milestone | 0d | 2012-02-17 | 2012-02-17 | 679 | 412.1d | 0d | start no earlier than 2011-08-08 |  |  |  |
| 681 | 6.4.1.1.4.1.9 | Install HV Rack |  | 1.85d | 2012-02-17 | 2012-02-21 | 680 | 412.1d | 0d |  | Electrical Technician | 14.8h |  |
| 682 | 6.4.1.1.4.1.10 | Terminate HV Rack cables |  | 2.77d | 2012-02-21 | 2012-02-24 | 681 | 412.1d | 0d |  | Electrical Technician | 22.2h |  |
| 683 | 6.4.1.1.4.1.11 | Install Auxiliary Rack |  | 1.85d | 2012-02-24 | 2012-02-28 | 682 | 412.1d | 0d |  | Electrical Technician | 14.8h |  |
| 684 | 6.4.1.1.4.1.12 | Terminate Auxiliary Rack cables |  | 3.7d | 2012-02-28 | 2012-03-02 | 683 | 412.1d | 0d |  | Electrical Technician | 29.6h | 500 |
| 685 | 6.4.1.1.4.1.13 | Prepare 4616 Dummy Load |  | 9.25d | 2012-03-02 | 2012-03-16 | 684 | 412.1d | 0d |  | Electrical Technician; Electrical Engineer [25%] | 92.5h |  |
| 686 | 6.4.1.1.4.1.14 | Commission Electrical system |  | 4.62d | 2012-03-16 | 2012-03-22 | 685 | 412.1d | 0d |  | Electrical Engineer; Electrical Technician [25%] | 46.25h |  |
| 687 | 6.4.1.1.4.1.15 | Commission RF with Dummy Load |  | 4.62d | 2012-03-22 | 2012-03-29 | 686 | 412.1d | 0d |  | Electrical Engineer [25%] | 9.25h |  |

| ID | WBS | Task | Type | Duration | Start | Finish | Predecessors | Total slack | Free slack | Constraint | Resources | Work | Cost |
| --- | --- | --- | --- | --- | --- | --- | --- | --- | --- | --- | --- | --- | --- |
| 688 | 6.4.1.1.4.2 | **TH116 Amplifier system #2** |  | 58.27d | 2012-03-29 | 2012-06-19 |  | 378.1d |  |  |  | 703h | 4,000 |
| 689 | 6.4.1.1.4.2.1 | Design cable management |  | 1.85d | 2012-03-29 | 2012-04-02 | 687 | 412.1d | 0d |  | Electrical Engineer; Electrical Designer | 29.6h |  |
| 690 | 6.4.1.1.4.2.2 | Install cable management |  | 2.77d | 2012-04-02 | 2012-04-04 | 689 | 412.1d | 0d |  | Electrical Designer; Electrical Technician | 44.4h | 1,000 |
| 691 | 6.4.1.1.4.2.3 | Design AC distribution |  | 1.85d | 2012-04-04 | 2012-04-06 | 690 | 412.1d | 0d |  | Electrical Designer; Electrical Engineer | 29.6h |  |
| 692 | 6.4.1.1.4.2.4 | Install AC distribution |  | 4.62d | 2012-04-06 | 2012-04-13 | 691 | 412.1d | 0d |  | Electrical Technician; Electrical Designer | 74h | 1,000 |
| 693 | 6.4.1.1.4.2.5 | Produce cable schedules - controls interface |  | 9.25d | 2012-04-13 | 2012-04-26 | 692 | 412.1d | 0d |  | Electrical Designer; Electrical Engineer | 148h |  |
| 694 | 6.4.1.1.4.2.6 | Install controls cables |  | 9.25d | 2012-04-26 | 2012-05-09 | 693 | 412.1d | 0d |  | Electrical Designer; Electrical Technician | 148h | 1,500 |
| 695 | 6.4.1.1.4.2.7 | System #2 TH116 Racks ready | milestone | 0d | 2012-05-09 | 2012-05-09 | 694 | 412.1d | 0d | start no earlier than 2011-10-17 |  |  |  |
| 696 | 6.4.1.1.4.2.8 | Install HV Rack |  | 1.85d | 2012-05-09 | 2012-05-11 | 695 | 412.1d | 0d |  | Electrical Technician | 14.8h |  |
| 697 | 6.4.1.1.4.2.9 | Terminate HV Rack cables |  | 2.77d | 2012-05-11 | 2012-05-16 | 696 | 412.1d | 0d |  | Electrical Technician | 22.2h |  |
| 698 | 6.4.1.1.4.2.10 | Install Auxiliary Rack |  | 1.85d | 2012-05-16 | 2012-05-18 | 697 | 412.1d | 0d |  | Electrical Technician | 14.8h |  |
| 699 | 6.4.1.1.4.2.11 | Terminate Auxiliary Rack cables |  | 3.7d | 2012-05-18 | 2012-05-24 | 698 | 412.1d | 0d |  | Electrical Technician | 29.6h | 500 |
| 700 | 6.4.1.1.4.2.12 | Prepare TH116 Dummy Load |  | 9.25d | 2012-05-24 | 2012-06-06 | 699 | 412.1d | 0d |  | Electrical Technician; Electrical Engineer [25%] | 92.5h |  |
| 701 | 6.4.1.1.4.2.13 | Commission Electrical system |  | 4.62d | 2012-06-06 | 2012-06-12 | 700 | 412.1d | 0d |  | Electrical Engineer; Electrical Technician [25%] | 46.25h |  |
| 702 | 6.4.1.1.4.2.14 | Commission RF with Dummy Load |  | 4.62d | 2012-06-12 | 2012-06-19 | 701 | 412.1d | 0d |  | Electrical Engineer [25%] | 9.25h |  |
| 703 | 6.4.1.1.5 | **RF Waveguide -Systems #1&2** |  | 13.88d | 2012-06-19 | 2012-07-09 | 702 | 378.1d |  |  | STEP V - TIARA | 222h |  |
| 704 | 6.4.1.1.5.1 | Review waveguide controls interface |  | 9.25d | 2012-06-19 | 2012-07-02 |  | 412.1d | 0d | start no earlier than 2012-04-30 | Electrical Engineer | 74h |  |
| 705 | 6.4.1.1.5.2 | RF Waveguide Installation complete | milestone | 0d | 2012-07-02 | 2012-07-02 | 704 | 412.1d | 0d | start no earlier than 2012-06-21 |  |  |  |
| 706 | 6.4.1.1.5.3 | Install Waveguide controls wiring |  | 4.62d | 2012-07-02 | 2012-07-09 | 705 | 412.1d | 0d |  | Electrical Technician | 37h |  |
| 707 | 6.4.1.1.6 | **RF System #3 - Installation** |  | 116.55d | 2012-07-09 | 2012-12-18 |  | 378.1d |  |  |  | 1406h | 8,000 |
| 708 | 6.4.1.1.6.1 | **4616 Amplifier system #3** |  | 58.27d | 2012-07-09 | 2012-09-27 | 706 | 378.1d |  |  |  | 703h | 4,000 |
| 709 | 6.4.1.1.6.1.1 | RF System #3 Integration starts | milestone | 0d | 2012-07-09 | 2012-07-09 |  | 714.58d |  |  |  |  |  |
| 710 | 6.4.1.1.6.1.2 | Design cable management |  | 1.85d | 2012-07-09 | 2012-07-11 |  | 412.1d | 0d |  | Electrical Engineer; Electrical Designer | 29.6h |  |
| 711 | 6.4.1.1.6.1.3 | Install cable management |  | 2.77d | 2012-07-11 | 2012-07-16 | 710 | 412.1d | 0d |  | Electrical Designer; Electrical Technician | 44.4h | 1,000 |
| 712 | 6.4.1.1.6.1.4 | Design AC distribution |  | 1.85d | 2012-07-16 | 2012-07-17 | 711 | 412.1d | 0d |  | Electrical Designer; Electrical Engineer | 29.6h |  |
| 713 | 6.4.1.1.6.1.5 | Install AC distribution |  | 4.62d | 2012-07-17 | 2012-07-24 | 712 | 412.1d | 0d |  | Electrical Technician; Electrical Designer | 74h | 1,000 |
| 714 | 6.4.1.1.6.1.6 | Produce cable schedules - controls interface |  | 9.25d | 2012-07-24 | 2012-08-06 | 713 | 412.1d | 0d |  | Electrical Designer; Electrical Engineer | 148h |  |
| 715 | 6.4.1.1.6.1.7 | Install controls cables |  | 9.25d | 2012-08-06 | 2012-08-20 | 714 | 412.1d | 0d |  | Electrical Designer; Electrical Technician | 148h | 1,500 |
| 716 | 6.4.1.1.6.1.8 | System #3 4616 Racks ready | milestone | 0d | 2012-08-20 | 2012-08-20 | 715 | 412.1d | 0d | start no earlier than 2011-01-24 |  |  |  |
| 717 | 6.4.1.1.6.1.9 | Install HV Rack |  | 1.85d | 2012-08-20 | 2012-08-21 | 716 | 412.1d | 0d |  | Electrical Technician | 14.8h |  |
| 718 | 6.4.1.1.6.1.10 | Terminate HV Rack cables |  | 2.77d | 2012-08-21 | 2012-08-24 | 717 | 412.1d | 0d |  | Electrical Technician | 22.2h |  |
| 719 | 6.4.1.1.6.1.11 | Install Auxiliary Rack |  | 1.85d | 2012-08-24 | 2012-08-28 | 718 | 412.1d | 0d |  | Electrical Technician | 14.8h |  |
| 720 | 6.4.1.1.6.1.12 | Terminate Auxiliary Rack cables |  | 3.7d | 2012-08-28 | 2012-09-03 | 719 | 412.1d | 0d |  | Electrical Technician | 29.6h | 500 |
| 721 | 6.4.1.1.6.1.13 | Prepare 4616 Dummy Load |  | 9.25d | 2012-09-03 | 2012-09-14 | 720 | 412.1d | 0d |  | Electrical Technician; Electrical Engineer [25%] | 92.5h |  |
| 722 | 6.4.1.1.6.1.14 | Commission Electrical system |  | 4.62d | 2012-09-14 | 2012-09-21 | 721 | 412.1d | 0d |  | Electrical Engineer; Electrical Technician [25%] | 46.25h |  |
| 723 | 6.4.1.1.6.1.15 | Commission RF with Dummy Load |  | 4.62d | 2012-09-21 | 2012-09-27 | 722 | 412.1d | 0d |  | Electrical Engineer [25%] | 9.25h |  |

| ID | WBS | Task | Type | Duration | Start | Finish | Predecessors | Total slack | Free slack | Constraint | Resources | Work | Cost |
| --- | --- | --- | --- | --- | --- | --- | --- | --- | --- | --- | --- | --- | --- |
| 724 | 6.4.1.1.6.2 | **TH116 Amplifier system #3** |  | 58.27d | 2012-09-27 | 2012-12-18 |  | 378.1d |  |  |  | 703h | 4,000 |
| 725 | 6.4.1.1.6.2.1 | Design cable management |  | 1.85d | 2012-09-27 | 2012-10-01 | 723 | 412.1d | 0d |  | Electrical Engineer; Electrical Designer | 29.6h |  |
| 726 | 6.4.1.1.6.2.2 | Install cable management |  | 2.77d | 2012-10-01 | 2012-10-04 | 725 | 412.1d | 0d |  | Electrical Designer; Electrical Technician | 44.4h | 1,000 |
| 727 | 6.4.1.1.6.2.3 | Design AC distribution |  | 1.85d | 2012-10-04 | 2012-10-08 | 726 | 412.1d | 0d |  | Electrical Designer; Electrical Engineer | 29.6h |  |
| 728 | 6.4.1.1.6.2.4 | Install AC distribution |  | 4.62d | 2012-10-08 | 2012-10-12 | 727 | 412.1d | 0d |  | Electrical Technician; Electrical Designer | 74h | 1,000 |
| 729 | 6.4.1.1.6.2.5 | Produce cable schedules - controls interface |  | 9.25d | 2012-10-12 | 2012-10-26 | 728 | 412.1d | 0d |  | Electrical Designer; Electrical Engineer | 148h |  |
| 730 | 6.4.1.1.6.2.6 | Install controls cables |  | 9.25d | 2012-10-26 | 2012-11-08 | 729 | 412.1d | 0d |  | Electrical Designer; Electrical Technician | 148h | 1,500 |
| 731 | 6.4.1.1.6.2.7 | System #3 TH116 Racks ready | milestone | 0d | 2012-11-08 | 2012-11-08 | 730 | 412.1d | 0d | start no earlier than 2011-10-17 |  |  |  |
| 732 | 6.4.1.1.6.2.8 | Install HV Rack |  | 1.85d | 2012-11-08 | 2012-11-12 | 731 | 412.1d | 0d |  | Electrical Technician | 14.8h |  |
| 733 | 6.4.1.1.6.2.9 | Terminate HV Rack cables |  | 2.77d | 2012-11-12 | 2012-11-14 | 732 | 412.1d | 0d |  | Electrical Technician | 22.2h |  |
| 734 | 6.4.1.1.6.2.10 | Install Auxiliary Rack |  | 1.85d | 2012-11-14 | 2012-11-16 | 733 | 412.1d | 0d |  | Electrical Technician | 14.8h |  |
| 735 | 6.4.1.1.6.2.11 | Terminate Auxiliary Rack cables |  | 3.7d | 2012-11-16 | 2012-11-22 | 734 | 412.1d | 0d |  | Electrical Technician | 29.6h | 500 |
| 736 | 6.4.1.1.6.2.12 | Prepare TH116 Dummy Load |  | 9.25d | 2012-11-22 | 2012-12-05 | 735 | 412.1d | 0d |  | Electrical Technician; Electrical Engineer [25%] | 92.5h |  |
| 737 | 6.4.1.1.6.2.13 | Commission Electrical system |  | 4.62d | 2012-12-05 | 2012-12-12 | 736 | 412.1d | 0d |  | Electrical Engineer; Electrical Technician [25%] | 46.25h |  |
| 738 | 6.4.1.1.6.2.14 | Commission RF with Dummy Load |  | 4.62d | 2012-12-12 | 2012-12-18 | 737 | 412.1d | 0d |  | Electrical Engineer [25%] | 9.25h |  |
| 739 | 6.4.1.1.7 | **RF System #4 - Installation** |  | 441.9d | 2011-12-27 | 2013-09-04 |  | 378.1d |  |  |  | 1609.5h | 8,000 |
| 740 | 6.4.1.1.7.1 | **4616 Amplifier system #4** |  | 58.27d | 2012-12-18 | 2013-03-11 |  | 378.1d |  |  |  | 703h | 4,000 |
| 741 | 6.4.1.1.7.1.1 | RF System #4 Integration starts | milestone | 0d | 2012-12-18 | 2012-12-18 | 738 | 412.1d | 0d |  |  |  |  |
| 742 | 6.4.1.1.7.1.2 | Design cable management |  | 1.85d | 2012-12-18 | 2012-12-20 | 741 | 412.1d | 0d |  | Electrical Engineer; Electrical Designer | 29.6h |  |
| 743 | 6.4.1.1.7.1.3 | Install cable management |  | 2.77d | 2012-12-20 | 2012-12-25 | 742 | 412.1d | 0d |  | Electrical Designer; Electrical Technician | 44.4h | 1,000 |
| 744 | 6.4.1.1.7.1.4 | Design AC distribution |  | 1.85d | 2012-12-25 | 2012-12-27 | 743 | 412.1d | 0d |  | Electrical Designer; Electrical Engineer | 29.6h |  |
| 745 | 6.4.1.1.7.1.5 | Install AC distribution |  | 4.62d | 2012-12-27 | 2013-01-03 | 744 | 412.1d | 0d |  | Electrical Technician; Electrical Designer | 74h | 1,000 |
| 746 | 6.4.1.1.7.1.6 | Produce cable schedules - controls interface |  | 9.25d | 2013-01-03 | 2013-01-16 | 745 | 412.1d | 0d |  | Electrical Designer; Electrical Engineer | 148h |  |
| 747 | 6.4.1.1.7.1.7 | Install controls cables |  | 9.25d | 2013-01-16 | 2013-01-29 | 746 | 412.1d | 0d |  | Electrical Designer; Electrical Technician | 148h | 1,500 |
| 748 | 6.4.1.1.7.1.8 | System #4 4616 Racks ready | milestone | 0d | 2013-01-29 | 2013-01-29 | 747 | 412.1d | 0d | start no earlier than 2011-01-24 |  |  |  |
| 749 | 6.4.1.1.7.1.9 | Install HV Rack |  | 1.85d | 2013-01-29 | 2013-01-31 | 748 | 412.1d | 0d |  | Electrical Technician | 14.8h |  |
| 750 | 6.4.1.1.7.1.10 | Terminate HV Rack cables |  | 2.77d | 2013-01-31 | 2013-02-05 | 749 | 412.1d | 0d |  | Electrical Technician | 22.2h |  |
| 751 | 6.4.1.1.7.1.11 | Install Auxiliary Rack |  | 1.85d | 2013-02-05 | 2013-02-07 | 750 | 412.1d | 0d |  | Electrical Technician | 14.8h |  |
| 752 | 6.4.1.1.7.1.12 | Terminate Auxiliary Rack cables |  | 3.7d | 2013-02-07 | 2013-02-12 | 751 | 412.1d | 0d |  | Electrical Technician | 29.6h | 500 |
| 753 | 6.4.1.1.7.1.13 | Prepare 4616 Dummy Load |  | 9.25d | 2013-02-12 | 2013-02-25 | 752 | 412.1d | 0d |  | Electrical Technician; Electrical Engineer [25%] | 92.5h |  |
| 754 | 6.4.1.1.7.1.14 | Commission Electrical system |  | 4.62d | 2013-02-26 | 2013-03-04 | 753 | 412.1d | 0d |  | Electrical Engineer; Electrical Technician [25%] | 46.25h |  |
| 755 | 6.4.1.1.7.1.15 | Commission RF with Dummy Load |  | 4.62d | 2013-03-04 | 2013-03-11 | 754 | 412.1d | 0d |  | Electrical Engineer [25%] | 9.25h |  |

| ID | WBS | Task | Type | Duration | Start | Finish | Predecessors | Total slack | Free slack | Constraint | Resources | Work | Cost |
| --- | --- | --- | --- | --- | --- | --- | --- | --- | --- | --- | --- | --- | --- |
| 756 | 6.4.1.1.7.2 | **TH116 Amplifier system #4** |  | 372.52d | 2011-12-27 | 2013-05-30 |  | 447.48d |  |  |  | 703h | 4,000 |
| 757 | 6.4.1.1.7.2.1 | Design cable management |  | 1.85d | 2013-03-11 | 2013-03-13 | 755 | 412.1d | 0d |  | Electrical Engineer; Electrical Designer | 29.6h |  |
| 758 | 6.4.1.1.7.2.2 | Install cable management |  | 2.77d | 2013-03-13 | 2013-03-15 | 757 | 412.1d | 0d |  | Electrical Designer; Electrical Technician | 44.4h | 1,000 |
| 759 | 6.4.1.1.7.2.3 | Design AC distribution |  | 1.85d | 2013-03-15 | 2013-03-19 | 758 | 412.1d | 0d |  | Electrical Designer; Electrical Engineer | 29.6h |  |
| 760 | 6.4.1.1.7.2.4 | Install AC distribution |  | 4.62d | 2013-03-19 | 2013-03-26 | 759 | 412.1d | 0d |  | Electrical Technician; Electrical Designer | 74h | 1,000 |
| 761 | 6.4.1.1.7.2.5 | Produce cable schedules - controls interface |  | 9.25d | 2013-03-26 | 2013-04-08 | 760 | 412.1d | 0d |  | Electrical Designer; Electrical Engineer | 148h |  |
| 762 | 6.4.1.1.7.2.6 | Install controls cables |  | 9.25d | 2013-04-08 | 2013-04-19 | 761 | 412.1d | 0d |  | Electrical Designer; Electrical Technician | 148h | 1,500 |
| 763 | 6.4.1.1.7.2.7 | System #4 TH116 Racks ready | milestone | 0d | 2013-04-19 | 2013-04-19 | 762 | 412.1d | 0d | start no earlier than 2011-10-17 |  |  |  |
| 764 | 6.4.1.1.7.2.8 | Install HV Rack |  | 1.85d | 2013-04-19 | 2013-04-23 | 763 | 412.1d | 0d |  | Electrical Technician | 14.8h |  |
| 765 | 6.4.1.1.7.2.9 | Terminate HV Rack cables |  | 2.77d | 2013-04-23 | 2013-04-26 | 764 | 412.1d | 0d |  | Electrical Technician | 22.2h |  |
| 766 | 6.4.1.1.7.2.10 | Install Auxiliary Rack |  | 1.85d | 2013-04-26 | 2013-04-30 | 765 | 412.1d | 0d |  | Electrical Technician | 14.8h |  |
| 767 | 6.4.1.1.7.2.11 | Terminate Auxiliary Rack cables |  | 3.7d | 2013-04-30 | 2013-05-06 | 766 | 412.1d | 0d |  | Electrical Technician | 29.6h | 500 |
| 768 | 6.4.1.1.7.2.12 | Prepare TH116 Dummy Load |  | 9.25d | 2011-12-27 | 2012-01-09 | 670 | 844.75d |  |  | Electrical Technician; Electrical Engineer [25%] | 92.5h |  |
| 769 | 6.4.1.1.7.2.13 | Commission Electrical system |  | 4.62d | 2013-05-17 | 2013-05-23 | 779 | 412.1d | 0d |  | Electrical Engineer; Electrical Technician [25%] | 46.25h |  |
| 770 | 6.4.1.1.7.2.14 | Commission RF with Dummy Load |  | 4.62d | 2013-05-23 | 2013-05-30 | 769 | 412.1d | 0d |  | Electrical Engineer [25%] | 9.25h |  |
| 771 | 6.4.1.1.7.3 | **RF Waveguide -Systems #3&4** |  | 13.88d | 2013-05-30 | 2013-06-19 | 770 | 378.1d |  |  |  | 111h |  |
| 772 | 6.4.1.1.7.3.1 | Review waveguide controls interface |  | 9.25d | 2013-05-30 | 2013-06-12 |  | 412.1d | 0d | start no earlier than 2012-06-25 | Electrical Engineer | 74h |  |
| 773 | 6.4.1.1.7.3.2 | RF Waveguide Installation complete | milestone | 0d | 2013-06-12 | 2013-06-12 | 772 | 412.1d | 0d | finish no earlier than 2012-08-06 |  |  |  |
| 774 | 6.4.1.1.7.3.3 | Install Waveguide controls wiring |  | 4.62d | 2013-06-12 | 2013-06-19 | 773 | 412.1d | 0d |  | Electrical Technician | 37h |  |
| 775 | 6.4.1.1.7.4 | **RF Cavity Commissioning** |  | 87.88d | 2013-05-06 | 2013-09-04 |  | 378.1d |  |  |  | 92.5h |  |
| 776 | 6.4.1.1.7.4.1 | Cavity Delivered | milestone | 0d | 2013-06-19 | 2013-06-19 | 774 | 412.1d | 0d |  |  |  |  |
| 777 | 6.4.1.1.7.4.2 | Install and prepare cavity for tests |  | 18.5d | 2013-06-19 | 2013-07-15 | 776 | 412.1d | 0d |  |  |  |  |
| 778 | 6.4.1.1.7.4.3 | Commission RF system into Cavity |  | 37d | 2013-07-15 | 2013-09-04 | 777 | 412.1d |  |  |  |  |  |
| 779 | 6.4.1.1.7.4.4 | Prepare TH116 Dummy Load |  | 9.25d | 2013-05-06 | 2013-05-17 | 767 | 412.1d | 0d |  | Electrical Technician; Electrical Engineer [25%] | 92.5h |  |

| ID | WBS | Task | Type | Duration | Start | Finish | Predecessors | Total slack | Free slack | Constraint | Resources | Work |
| --- | --- | --- | --- | --- | --- | --- | --- | --- | --- | --- | --- | --- |
| 780 | 6.4.1.2 | **RF Hall Mechanical Infrastructure** |  | 15d | 2011-03-01 | 2011-03-21 |  | 916d |  |  |  |  |
| 781 | 6.4.1.2.1 | Install mezzanine/supports/floor plates |  | 15d | 2011-03-01 | 2011-03-21 |  | 950d | 51d | start no earlier than 2011-03-01 |  |  |
| 782 | 6.4.2 | **Amplifiers** |  | 326d | 2011-06-01 | 2012-11-16 |  | 549d |  |  |  | 160h |
| 783 | 6.4.2.1 | **System #1** |  | 10d | 2011-06-01 | 2011-06-14 |  | 865d |  |  | STEP V - TIARA | 80h |
| 784 | 6.4.2.1.1 | Install amplfiier in position on platform |  | 10d | 2011-06-01 | 2011-06-14 | 781, 86 | 899d | 0d | start no earlier than 2011-06-01 |  |  |
| 785 | 6.4.2.1.2 | Amplfier#1 installation complete | milestone | 0d | 2011-06-14 | 2011-06-14 | 784 | 899d | 0d |  |  |  |
| 786 | 6.4.2.2 | **System #2** |  | 10d | 2012-01-18 | 2012-01-31 |  | 757d |  |  | STEP V - TIARA | 80h |
| 787 | 6.4.2.2.1 | Install amplfiier in position on platform |  | 10d | 2012-01-18 | 2012-01-31 | 89 | 791d | 0d |  |  |  |
| 788 | 6.4.2.2.2 | Amplfier#2 installation complete | milestone | 0d | 2012-01-31 | 2012-01-31 | 787 | 791d | 0d |  |  |  |
| 789 | 6.4.2.3 | **System #3** |  | 10d | 2012-07-02 | 2012-07-13 |  | 639d |  |  |  |  |
| 790 | 6.4.2.3.1 | Install amplfiier in position on platform |  | 10d | 2012-07-02 | 2012-07-13 | 92 | 673d | 0d |  |  |  |
| 791 | 6.4.2.3.2 | Amplfier#3 installation complete | milestone | 0d | 2012-07-13 | 2012-07-13 | 790 | 673d | 0d |  |  |  |
| 792 | 6.4.2.4 | **System #4** |  | 10d | 2012-11-05 | 2012-11-16 |  | 549d |  |  |  |  |
| 793 | 6.4.2.4.1 | Install amplfiier in position on platform |  | 10d | 2012-11-05 | 2012-11-16 | 95 | 583d | 0d |  |  |  |
| 794 | 6.4.2.4.2 | Amplfier#4 installation complete | milestone | 0d | 2012-11-16 | 2012-11-16 | 793 | 583d | 0d |  |  |  |
| 795 | 6.4.3 | **Waveguides** |  | 468d | 2011-12-23 | 2013-10-08 |  | 388d |  |  |  | 3744h |
| 796 | 6.4.3.1 | **System#1** |  | 468d | 2011-12-23 | 2013-10-08 |  | 388d |  |  | STEP V - TIARA | 3744h |
| 797 | 6.4.3.1.1 | Install waveguides |  | 5d | 2011-12-23 | 2011-12-29 | 99 | 846d | 0d |  |  |  |
| 798 | 6.4.3.1.2 | install dummy loads |  | 5d | 2011-12-30 | 2012-01-05 | 797 | 846d |  |  |  |  |
| 799 | 6.4.3.1.3 | couple up to cavity |  | 2d | 2013-10-07 | 2013-10-08 | 940 | 388d |  |  |  |  |
| 800 | 6.4.3.2 | **System#2** |  | 468d | 2011-12-23 | 2013-10-08 |  | 388d |  |  |  |  |
| 801 | 6.4.3.2.1 | Install all waveguides |  | 5d | 2011-12-23 | 2011-12-29 | 102 | 846d | 0d |  |  |  |
| 802 | 6.4.3.2.2 | install dummy loads |  | 5d | 2011-12-30 | 2012-01-05 | 801 | 846d |  |  |  |  |
| 803 | 6.4.3.2.3 | couple up to cavity |  | 2d | 2013-10-07 | 2013-10-08 | 940 | 388d |  |  |  |  |

| ID | WBS | Task | Duration | Start | Finish | Predecessors | Complete | Remaining | Baseline start | Baseline finish | Baseline duration | Total slack | Free slack | Constraint | Resources | Work | Actual work | Cost | Actual cost |
| --- | --- | --- | --- | --- | --- | --- | --- | --- | --- | --- | --- | --- | --- | --- | --- | --- | --- | --- | --- |
| 804 | 6.5 | **MICE Step IV Installation** | 393d | 2011-01-17 A | 2012-10-05 |  | 22% | 305.5d |  |  |  | 650d |  |  | Step IV | 3144h | 700.03h | 26,000 | 6,000 |
| 805 | 6.5.1 | **Step IV Base plate installation** | 135d | 2011-01-17 A | 2011-09-01 |  | 68% | 43.39d |  |  |  | 908d |  |  |  |  |  | 26,000 | 6,000 |
| 806 | 6.5.1.1 | Update MICE hall CAD model with new floor configuration | 40d | 2011-01-17 A | 2011-03-11 A |  | 100% |  |  |  |  |  |  | start no earlier than 2011-01-17 |  |  |  |  |  |
| 807 | 6.5.1.2 | Manufacture Al intermediate plates for the false floor | 15d | 2011-03-14 A | 2011-04-01 A | 806 | 100% |  |  |  |  |  |  | start no earlier than 2011-02-21 |  |  |  | 6,000 | 6,000 |
| 808 | 6.5.1.3 | Fit intermediate surface (tiled Aluminium plates) for the false floor step IV position | 2d | 2011-04-04 A | 2011-04-05 A | 807 | 100% |  |  |  |  |  |  | start no earlier than 2011-01-19 |  |  |  |  |  |
| 809 | 6.5.1.4 | Carry out any remedial work to existing concrete floor | 2d | 2011-04-06 | 2011-04-07 | 808 |  |  |  |  |  | 959d | 51d | start no earlier than 2011-01-20 |  |  |  | 500 |  |
| 810 | 6.5.1.5 | Trial AFC base plate Installation including survey and marking out (on and off line) | 5d | 2011-06-20 | 2011-06-24 | 809, 125 |  |  |  |  |  | 908d | 0d | start no earlier than 2011-01-20 |  |  |  | 2,500 |  |
| 811 | 6.5.1.6 | Carry out anchor hole drilling in the concrete for the AFC | 5d | 2011-06-27 | 2011-07-01 | 810 |  |  |  |  |  | 908d | 0d |  |  |  |  | 3,000 |  |
| 812 | 6.5.1.7 | Replace AFC base plate anchor and grout (on and off line?) | 2d | 2011-07-04 | 2011-08-15 | 811 |  |  |  |  |  | 908d | 0d | start no earlier than 2011-02-09 |  |  |  | 4,000 |  |
| 813 | 6.5.1.8 | Trial spectrometer #2 base plate Installation including survey and marking out (on and off line) | 2d | 2011-08-16 | 2011-08-17 | 812 |  |  |  |  |  | 908d | 0d | start no earlier than 2011-02-09 |  |  |  | 3,000 |  |
| 814 | 6.5.1.9 | Anchor hole drilling in concrete floor and false floor plates (on and off line) | 5d | 2011-08-18 | 2011-08-24 | 813 |  |  |  |  |  | 908d | 0d | start no earlier than 2011-02-09 |  |  |  | 4,000 |  |
| 815 | 6.5.1.10 | Create level surface with washers at bolt locations (survey level) | 2d | 2011-08-25 | 2011-08-26 | 814 |  |  |  |  |  | 908d | 0d | start no earlier than 2011-02-09 |  |  |  | 2,000 |  |
| 816 | 6.5.1.11 | Re-Install spectrometer #2 base plates (on and off line) | 2d | 2011-08-29 | 2011-08-30 | 815 |  |  |  |  |  | 908d | 0d | start no earlier than 2011-02-09 |  |  |  |  |  |
| 817 | 6.5.1.12 | Install through bolts and survey, level and tighten the complete arrangement | 2d | 2011-08-31 | 2011-09-01 | 816 |  |  |  |  |  | 908d | 0d | start no earlier than 2011-02-09 |  |  |  | 1,000 |  |
| 818 | 6.5.2 | Spectrometer Solenoid # 1 Installation | 15d | 2012-04-10 | 2012-04-30 | 107FS+10d |  |  |  |  |  | 7d | 0d | start no earlier than 2012-01-16 |  |  |  |  |  |
| 819 | 6.5.3 | **Tracker #1 Installation** | 49d | 2012-05-01 | 2012-07-06 | 818 |  |  |  |  |  | 715d |  |  |  |  |  |  |  |
| 820 | 6.5.3.1 | Clear area for tracker installation | 1d | 2012-05-01 | 2012-05-01 |  |  |  | 2009-08-11 | 2009-08-13 | 3d? | 715d | 0d | start no earlier than 2009-05-25 |  |  |  |  |  |
| 821 | 6.5.3.2 | Move Spectrometer Solenoid into parked position | 1d | 2012-05-02 | 2012-05-02 | 820 |  |  |  |  |  | 715d | 0d |  |  |  |  |  |  |
| 822 | 6.5.3.3 | Fit and seal patch panel to the solenoid front plate | 1d | 2012-05-03 | 2012-05-03 | 821 |  |  | 2009-08-14 | 2009-08-17 | 2d | 715d | 0d |  |  |  |  |  |  |
| 823 | 6.5.3.4 | Survey the bore of the solenoid using the tracker alignment tools | 2d | 2012-05-04 | 2012-05-07 | 822 |  |  | 2009-08-18 | 2009-08-24 | 5d? | 715d | 0d | start no earlier than 2009-05-25 |  |  |  |  |  |
| 824 | 6.5.3.5 | Fit the far hall probes collar into the bore | 1d | 2012-05-08 | 2012-05-08 | 823 |  |  | 2009-08-25 | 2009-08-31 | 5d? | 715d | 0d | start no earlier than 2009-06-01 |  |  |  |  |  |
| 825 | 6.5.3.6 | Fit the helium window | 1d | 2012-05-09 | 2012-05-09 | 824 |  |  | 2009-09-01 | 2009-09-01 | 1d? | 715d | 0d |  |  |  |  |  |  |
| 826 | 6.5.3.7 | Connect the tracker volume helium supply | 1d | 2012-05-10 | 2012-05-10 | 825 |  |  | 2009-09-02 | 2009-09-08 | 5d | 715d | 0d |  |  |  |  |  |  |
| 827 | 6.5.3.8 | Erect blockout tent | 1d | 2012-05-11 | 2012-05-11 | 826 |  |  | 2009-09-09 | 2009-09-10 | 2d | 715d | 0d |  |  |  |  |  |  |
| 828 | 6.5.3.9 | Fit yellow lighting inside the tent | 1d | 2012-05-14 | 2012-05-14 | 827 |  |  | 2009-09-11 | 2009-09-16 | 4d? | 715d | 0d | start no earlier than 2009-06-09 |  |  |  |  |  |
| 829 | 6.5.3.10 | install the tracker installation platform inside the tent | 1d | 2012-05-15 | 2012-05-15 | 828 |  |  |  |  |  | 715d | 0d |  |  |  |  |  |  |
| 830 | 6.5.3.11 | Install the tracker replacing any faulty internal waveguides | 5d | 2012-05-16 | 2012-05-22 | 829 |  |  |  |  |  | 715d | 0d |  |  |  |  |  |  |
| 831 | 6.5.3.12 | Fit and seal the patch panel cover plus crown for diffuser | 1d | 2012-05-23 | 2012-05-23 | 830 |  |  |  |  |  | 715d | 0d |  |  |  |  |  |  |
| 832 | 6.5.3.13 | Remove the blackout tent | 1d | 2012-05-24 | 2012-05-24 | 831 |  |  |  |  |  | 715d | 0d |  |  |  |  |  |  |
| 833 | 6.5.3.14 | Position and fit the VLPC and Cryo-coolers onto the rolling platform | 5d | 2012-05-25 | 2012-05-31 | 832 |  |  |  |  |  | 715d | 0d |  |  |  |  |  |  |
| 834 | 6.5.3.15 | Position and fit the services required fir the Cryo-coolers | 5d | 2012-06-01 | 2012-06-07 | 833 |  |  |  |  |  | 715d | 0d |  |  |  |  |  |  |
| 835 | 6.5.3.16 | Errect the trellis to support the external waveguides | 3d | 2012-06-08 | 2012-06-12 | 834 |  |  |  |  |  | 715d | 0d |  |  |  |  |  |  |
| 836 | 6.5.3.17 | Fit the external waveguides | 2d | 2012-06-13 | 2012-06-14 | 835 |  |  |  |  |  | 715d | 0d |  |  |  |  |  |  |
| 837 | 6.5.3.18 | Set up micetkpc1 (server PC for AFEllts & cryo system) | 2d | 2012-06-15 | 2012-06-18 | 836 |  |  |  |  |  | 715d | 0d |  |  |  |  |  |  |
| 838 | 6.5.3.19 | AFEllt trigger distribution | 3d | 2012-06-19 | 2012-06-21 | 837 |  |  |  |  |  | 715d | 0d |  |  |  |  |  |  |
| 839 | 6.5.3.20 | Prepare 3 phase & chilled water for compressors (cold head) | 1d | 2012-06-22 | 2012-06-22 | 838 |  |  |  |  |  | 715d | 0d |  |  |  |  |  |  |
| 840 | 6.5.3.21 | Install compressors | 2d | 2012-06-25 | 2012-06-26 | 839 |  |  |  |  |  | 715d | 0d |  |  |  |  |  |  |
| 841 | 6.5.3.22 | Install cryo insulating vacuum pump sets | 1d | 2012-06-27 | 2012-06-27 | 840 |  |  |  |  |  | 715d | 0d |  |  |  |  |  |  |
| 842 | 6.5.3.23 | Move and position tracker rack | 1d | 2012-06-28 | 2012-06-28 | 841 |  |  |  |  |  | 715d | 0d |  |  |  |  |  |  |
| 843 | 6.5.3.24 | Connect network, electrical & He services for tracker rack | 2d | 2012-06-29 | 2012-07-02 | 842 |  |  |  |  |  | 715d | 0d |  |  |  |  |  |  |
| 844 | 6.5.3.25 | Integration & testing of tracker safety interlocks | 4d | 2012-07-03 | 2012-07-06 | 843 |  |  |  |  |  | 715d | 0d |  |  |  |  |  |  |

| ID | WBS | Task | Type | Duration | Start | Finish | Predecessors | Baseline start | Baseline finish | Baseline duration | Total slack | Free slack | Constraint |
| --- | --- | --- | --- | --- | --- | --- | --- | --- | --- | --- | --- | --- | --- |
| 845 | 6.5.4 | **AFC #1 LiH2 Absorber installation** |  | 52d | 2012-04-09 | 2012-06-19 |  |  |  |  | 7d | 0d |  |
| 846 | 6.5.4.1 | Move AFC #1 into parked position |  | 1d | 2012-04-09 | 2012-04-09 | 630, 818SS-1d |  |  |  | 22d | 15d |  |
| 847 | 6.5.4.2 | Remove AFC outer vacuum windows |  | 1d | 2012-05-01 | 2012-05-01 | 846, 818 |  |  |  | 7d | 0d |  |
| 848 | 6.5.4.3 | Insert absorber and fit mountings |  | 3d | 2012-05-02 | 2012-05-04 | 847 |  |  |  | 7d | 0d |  |
| 849 | 6.5.4.4 | Make gas connections |  | 1d | 2012-05-07 | 2012-05-07 | 848 |  |  |  | 7d | 0d |  |
| 850 | 6.5.4.5 | Make electrical connections |  | 2d | 2012-05-08 | 2012-05-09 | 849 |  |  |  | 7d | 0d |  |
| 851 | 6.5.4.6 | Re-fit outer vacuum windows and fit bellows |  | 2d | 2012-05-10 | 2012-05-11 | 850 |  |  |  | 7d | 0d |  |
| 852 | 6.5.4.7 | Return module to beamline position |  | 1d | 2012-05-14 | 2012-05-14 | 851 |  |  |  | 7d | 0d |  |
| 853 | 6.5.4.8 | Connect H2 transfer line, crycooler lines and vacuum/relief line |  | 1d | 2012-05-15 | 2012-05-15 | 852 |  |  |  | 7d | 0d |  |
| 854 | 6.5.4.9 | Pump down vacuum spaces |  | 3d | 2012-05-16 | 2012-05-18 | 853 |  |  |  | 7d | 0d |  |
| 855 | 6.5.4.10 | Leak check vacuum spaces |  | 1d | 2012-05-21 | 2012-05-21 | 854 |  |  |  | 7d | 0d |  |
| 856 | 6.5.4.11 | Leak check cryocooler circuit |  | 1d | 2012-05-22 | 2012-05-22 | 855 |  |  |  | 7d | 0d |  |
| 857 | 6.5.4.12 | Cool down of magnet and absorber |  | 10d | 2012-05-23 | 2012-06-05 | 856 |  |  |  | 7d | 0d |  |
| 858 | 6.5.4.13 | LiH2 Absorber test period |  | 10d | 2012-06-06 | 2012-06-19 | 857 |  |  |  | 7d | 0d |  |
| 859 | 6.5.5 | Reposition spectrometer #1 and align |  | 3d | 2012-06-20 | 2012-06-22 | 858 | 2010-05-26 | 2010-05-27 | 2d | 7d | 0d |  |
| 860 | 6.5.6 | Spectrometer Solenoid # 2 Installation |  | 15d | 2012-07-04 | 2012-07-24 | 859, 111 | 2010-05-28 | 2010-05-31 | 2d | 0d |  |  |
| 861 | 6.5.7 | **Tracker #2 Installation** |  | 48d | 2012-07-25 | 2012-09-28 |  |  |  |  | 0d |  |  |
| 862 | 6.5.7.1 | Clear area for tracker installation |  | 1d | 2012-07-25 | 2012-07-25 | 860 | 2009-08-11 | 2009-08-13 | 3d? | 0d |  | start no earlier than 2009-05-25 |
| 863 | 6.5.7.2 | Fit and seal patch panel to the solenoid front plate |  | 1d | 2012-07-26 | 2012-07-26 | 862 | 2009-08-14 | 2009-08-17 | 2d | 0d |  |  |
| 864 | 6.5.7.3 | Survey the bore of the solenoid using the tracker alignment tools |  | 2d | 2012-07-27 | 2012-07-30 | 863 | 2009-08-18 | 2009-08-24 | 5d? | 0d |  | start no earlier than 2009-05-25 |
| 865 | 6.5.7.4 | Fit the far hall probes on their collar |  | 1d | 2012-07-31 | 2012-07-31 | 864 | 2009-08-25 | 2009-08-31 | 5d? | 0d |  | start no earlier than 2009-06-01 |
| 866 | 6.5.7.5 | Fit the helium window |  | 1d | 2012-08-01 | 2012-08-01 | 865 | 2009-09-01 | 2009-09-01 | 1d? | 0d |  |  |
| 867 | 6.5.7.6 | Connect the tracker volume helium supply |  | 1d | 2012-08-02 | 2012-08-02 | 866 | 2009-09-02 | 2009-09-08 | 5d | 0d |  |  |
| 868 | 6.5.7.7 | Erect blockout tent |  | 1d | 2012-08-03 | 2012-08-03 | 867 | 2009-09-09 | 2009-09-10 | 2d | 0d |  |  |
| 869 | 6.5.7.8 | Fit yellow lighting inside the tent |  | 1d | 2012-08-06 | 2012-08-06 | 868 | 2009-09-11 | 2009-09-16 | 4d? | 0d |  | start no earlier than 2009-06-09 |
| 870 | 6.5.7.9 | install the tracker installation platform inside the tent |  | 1d | 2012-08-07 | 2012-08-07 | 869 |  |  |  | 0d |  |  |
| 871 | 6.5.7.10 | Install the tracker replacing any faulty waveguides |  | 5d | 2012-08-08 | 2012-08-14 | 870 |  |  |  | 0d |  |  |
| 872 | 6.5.7.11 | Fit and seal the patch panel cover plus bulkhead connector covers |  | 1d | 2012-08-15 | 2012-08-15 | 871 |  |  |  | 0d |  |  |
| 873 | 6.5.7.12 | Remove the blackout tent |  | 1d | 2012-08-16 | 2012-08-16 | 872 |  |  |  | 0d |  |  |
| 874 | 6.5.7.13 | Position and fit the VLPC and Cryo-coolers onto the rolling platform |  | 5d | 2012-08-17 | 2012-08-23 | 873 |  |  |  | 0d |  |  |
| 875 | 6.5.7.14 | Position and fit the services required fir the Cryo-coolers |  | 5d | 2012-08-24 | 2012-08-30 | 874 |  |  |  | 0d |  |  |
| 876 | 6.5.7.15 | Errect the trellis to support the external waveguides |  | 3d | 2012-08-31 | 2012-09-04 | 875 |  |  |  | 0d |  |  |
| 877 | 6.5.7.16 | Fit the external waveguides |  | 2d | 2012-09-05 | 2012-09-06 | 876 |  |  |  | 0d |  |  |
| 878 | 6.5.7.17 | Set up micetkpc1 (server PC for AFEllts & cryo system) |  | 2d | 2012-09-07 | 2012-09-10 | 877 |  |  |  | 0d |  |  |
| 879 | 6.5.7.18 | AFEllt trigger distribution |  | 3d | 2012-09-11 | 2012-09-13 | 878 |  |  |  | 0d |  |  |
| 880 | 6.5.7.19 | Prepare 3 phase & chilled water for compressors (cold head) |  | 1d | 2012-09-14 | 2012-09-14 | 879 |  |  |  | 0d |  |  |
| 881 | 6.5.7.20 | Install compressors |  | 2d | 2012-09-17 | 2012-09-18 | 880 |  |  |  | 0d |  |  |
| 882 | 6.5.7.21 | Install cryo insulating vacuum pump sets |  | 1d | 2012-09-19 | 2012-09-19 | 881 |  |  |  | 0d |  |  |
| 883 | 6.5.7.22 | Move and position tracker rack |  | 1d | 2012-09-20 | 2012-09-20 | 882 |  |  |  | 0d |  |  |
| 884 | 6.5.7.23 | Connect network, electrical & He services for tracker rack |  | 2d | 2012-09-21 | 2012-09-24 | 883 |  |  |  | 0d |  |  |
| 885 | 6.5.7.24 | Integration & testing of tracker safety interlocks |  | 4d | 2012-09-25 | 2012-09-28 | 884 |  |  |  | 0d |  |  |
| 886 | 6.5.8 | Re-install TOF2, KL & EMR |  | 5d | 2012-10-01 | 2012-10-05 | 861 | 2010-06-01 | 2010-06-14 | 10d? | 0d |  | finish no earlier than 2010-03-12 |
| 887 | 6.5.9 | MICE step IV installation complete | milestone | 0d | 2012-10-05 | 2012-10-05 | 886 | 2010-06-15 | 2010-06-15 | 0d | 0d |  |  |

Notes:
- 847: Due to congestion in the area. Solenoid to be installed before any more work is carried out on AFC.

| ID | WBS | Task | Type | Duration | Start | Finish | Predecessors | Baseline start | Baseline finish | Baseline duration | Total slack | Constraint | Resources | Work | Cost |
| --- | --- | --- | --- | --- | --- | --- | --- | --- | --- | --- | --- | --- | --- | --- | --- |
| 888 | 6.6 | **MICE Step V Installation** |  | 265d | 2012-12-03 | 2013-12-06 |  | 2009-11-02 | 2011-05-02 | 391d? | 0d |  | Step V | 2120h | 27,000 |
| 889 | 6.6.1 | Remove TOF1 & KL & EMR |  | 2d | 2012-12-03 | 2012-12-04 | 1060 | 2010-08-09 | 2010-08-13 | 5d? | 0d |  |  |  |  |
| 890 | 6.6.2 | Move spectrometer #1 to parked position |  | 2d | 2012-12-05 | 2012-12-06 | 889 |  |  |  | 0d |  |  |  |  |
| 891 | 6.6.3 | Move AFC to parked position |  | 1d | 2012-12-07 | 2012-12-07 | 890 |  |  |  | 0d |  |  |  |  |
| 892 | 6.6.4 | Remove spectrometer #2 |  | 1d | 2012-12-10 | 2012-12-10 | 891 |  |  |  | 0d |  |  |  |  |
| 893 | 6.6.5 | **Step V Base plate installation** |  | 79d | 2012-12-11 | 2013-04-01 |  |  |  |  | 0d |  |  |  | 27,000 |
| 894 | 6.6.5.1 | Procure steel plates for the false floor intermediate surface | milestone | 0d | 2013-04-01 | 2013-04-01 |  |  |  |  | 525d | start no earlier than 2013-04-01 |  |  | 14,000 |
| 895 | 6.6.5.2 | Remove step IV false floor plates |  | 2d | 2012-12-11 | 2012-12-12 | 892 |  |  |  | 0d |  |  |  |  |
| 896 | 6.6.5.3 | Begin drilling and tapping holes in the false floor suffcient for step V |  | 8d | 2012-12-13 | 2012-12-24 | 895 |  |  |  | 0d |  |  |  |  |
| 897 | 6.6.5.4 | Fit intermediate surface (tiled steel plates) for the false floor step V position |  | 5d | 2012-12-25 | 2012-12-31 | 896 |  |  |  | 0d |  |  |  |  |
| 898 | 6.6.5.5 | Trial RFCC #1 base plate Installation including survey and marking out |  | 2d | 2013-01-01 | 2013-01-02 | 897 |  |  |  | 0d |  |  |  | 2,000 |
| 899 | 6.6.5.6 | Drill and tap threaded holes in the false floor intermediate surface |  | 3d | 2013-01-03 | 2013-01-07 | 898 |  |  |  | 0d |  |  |  |  |
| 900 | 6.6.5.7 | Create level surface with washers at bolt locations (survey level) |  | 5d | 2013-01-08 | 2013-01-14 | 899 |  |  |  | 0d |  |  |  | 2,000 |
| 901 | 6.6.5.8 | Re-Install base plate |  | 2d | 2013-01-15 | 2013-01-16 | 900 |  |  |  | 0d |  |  |  |  |
| 902 | 6.6.5.9 | Install through bolts and survey, level and tighten the complete arrangement |  | 3d | 2013-01-17 | 2013-01-21 | 901 |  |  |  | 0d |  |  |  |  |
| 903 | 6.6.5.10 | Trial AFC #2 base plate installation including survey and marking out |  | 3d | 2013-01-22 | 2013-01-24 | 902 |  |  |  | 0d |  |  |  | 2,000 |
| 904 | 6.6.5.11 | Drill and tap threaded holes in the false floor intermediate surface |  | 3d | 2013-01-25 | 2013-01-29 | 903 |  |  |  | 0d |  |  |  |  |
| 905 | 6.6.5.12 | Create level surface with washers at bolt locations (survey level) |  | 2d | 2013-01-30 | 2013-01-31 | 904 |  |  |  | 0d |  |  |  | 2,000 |
| 906 | 6.6.5.13 | Re-Install base plate |  | 2d | 2013-02-01 | 2013-02-04 | 905 |  |  |  | 0d |  |  |  |  |
| 907 | 6.6.5.14 | Install through bolts and survey, level and tighten the complete arrangement |  | 2d | 2013-02-05 | 2013-02-06 | 906 |  |  |  | 0d |  |  |  | 2,000 |
| 908 | 6.6.5.15 | Trial spectrometer #2 base plate Installation including survey and marking out |  | 3d | 2013-02-07 | 2013-02-11 | 907 |  |  |  | 0d |  |  |  |  |
| 909 | 6.6.5.16 | Drill and tap threaded holes in the false floor intermediate surface |  | 3d | 2013-02-12 | 2013-02-14 | 908 |  |  |  | 0d |  |  |  |  |
| 910 | 6.6.5.17 | Create level surface with washers at bolt locations (survey level) |  | 3d | 2013-02-15 | 2013-02-19 | 909 |  |  |  | 0d |  |  |  | 2,000 |
| 911 | 6.6.5.18 | Re-Install base plate |  | 2d | 2013-02-20 | 2013-02-21 | 910 |  |  |  | 0d |  |  |  |  |
| 912 | 6.6.5.19 | Install through bolts and survey, level and tighten the complete arrangement |  | 3d | 2013-02-22 | 2013-02-26 | 911 |  |  |  | 0d |  |  |  | 1,000 |

| ID | WBS | Task | Type | Duration | Start | Finish | Predecessors | Baseline start | Baseline finish | Baseline duration | Total slack | Constraint |
| --- | --- | --- | --- | --- | --- | --- | --- | --- | --- | --- | --- | --- |
| 913 | 6.6.6 | **AFC #2 Installation** |  | 91d | 2013-02-27 | 2013-07-03 |  | 2009-12-01 | 2011-03-31 | 348d? | 0d |  |
| 914 | 6.6.6.1 | Install AFC #2 rail system |  | 2d | 2013-02-27 | 2013-02-28 | 912 |  |  |  | 0d |  |
| 915 | 6.6.6.2 | Install AFC #2supports to floor |  | 2d | 2013-03-01 | 2013-03-04 | 914 | 2010-02-22 | 2010-02-26 | 5d | 0d | finish no earlier than 2010-02-26 |
| 916 | 6.6.6.3 | Install AFC #2 module and align |  | 5d | 2013-03-05 | 2013-03-11 | 915 | 2010-04-09 | 2010-04-12 | 2d | 0d | start no earlier than 2010-03-01 |
| 917 | 6.6.6.4 | Cooldown AFC #2 |  | 20d | 2013-03-12 | 2013-04-08 | 916 |  |  |  | 0d |  |
| 918 | 6.6.6.5 | AFC magnet test period |  | 20d | 2013-04-09 | 2013-05-06 | 917 | 2010-04-26 | 2010-05-21 | 20d | 0d | start no earlier than 2010-04-26 |
| 919 | 6.6.6.6 | Connect R&D LH2 system |  | 5d | 2013-05-07 | 2013-05-13 | 918 | 2010-05-24 | 2010-05-25 | 2d | 0d |  |
| 920 | 6.6.6.7 | **AFC #2 LiH2 Absorber installation** |  | 37d | 2013-05-14 | 2013-07-03 |  |  |  |  | 0d |  |
| 921 | 6.6.6.7.1 | Movel AFC #2 into parked position |  | 1d | 2013-05-14 | 2013-05-14 | 919 |  |  |  | 0d |  |
| 922 | 6.6.6.7.2 | Remove AFC outer vacuum windows |  | 1d | 2013-05-15 | 2013-05-15 | 921 |  |  |  | 0d |  |
| 923 | 6.6.6.7.3 | Insert absorber and fit mountings |  | 3d | 2013-05-16 | 2013-05-20 | 922 |  |  |  | 0d |  |
| 924 | 6.6.6.7.4 | Make gas connections |  | 1d | 2013-05-21 | 2013-05-21 | 923 |  |  |  | 0d |  |
| 925 | 6.6.6.7.5 | Make electrical connections |  | 2d | 2013-05-22 | 2013-05-23 | 924 |  |  |  | 0d |  |
| 926 | 6.6.6.7.6 | Re-fit outer vacuum windows and fit bellows |  | 2d | 2013-05-24 | 2013-05-27 | 925 |  |  |  | 0d |  |
| 927 | 6.6.6.7.7 | Return module to beamline position |  | 1d | 2013-05-28 | 2013-05-28 | 926 |  |  |  | 0d |  |
| 928 | 6.6.6.7.8 | Connect H2 transfer line, crycooler lines and vacuum/relief line |  | 1d | 2013-05-29 | 2013-05-29 | 927 |  |  |  | 0d |  |
| 929 | 6.6.6.7.9 | Pump down vacuum spaces |  | 3d | 2013-05-30 | 2013-06-03 | 928 |  |  |  | 0d |  |
| 930 | 6.6.6.7.10 | Leak check vacuum spaces |  | 1d | 2013-06-04 | 2013-06-04 | 929 |  |  |  | 0d |  |
| 931 | 6.6.6.7.11 | Leak check cryocooler circuit |  | 1d | 2013-06-05 | 2013-06-05 | 930 |  |  |  | 0d |  |
| 932 | 6.6.6.7.12 | Cool down of magnet and absorber |  | 10d | 2013-06-06 | 2013-06-19 | 931 |  |  |  | 0d |  |
| 933 | 6.6.6.7.13 | LiH2 Absorber test period |  | 10d | 2013-06-20 | 2013-07-03 | 932 |  |  |  | 0d |  |
| 934 | 6.6.7 | **RFCC #1 Installation** |  | 92d | 2013-07-04 | 2013-11-08 |  |  |  |  | 0d |  |
| 935 | 6.6.7.1 | Install RFFC rail system |  | 2d | 2013-07-04 | 2013-07-05 | 933 |  |  |  | 0d |  |
| 936 | 6.6.7.2 | Install RFFC supports to floor |  | 5d | 2013-07-08 | 2013-07-12 | 935 | 2010-02-22 | 2010-02-26 | 5d | 0d | finish no earlier than 2010-02-26 |
| 937 | 6.6.7.3 | Install RFFC module #1 and align |  | 5d | 2013-07-15 | 2013-07-19 | 936 | 2010-04-09 | 2010-04-12 | 2d | 0d | start no earlier than 2010-03-01 |
| 938 | 6.6.7.4 | Cooldown RFFC #1 |  | 20d | 2013-07-22 | 2013-08-16 | 937 |  |  |  | 0d |  |
| 939 | 6.6.7.5 | RFFC magnet test period |  | 20d | 2013-08-19 | 2013-09-13 | 938 | 2010-04-26 | 2010-05-21 | 20d | 0d | start no earlier than 2010-04-26 |
| 940 | 6.6.7.6 | Connect RF wave guides |  | 15d | 2013-09-16 | 2013-10-04 | 939 | 2010-05-24 | 2010-05-25 | 2d | 0d |  |
| 941 | 6.6.7.7 | RF Amplifier test period |  | 10d | 2013-10-07 | 2013-10-18 | 940 |  |  |  | 0d |  |
| 942 | 6.6.7.8 | RFFC test period |  | 15d | 2013-10-21 | 2013-11-08 | 941 |  |  |  | 0d |  |
| 943 | 6.6.8 | Spectrometer Solenoid #2 installation |  | 15d | 2013-11-11 | 2013-11-29 | 942 |  |  |  | 0d |  |
| 944 | 6.6.9 | Re-install TOF2, KL & EMR |  | 5d | 2013-12-02 | 2013-12-06 | 943 | 2010-06-01 | 2010-06-14 | 10d? | 0d | finish no earlier than 2010-03-12 |
| 945 | 6.6.10 | MICE step V installation complete | milestone | 0d | 2013-12-06 | 2013-12-06 | 944 | 2010-06-15 | 2010-06-15 | 0d | 0d | start no earlier than 2010-05-07 |

| ID | WBS | Task | Type | Duration | Start | Finish | Predecessors | Baseline start | Baseline finish | Baseline duration | Total slack | Constraint | Resources | Work | Cost |
| --- | --- | --- | --- | --- | --- | --- | --- | --- | --- | --- | --- | --- | --- | --- | --- |
| 946 | 6.7 | **MICE Step VI Installation** |  | 265d | 2014-02-03 | 2015-02-06 |  |  |  |  | 0d |  | Step VI | 2120h | 27,000 |
| 947 | 6.7.1 | Remove TOF1 & KL & EMR |  | 2d | 2014-02-03 | 2014-02-04 | 1063 | 2010-08-09 | 2010-08-13 | 5d? | 0d | start no earlier than 2013-04-01 |  |  |  |
| 948 | 6.7.2 | Move spectrometer #1 to parked position |  | 2d | 2014-02-05 | 2014-02-06 | 947 |  |  |  | 0d |  |  |  |  |
| 949 | 6.7.3 | Move AFC#1to parked position |  | 2d | 2014-02-07 | 2014-02-10 | 948 |  |  |  | 0d |  |  |  |  |
| 950 | 6.7.4 | Move RFCC #1 to parked position |  | 2d | 2014-02-11 | 2014-02-12 | 949 |  |  |  | 0d |  |  |  |  |
| 951 | 6.7.5 | Move AFC#2 to parked position |  | 1d | 2014-02-13 | 2014-02-13 | 950 |  |  |  | 0d |  |  |  |  |
| 952 | 6.7.6 | Remove spectrometer #2 |  | 1d | 2014-02-14 | 2014-02-14 | 951 |  |  |  | 0d |  |  |  |  |
| 953 | 6.7.7 | **Base plate installation** |  | 49d | 2014-02-14 | 2014-04-24 |  |  |  |  | 0d |  |  |  | 27,000 |
| 954 | 6.7.7.1 | Procure Aluminium plates for the false floor intermediate surface | milestone | 0d | 2014-02-14 | 2014-02-14 | 952 |  |  |  | 0d | start no earlier than 2013-04-01 |  |  | 14,000 |
| 955 | 6.7.7.2 | Remove step V false floor plates under spectrometer #2 |  | 2d | 2014-02-17 | 2014-02-18 | 954 |  |  |  | 0d |  |  |  |  |
| 956 | 6.7.7.3 | Fit intermediate surface (tiled aluminium plates) for the false floor step VI position |  | 5d | 2014-02-19 | 2014-02-25 | 955 |  |  |  | 0d |  |  |  |  |
| 957 | 6.7.7.4 | Trial RFCC #1 base plate Installation including survey and marking out |  | 2d | 2014-02-26 | 2014-02-27 | 956 |  |  |  | 0d |  |  |  | 2,000 |
| 958 | 6.7.7.5 | Drill and tap threaded holes in the false floor intermediate surface |  | 3d | 2014-02-28 | 2014-03-04 | 957 |  |  |  | 0d |  |  |  |  |
| 959 | 6.7.7.6 | Create level surface with washers at bolt locations (survey level) |  | 5d | 2014-03-05 | 2014-03-11 | 958 |  |  |  | 0d |  |  |  | 2,000 |
| 960 | 6.7.7.7 | Re-Install base plate |  | 2d | 2014-03-12 | 2014-03-13 | 959 |  |  |  | 0d |  |  |  |  |
| 961 | 6.7.7.8 | Install through bolts and survey, level and tighten the complete arrangement |  | 3d | 2014-03-14 | 2014-03-18 | 960 |  |  |  | 0d |  |  |  |  |
| 962 | 6.7.7.9 | Trial AFC #2 base plate installation including survey and marking out |  | 3d | 2014-03-19 | 2014-03-21 | 961 |  |  |  | 0d |  |  |  | 2,000 |
| 963 | 6.7.7.10 | Drill and tap threaded holes in the false floor intermediate surface |  | 3d | 2014-03-24 | 2014-03-26 | 962 |  |  |  | 0d |  |  |  |  |
| 964 | 6.7.7.11 | Create level surface with washers at bolt locations (survey level) |  | 2d | 2014-03-27 | 2014-03-28 | 963 |  |  |  | 0d |  |  |  | 2,000 |
| 965 | 6.7.7.12 | Re-Install base plate |  | 2d | 2014-03-31 | 2014-04-01 | 964 |  |  |  | 0d |  |  |  |  |
| 966 | 6.7.7.13 | Install through bolts and survey, level and tighten the complete arrangement |  | 2d | 2014-04-02 | 2014-04-03 | 965 |  |  |  | 0d |  |  |  | 2,000 |
| 967 | 6.7.7.14 | Trial spectrometer #2 base plate Installation including survey and marking out |  | 3d | 2014-04-04 | 2014-04-08 | 966 |  |  |  | 0d |  |  |  |  |
| 968 | 6.7.7.15 | Drill and tap threaded holes in the false floor intermediate surface |  | 3d | 2014-04-09 | 2014-04-11 | 967 |  |  |  | 0d |  |  |  |  |
| 969 | 6.7.7.16 | Create level surface with washers at bolt locations (survey level) |  | 3d | 2014-04-14 | 2014-04-16 | 968 |  |  |  | 0d |  |  |  | 2,000 |
| 970 | 6.7.7.17 | Re-Install base plate |  | 2d | 2014-04-17 | 2014-04-18 | 969 |  |  |  | 0d |  |  |  |  |
| 971 | 6.7.7.18 | Grout in base plate |  | 1d | 2014-04-21 | 2014-04-21 | 970 |  |  |  | 0d |  |  |  |  |
| 972 | 6.7.7.19 | Install through bolts and survey, level and tighten the complete arrangement |  | 3d | 2014-04-22 | 2014-04-24 | 971 |  |  |  | 0d |  |  |  | 1,000 |

| ID | WBS | Task | Type | Duration | Start | Finish | Predecessors | Baseline start | Baseline finish | Baseline duration | Total slack | Constraint |
| --- | --- | --- | --- | --- | --- | --- | --- | --- | --- | --- | --- | --- |
| 973 | 6.7.8 | **RFCC #2 Installation** |  | 92d | 2014-04-25 | 2014-09-01 |  |  |  |  | 0d |  |
| 974 | 6.7.8.1 | Install RFFC #2 rail system |  | 2d | 2014-04-25 | 2014-04-28 | 972 |  |  |  | 0d |  |
| 975 | 6.7.8.2 | Install RFFC #2 supports to floor |  | 5d | 2014-04-29 | 2014-05-05 | 974 | 2010-02-22 | 2010-02-26 | 5d | 0d | finish no earlier than 2010-02-26 |
| 976 | 6.7.8.3 | Install RFFC module #2 and align |  | 5d | 2014-05-06 | 2014-05-12 | 975 | 2010-04-09 | 2010-04-12 | 2d | 0d | start no earlier than 2010-03-01 |
| 977 | 6.7.8.4 | Cooldown RFFC #2 |  | 20d | 2014-05-13 | 2014-06-09 | 976 |  |  |  | 0d |  |
| 978 | 6.7.8.5 | RFFC magnet test period |  | 20d | 2014-06-10 | 2014-07-07 | 977 | 2010-04-26 | 2010-05-21 | 20d | 0d | start no earlier than 2010-04-26 |
| 979 | 6.7.8.6 | Connect RF wave guides |  | 15d | 2014-07-08 | 2014-07-28 | 978 | 2010-05-24 | 2010-05-25 | 2d | 0d |  |
| 980 | 6.7.8.7 | RF Amplifier test period |  | 10d | 2014-07-29 | 2014-08-11 | 979 |  |  |  | 0d |  |
| 981 | 6.7.8.8 | RFFC absorber test period |  | 15d | 2014-08-12 | 2014-09-01 | 980 |  |  |  | 0d |  |
| 982 | 6.7.9 | **AFC #3 Installation** |  | 94d | 2014-09-02 | 2015-01-09 |  | 2009-12-01 | 2011-03-31 | 348d? | 0d |  |
| 983 | 6.7.9.1 | Install AFC #3 rail system |  | 2d | 2014-09-02 | 2014-09-03 | 981 |  |  |  | 0d |  |
| 984 | 6.7.9.2 | Install AFC #3 supports to floor |  | 5d | 2014-09-04 | 2014-09-10 | 983 | 2010-02-22 | 2010-02-26 | 5d | 0d | finish no earlier than 2010-02-26 |
| 985 | 6.7.9.3 | Install AFC #3 module and align |  | 5d | 2014-09-11 | 2014-09-17 | 984 | 2010-04-09 | 2010-04-12 | 2d | 0d | start no earlier than 2010-03-01 |
| 986 | 6.7.9.4 | Cooldown AFC #3 |  | 20d | 2014-09-18 | 2014-10-15 | 985 |  |  |  | 0d |  |
| 987 | 6.7.9.5 | AFC #3 magnet test period |  | 20d | 2014-10-16 | 2014-11-12 | 986 | 2010-04-26 | 2010-05-21 | 20d | 0d | start no earlier than 2010-04-26 |
| 988 | 6.7.9.6 | Connect R&D LH2 system |  | 5d | 2014-11-13 | 2014-11-19 | 987 | 2010-05-24 | 2010-05-25 | 2d | 0d |  |
| 989 | 6.7.9.7 | **AFC #3 LiH2 Absorber installation** |  | 37d | 2014-11-20 | 2015-01-09 |  |  |  |  | 0d |  |
| 990 | 6.7.9.7.1 | Movel AFC #3 into parked position |  | 1d | 2014-11-20 | 2014-11-20 | 988 |  |  |  | 0d |  |
| 991 | 6.7.9.7.2 | Remove AFC outer vacuum windows |  | 1d | 2014-11-21 | 2014-11-21 | 990 |  |  |  | 0d |  |
| 992 | 6.7.9.7.3 | Insert absorber and fit mountings |  | 3d | 2014-11-24 | 2014-11-26 | 991 |  |  |  | 0d |  |
| 993 | 6.7.9.7.4 | Make gas connections |  | 1d | 2014-11-27 | 2014-11-27 | 992 |  |  |  | 0d |  |
| 994 | 6.7.9.7.5 | Make electrical connections |  | 2d | 2014-11-28 | 2014-12-01 | 993 |  |  |  | 0d |  |
| 995 | 6.7.9.7.6 | Re-fit outer vacuum windows and fit bellows |  | 2d | 2014-12-02 | 2014-12-03 | 994 |  |  |  | 0d |  |
| 996 | 6.7.9.7.7 | Return module to beamline position |  | 1d | 2014-12-04 | 2014-12-04 | 995 |  |  |  | 0d |  |
| 997 | 6.7.9.7.8 | Connect H2 transfer line, crycooler lines and vacuum/relief line |  | 1d | 2014-12-05 | 2014-12-05 | 996 |  |  |  | 0d |  |
| 998 | 6.7.9.7.9 | Pump down vacuum spaces |  | 3d | 2014-12-08 | 2014-12-10 | 997 |  |  |  | 0d |  |
| 999 | 6.7.9.7.10 | Leak check vacuum spaces |  | 1d | 2014-12-11 | 2014-12-11 | 998 |  |  |  | 0d |  |
| 1000 | 6.7.9.7.11 | Leak check cryocooler circuit |  | 1d | 2014-12-12 | 2014-12-12 | 999 |  |  |  | 0d |  |
| 1001 | 6.7.9.7.12 | Cool down of magnet and absorber |  | 10d | 2014-12-15 | 2014-12-26 | 1000 |  |  |  | 0d |  |
| 1002 | 6.7.9.7.13 | LiH2 Absorber test period |  | 10d | 2014-12-29 | 2015-01-09 | 1001 |  |  |  | 0d |  |
| 1003 | 6.7.10 | Spectrometer Solenoid #2 Installation |  | 15d | 2015-01-12 | 2015-01-30 | 1002 |  |  |  | 0d |  |
| 1004 | 6.7.11 | Re-install TOF2, KL & EMR |  | 5d | 2015-02-02 | 2015-02-06 | 1003 | 2010-06-01 | 2010-06-14 | 10d? | 0d | finish no earlier than 2010-03-12 |
| 1005 | 6.7.12 | MICE step VI installation complete | milestone | 0d | 2015-02-06 | 2015-02-06 | 1004 | 2010-06-15 | 2010-06-15 | 0d | 0d | start no earlier than 2010-05-07 |

| ID | WBS | Task | Duration | Start | Finish | Predecessors | Remaining | Total slack | Free slack | Resources | Work | Actual work | Cost |
| --- | --- | --- | --- | --- | --- | --- | --- | --- | --- | --- | --- | --- | --- |
| 1007 | 7 | **Commissioing** | 955d | 2011-05-19 | 2015-04-03 |  |  | 0d |  | Commissioning | 16368h | 647.25h | 101,378.48 |
| 1008 | 7.1 | **Hydrogen System Commissioning** | 729d | 2011-05-19 A | 2014-05-22 |  | 729d | 192d |  | Hydrogen System | 7472h | 647.25h | 101,378.48 |
| 1009 | 7.1.1 | **R&D Tests** | 39d | 2011-05-19 | 2011-08-22 | 540 |  | 101d | 0d |  | 624h |  | 33,224.88 |
| 1010 | 7.1.1.1 | **Helium Tests** | 25d | 2011-05-19 | 2011-06-22 |  |  | 101d | 0d |  | 400h |  | 21,298 |
| 1011 | 7.1.1.1.1 | Check instrumentation | 3d | 2011-05-19 | 2011-05-23 |  |  | 135d | 0d | Mike Courthold; Matt Hills | 48h |  | 2,555.76 |
| 1012 | 7.1.1.1.2 | Pump and purge | 2d | 2011-05-24 | 2011-05-25 | 1011 |  | 135d | 0d | Mike Courthold; Matt Hills | 32h |  | 1,703.84 |
| 1013 | 7.1.1.1.3 | Check relief valve settings | 1d | 2011-05-26 | 2011-05-26 | 1012 |  | 135d | 0d | Matt Hills; Mike Courthold | 16h |  | 851.92 |
| 1014 | 7.1.1.1.4 | Check cryocooler operation at LH2 and LHe temperatures | 4d | 2011-05-27 | 2011-06-01 | 1013 |  | 135d | 0d | Mike Courthold; Matt Hills | 64h |  | 3,407.68 |
| 1015 | 7.1.1.1.5 | Liquify helium in the cryostat | 4d | 2011-06-02 | 2011-06-07 | 1014 |  | 135d | 0d | Mike Courthold; Matt Hills | 64h |  | 3,407.68 |
| 1016 | 7.1.1.1.6 | Test emptying sequence | 1d | 2011-06-08 | 2011-06-08 | 1015 |  | 135d | 0d | Mike Courthold; Matt Hills | 16h |  | 851.92 |
| 1017 | 7.1.1.1.7 | Thermal cycling to check for leaks from thermal stresses | 10d | 2011-06-09 | 2011-06-22 | 1016 |  | 135d |  | Mike Courthold; Matt Hills | 160h |  | 8,519.2 |
| 1018 | 7.1.1.2 | **Hydrogen Tests** | 14d | 2011-06-23 | 2011-08-22 | 1010 |  | 101d |  |  | 224h |  | 11,926.88 |
| 1019 | 7.1.1.2.1 | Liquify hydrogen in the cryostat | 3d | 2011-06-23 | 2011-06-27 | 1010 |  | 135d | 0d | Mike Courthold; Matt Hills | 48h |  | 2,555.76 |
| 1020 | 7.1.1.2.2 | Check empty and purge sequence | 2d | 2011-06-28 | 2011-06-29 | 1019 |  | 135d | 0d | Mike Courthold; Matt Hills | 32h |  | 1,703.84 |
| 1021 | 7.1.1.2.3 | Tests to determine effects of using Helium top-up gas | 5d | 2011-06-30 | 2011-08-16 | 1020 |  | 135d | 0d | Mike Courthold; Matt Hills | 80h |  | 4,259.6 |
| 1022 | 7.1.1.2.4 | Check alarms and interlocks | 2d | 2011-08-17 | 2011-08-18 | 1021 |  | 135d | 0d | Mike Courthold; Matt Hills | 32h |  | 1,703.84 |
| 1023 | 7.1.1.2.5 | Measure H2 desorption rate | 2d | 2011-08-19 | 2011-08-22 | 1022 |  | 135d |  | Mike Courthold; Matt Hills | 32h |  | 1,703.84 |
| 1024 | 7.1.2 | **Hydrogen system B Commissioning (with AFC)** | 39d | 2013-04-18 | 2013-06-11 | 558, 568 |  | 439d | 0d |  | 624h |  | 33,224.88 |
| 1025 | 7.1.2.1 | **Helium Tests** | 25d | 2013-04-18 | 2013-05-22 |  |  | 439d | 0d |  | 400h |  | 21,298 |
| 1026 | 7.1.2.1.1 | Check instrumentation | 3d | 2013-04-18 | 2013-04-22 |  |  | 473d | 0d | Mike Courthold; Matt Hills | 48h |  | 2,555.76 |
| 1027 | 7.1.2.1.2 | Pump and purge | 2d | 2013-04-23 | 2013-04-24 | 1026 |  | 473d | 0d | Mike Courthold; Matt Hills | 32h |  | 1,703.84 |
| 1028 | 7.1.2.1.3 | Check relief valve settings | 1d | 2013-04-25 | 2013-04-25 | 1027 |  | 473d | 0d | Matt Hills; Mike Courthold | 16h |  | 851.92 |
| 1029 | 7.1.2.1.4 | Check cryocooler operation at LH2 and LHe temperatures | 4d | 2013-04-26 | 2013-05-01 | 1028 |  | 473d | 0d | Mike Courthold; Matt Hills | 64h |  | 3,407.68 |
| 1030 | 7.1.2.1.5 | Liquify helium in the cryostat | 4d | 2013-05-02 | 2013-05-07 | 1029 |  | 473d | 0d | Mike Courthold; Matt Hills | 64h |  | 3,407.68 |
| 1031 | 7.1.2.1.6 | Test emptying sequence | 1d | 2013-05-08 | 2013-05-08 | 1030 |  | 473d | 0d | Mike Courthold; Matt Hills | 16h |  | 851.92 |
| 1032 | 7.1.2.1.7 | Thermal cycling to check for leaks from thermal stresses | 10d | 2013-05-09 | 2013-05-22 | 1031 |  | 473d |  | Mike Courthold; Matt Hills | 160h |  | 8,519.2 |

Notes:
- 1023: Fill cryostat completely from Hydride Bed

| ID | WBS | Task | Duration | Start | Finish | Predecessors | Total slack | Free slack | Resources | Work | Cost |
| --- | --- | --- | --- | --- | --- | --- | --- | --- | --- | --- | --- |
| 1033 | 7.1.2.2 | **Hydrogen Tests** | 14d | 2013-05-23 | 2013-06-11 | 1025 | 439d |  |  | 224h | 11,926.88 |
| 1034 | 7.1.2.2.1 | Liquify hydrogen in the cryostat | 3d | 2013-05-23 | 2013-05-27 | 1025 | 473d | 0d | Mike Courthold; Matt Hills | 48h | 2,555.76 |
| 1035 | 7.1.2.2.2 | Check empty and purge sequence | 2d | 2013-05-28 | 2013-05-29 | 1034 | 473d | 0d | Mike Courthold; Matt Hills | 32h | 1,703.84 |
| 1036 | 7.1.2.2.3 | Tests to determine effects of using Helium top-up gas | 5d | 2013-05-30 | 2013-06-05 | 1035 | 473d | 0d | Mike Courthold; Matt Hills | 80h | 4,259.6 |
| 1037 | 7.1.2.2.4 | Check alarms and interlocks | 2d | 2013-06-06 | 2013-06-07 | 1036 | 473d | 0d | Mike Courthold; Matt Hills | 32h | 1,703.84 |
| 1038 | 7.1.2.2.5 | Measure H2 desorption rate | 2d | 2013-06-10 | 2013-06-11 | 1037 | 473d |  | Mike Courthold; Matt Hills | 32h | 1,703.84 |
| 1039 | 7.1.3 | **Hydrogen system C Commissioning (with AFC)** | 41d | 2014-03-27 | 2014-05-22 | 578, 588 | 192d | 0d |  | 656h | 34,928.72 |
| 1040 | 7.1.3.1 | **Helium Tests** | 25d | 2014-03-27 | 2014-04-30 |  | 192d | 0d |  | 400h | 21,298 |
| 1041 | 7.1.3.1.1 | Check instrumentation | 3d | 2014-03-27 | 2014-03-31 |  | 226d | 0d | Mike Courthold; Matt Hills | 48h | 2,555.76 |
| 1042 | 7.1.3.1.2 | Pump and purge | 2d | 2014-04-01 | 2014-04-02 | 1041 | 226d | 0d | Mike Courthold; Matt Hills | 32h | 1,703.84 |
| 1043 | 7.1.3.1.3 | Check relief valve settings | 1d | 2014-04-03 | 2014-04-03 | 1042 | 226d | 0d | Matt Hills; Mike Courthold | 16h | 851.92 |
| 1044 | 7.1.3.1.4 | Check cryocooler operation at LH2 and LHe temperatures | 4d | 2014-04-04 | 2014-04-09 | 1043 | 226d | 0d | Mike Courthold; Matt Hills | 64h | 3,407.68 |
| 1045 | 7.1.3.1.5 | Liquify helium in the cryostat | 4d | 2014-04-10 | 2014-04-15 | 1044 | 226d | 0d | Mike Courthold; Matt Hills | 64h | 3,407.68 |
| 1046 | 7.1.3.1.6 | Test emptying sequence | 1d | 2014-04-16 | 2014-04-16 | 1045 | 226d | 0d | Mike Courthold; Matt Hills | 16h | 851.92 |
| 1047 | 7.1.3.1.7 | Thermal cycling to check for leaks from thermal stresses | 10d | 2014-04-17 | 2014-04-30 | 1046 | 226d |  | Mike Courthold; Matt Hills | 160h | 8,519.2 |
| 1048 | 7.1.3.2 | **Hydrogen Tests** | 16d | 2014-05-01 | 2014-05-22 | 1040 | 192d |  |  | 256h | 13,630.72 |
| 1049 | 7.1.3.2.1 | Liquify hydrogen in the cryostat | 3d | 2014-05-01 | 2014-05-05 | 1040 | 226d | 0d | Mike Courthold; Matt Hills | 48h | 2,555.76 |
| 1050 | 7.1.3.2.2 | Check empty and purge sequence | 2d | 2014-05-06 | 2014-05-07 | 1049 | 226d | 0d | Mike Courthold; Matt Hills | 32h | 1,703.84 |
| 1051 | 7.1.3.2.3 | Tests to determine effects of using Helium top-up gas | 5d | 2014-05-08 | 2014-05-14 | 1050 | 226d | 0d | Mike Courthold; Matt Hills | 80h | 4,259.6 |
| 1052 | 7.1.3.2.4 | Check alarms and interlocks | 2d | 2014-05-15 | 2014-05-16 | 1051 | 226d | 0d | Mike Courthold; Matt Hills | 32h | 1,703.84 |
| 1053 | 7.1.3.2.5 | Measure H2 desorption rate | 2d | 2014-05-19 | 2014-05-20 | 1052 | 226d | 0d | Mike Courthold; Matt Hills | 32h | 1,703.84 |
| 1054 | 7.1.3.2.6 | Measure H2 absorption rate | 2d | 2014-05-21 | 2014-05-22 | 1053 | 226d |  | Mike Courthold; Matt Hills | 32h | 1,703.84 |
| 1055 | 7.2 | **RF Commissioning** | 274.73d | 2012-06-19 | 2013-07-09 |  | 419.73d |  | RF System | 296h |  |
| 1056 | 7.2.1 | Commission RF system #1 | 37d | 2012-06-19 | 2012-08-09 | 702, 785, 788 | 691.45d |  | STEP V - TIARA | 296h |  |
| 1057 | 7.2.2 | Commission RF system #2 | 37d | 2013-05-17 | 2013-07-09 | 738, 779, 791, 794 | 453.73d |  |  |  |  |

Notes:
- 1038: Fill cryostat completely from Hydride Bed
- 1053: Fill cryostat completely from Hydride Bed
- 1054: Empty full cryostat back to Hydride Bed.

| ID | WBS | Task | Type | Duration | Start | Finish | Predecessors | Baseline start | Baseline finish | Baseline duration | Total slack | Resources | Work |
| --- | --- | --- | --- | --- | --- | --- | --- | --- | --- | --- | --- | --- | --- |
| 1058 | 7.3 | **MICE Step IV Commissioning** |  | 40d | 2012-10-08 | 2012-11-30 |  |  |  |  | 0d | Step IV | 320h |
| 1059 | 7.3.1 | Step IV Detector commissioning |  | 40d | 2012-10-08 | 2012-11-30 | 887 | 2010-06-01 | 2010-06-15 | 11d? | 0d |  |  |
| 1060 | 7.3.2 | Step IV Detector commissioning Complete | milestone | 0d | 2012-11-30 | 2012-11-30 | 1059 | 2010-06-01 | 2010-06-15 | 11d? | 0d |  |  |
| 1061 | 7.4 | **MICE Step V Commissioning** |  | 40d | 2013-12-09 | 2014-01-31 |  |  |  |  | 0d | Step V | 320h |
| 1062 | 7.4.1 | Step V Detector commissioning |  | 40d | 2013-12-09 | 2014-01-31 | 945 | 2010-06-01 | 2010-06-15 | 11d? | 0d |  |  |
| 1063 | 7.4.2 | Step V Detector commissioning Complete | milestone | 0d | 2014-01-31 | 2014-01-31 | 1062 | 2010-06-01 | 2010-06-15 | 11d? | 0d |  |  |
| 1064 | 7.5 | **MICE Step VI Commissioning** |  | 40d | 2015-02-09 | 2015-04-03 |  |  |  |  | 0d | Step VI | 320h |
| 1065 | 7.5.1 | Step VI Detector commissioning |  | 40d | 2015-02-09 | 2015-04-03 | 1005 | 2010-06-01 | 2010-06-15 | 11d? | 0d |  |  |
| 1066 | 7.5.2 | Step VI Detector commissioning Complete | milestone | 0d | 2015-04-03 | 2015-04-03 | 1065 | 2010-06-01 | 2010-06-15 | 11d? | 0d |  |  |
